# PM Obra De Ampliación Aumento De Capacidad Línea 2x220KV Encuentro – Kimal 21_185_OA_02

Schedule from MS Project, 2023-03-01 to 2026-01-11, status date 2025-09-20, 9 hours a day, A marks actual dates.
Alstom

## Calendars

- ENKI - Días corridos: Mon-Sun 08:00-13:00, 14:00-18:00.
- ENKI - Días habiles: Mon-Fri 08:00-13:00, 14:00-18:00; Sat-Sun off.
- ENKI - ELECNOR L_S: Mon off; Tue-Sat 08:00-13:00, 14:00-18:00; Sun off. Exceptions (off unless hours are given): 2024-12-21 to 2025-01-01 (Navidad), 2025-09-18 to 2025-09-20 (fechas patrias).

## Resources

| Resource |
| --- |
| General |
| PC12. Supervisor de Programacion y calidad |
| Diagrama unilineal funcional (DUF) |
| Plano de disposición de equipos eléctricos (DEE) |
| Plano de disposición general de instalaciones (DGI) |
| Hojas Técnicas de Características Garantizadas (HCTG) |
| Estudio de Cortocircuito y Verificación de Capacidad de Interruptores |
| Estudio de Coordinación de Aislamiento |
| Estudio de Capacidad Barras |
| Estudio de Diseño y Capacidad de Malla a Tierra |
| Estudio de Saturación Magnética de los TT/CC |
| Estudio de Desbalance de Tensiones |
| Estudios de Voltajes Transitorios de Recuperación |
| Ingeniería Electromecánica |
| Ingeniería Civil |
| Control y Protecciones |
| Telecomunicaciones |
| Topografia |
| Campaña geotecnica |
| Resistencia del suelo |
| Meteorológico |
| Hidrológicos |
| Geotécnicos (Mecánica de suelos) |
| Topografo |
| Ayudante Topografia |
| Operador Retro |
| Operador Grua movil |
| Oficial. Obra civil |
| Ayudante. Obra civil |
| Peon |
| Maquinista |
| Ingeniero Electrico |
| Tecnicos electricistas |
| Ingeniero Sistemas |
| Tecnico sistemas |

## Schedule

| ID | WBS | Task | Type | Duration | Start | Finish | Predecessors | Complete | Remaining | Baseline start | Baseline finish | Baseline duration | Baseline 1 start | Baseline 1 finish | Total slack | Free slack | Constraint | Work | Actual work | Propietario | Baseline Star Rev1 | Baseline Finish Rev1 | Baseline Duration Rev1 | % Complete Peso | % Baseline Peso | % Baseline (Tempo) | : | Text11 |
| --- | --- | --- | --- | --- | --- | --- | --- | --- | --- | --- | --- | --- | --- | --- | --- | --- | --- | --- | --- | --- | --- | --- | --- | --- | --- | --- | --- | --- |
| 1 | 1 | **SE ENCUENTRO 220kV (TRANSELEC)** |  | 1048d | 2023-03-01 A | 2026-01-11 |  | 94% | 62.02d | 2023-03-01 | 2026-01-11 | 1048d | 2023-03-01 | 2025-09-02 | 0d |  |  | 52173h | 42323.2h | TRANSELEC | 01-03-2023 | 02-09-2025 | 917 días | 80,77% | 80,40% | 89% |  |  |
| 2 | 1.1 | **HI - HITOS** |  | 1048d | 2023-03-01 | 2026-01-11 |  |  |  | 2023-03-01 | 2026-01-11 | 1048d | 2023-03-01 | 2025-09-02 | 0d |  |  |  |  | TRANSELEC | 01-03-2023 | 02-09-2025 | 917 días | 0,00% | 0,00% | 89% | 00 HI - HITOS |  |
| 3 | 1.1.1 | **Hitos Generales** |  | 1021d | 2023-03-01 | 2025-12-15 |  |  |  | 2023-03-01 | 2025-12-15 | 1021d | 2023-03-01 | 2025-09-02 | 5d |  |  |  |  | TRANSELEC | 01-03-2023 | 02-09-2025 | 917 días | 0,00% | 0,00% | 91% | 00 HI - HITOS |  |
| 4 | 1.1.1.1 | Publicación en el Diario Oficial del Decreto de Adjudicación | milestone | 0d | 2023-03-01 | 2023-03-01 |  |  |  | 2023-03-01 | 2023-03-01 | 0d | 2023-03-01 | 2023-03-01 | 5d | 0d |  |  |  | TRANSELEC | 01-03-2023 | 01-03-2023 | 0 días | 0,00% | 100,00% | 100% | 00 HI - HITOS | día 1 |
| 5 | 1.1.1.2 | Día siguiente a la fecha de publicación en el Diario Oficial del Decreto de Adjudicación | milestone | 0d | 2023-03-02 | 2023-03-02 | 4FS+2d |  |  | 2023-03-02 | 2023-03-02 | 0d | 2023-03-02 | 2023-03-02 | 5d | 0d |  |  |  | TRANSELEC | 02-03-2023 | 02-03-2023 | 0 días | 0,00% | 100,00% | 100% | 00 HI - HITOS | día 3,25 |
| 6 | 1.1.1.3 | Firma del Contrato con Propietario | milestone | 0d | 2023-03-16 | 2023-03-16 | 5FS+14d |  |  | 2023-03-16 | 2023-03-16 | 0d | 2023-03-16 | 2023-03-16 | 950d | 0d |  |  |  | TRANSELEC | 16-03-2023 | 16-03-2023 | 0 días | 0,00% | 100,00% | 100% | 00 HI - HITOS | día 19 |
| 7 | 1.1.1.4 | Emisión de Boleta de Garantia | milestone | 0d | 2023-03-16 | 2023-03-16 | 5FS+14d |  |  | 2023-03-16 | 2023-03-16 | 0d | 2023-03-16 | 2023-03-16 | 1032d |  |  |  |  | TRANSELEC | 16-03-2023 | 16-03-2023 | 0 días | 0,00% | 100,00% | 100% | 00 HI - HITOS | día 19 |
| 8 | 1.1.1.5 | Entrega de Programa Maestro del Contrato | milestone | 0d | 2023-04-01 | 2023-04-01 | 5FS+30d |  |  | 2023-04-01 | 2023-04-01 | 0d | 2023-04-01 | 2023-04-01 | 844d | 0d |  |  |  | TRANSELEC | 01-04-2023 | 01-04-2023 | 0 días | 0,00% | 100,00% | 100% | 00 HI - HITOS | día 37 |
| 9 | 1.1.1.6 | Entrega de Lista de Entregables de Ingeniería | milestone | 0d | 2023-04-01 | 2023-04-01 | 5FS+30d |  |  | 2023-04-01 | 2023-04-01 | 0d | 2023-04-01 | 2023-04-01 | 844d | 0d |  |  |  | TRANSELEC | 01-04-2023 | 01-04-2023 | 0 días | 0,00% | 100,00% | 100% | 00 HI - HITOS | día 37 |
| 10 | 1.1.1.7 | Acceso sin restricción al terreno para realización de estudios de diseño | milestone | 0d | 2023-05-02 | 2023-05-02 | 62SS |  |  | 2023-05-02 | 2023-05-02 | 0d | 2023-05-02 | 2023-05-02 | 986d |  |  |  |  | TRANSELEC | 02-05-2023 | 02-05-2023 | 0 días | 0,00% | 100,00% | 100% | 00 HI - HITOS | día 70,75 |
| 11 | 1.1.1.8 | Revisión y Aprobación del Programa Maestro del Contrato y Lista de Entregables de Ingeniería | milestone | 0d | 2023-06-30 | 2023-06-30 | 8FS+90d, 9FS+90d |  |  | 2023-06-30 | 2023-06-30 | 0d | 2023-06-30 | 2023-06-30 | 844d | 0d |  |  |  | TRANSELEC | 30-06-2023 | 30-06-2023 | 0 días | 0,00% | 100,00% | 100% | 00 HI - HITOS | día 138,25 |
| 12 | 1.1.1.9 | Contratación de seguros | milestone | 0d | 2024-11-14 | 2024-11-14 | 124FS-15d |  |  | 2024-11-14 | 2024-11-14 | 0d | 2024-09-18 | 2024-09-18 | 424d |  |  |  |  | TRANSELEC | 14-11-2024 | 14-11-2024 | 0 días | 0,00% | 100,00% | 100% | 00 HI - HITOS | día 703 |
| 13 | 1.1.1.10 | Presentación Ofertas ITO al Coordinador | milestone | 0d | 2024-06-24 | 2024-06-24 | 75 |  |  | 2024-06-24 | 2024-06-24 | 0d | 2024-06-24 | 2024-06-24 | 566d |  |  |  |  | TRANSELEC | 24-06-2024 | 24-06-2024 | 0 días | 0,00% | 100,00% | 100% | 00 HI - HITOS | día 543,25 |
| 14 | 1.1.1.11 | Firma Contrato con ITO designado | milestone | 0d | 2024-09-08 | 2024-09-08 | 77 |  |  | 2024-09-08 | 2024-09-08 | 0d | 2024-09-07 | 2024-09-07 | 490d |  |  |  |  | TRANSELEC | 08-09-2024 | 08-09-2024 | 0 días | 0,00% | 100,00% | 100% | 00 HI - HITOS | día 628,75 |
| 15 | 1.1.1.12 | Taller de constructibilidad | milestone | 0d | 2025-02-19 | 2025-02-19 | 125 |  |  | 2025-02-19 | 2025-02-19 | 0d | 2024-08-19 | 2024-08-19 | 326d |  |  |  |  | TRANSELEC | 11-01-2025 | 11-01-2025 | 0 días | 0,00% | 100,00% | 100% | 00 HI - HITOS | día 813,25 |
| 16 | 1.1.1.13 | Taller de riesgo | milestone | 0d | 2025-02-19 | 2025-02-19 | 125 |  |  | 2025-02-19 | 2025-02-19 | 0d | 2024-08-19 | 2024-08-19 | 326d |  |  |  |  | TRANSELEC | 11-01-2025 | 11-01-2025 | 0 días | 0,00% | 100,00% | 100% | 00 HI - HITOS | día 813,25 |
| 17 | 1.1.1.14 | Recepción del Acta de Entrega de Terreno | milestone | 0d | 2024-11-29 | 2024-11-29 | 124 |  |  | 2024-11-29 | 2024-11-29 | 0d | 2024-10-02 | 2024-10-02 | 409d |  |  |  |  | TRANSELEC | 29-11-2024 | 29-11-2024 | 0 días | 0,00% | 100,00% | 100% | 00 HI - HITOS | día 719,875 |
| 18 | 1.1.1.15 | Término comisionamiento del transformadores de medida, seccionadores, etc. | milestone | 0d | 2025-12-13 | 2025-12-13 | 264 |  |  | 2025-12-13 | 2025-12-13 | 0d | 2025-07-18 | 2025-07-18 | 29d |  |  |  |  | TRANSELEC | 12-08-2025 | 12-08-2025 | 0 días | 0,00% | 0,00% | 0% | 00 HI - HITOS | día 1147,375 |
| 19 | 1.1.1.16 | Solicitud de conexión al Coordinador Eléctrico Nacional de acuerdo a lo indicado en el Anexo Técnico Requisitos Técnicos Mínimos de Instalaciones que se conectan al SI, de la NTSyCS, según se establece en numeral 2 romanillos xi o xii | milestone | 0d | 2024-08-12 | 2024-08-12 | 508SS, 268SS |  |  | 2024-08-12 | 2024-08-12 | 0d | 2024-08-12 | 2024-08-12 | 518d |  |  |  |  | TRANSELEC | 12-08-2024 | 12-08-2024 | 0 días | 0,00% | 100,00% | 100% | 00 HI - HITOS | día 597,25 |
| 20 | 1.1.1.17 | Entrada en Operación de la Obra | milestone | 0d | 2025-12-15 | 2025-12-15 | 615, 411 |  |  | 2025-12-15 | 2025-12-15 | 0d | 2025-09-02 | 2025-09-02 | 27d |  |  |  |  | TRANSELEC | 02-09-2025 | 02-09-2025 | 0 días | 0,00% | 0,00% | 0% | 00 HI - HITOS | día 1149,625 |
| 21 | 1.1.1.18 | Entrega AS BUILT (Información) por parte del Coordinador, de las Subestaciones Colindantes | milestone | 0d | 2023-03-26 | 2023-03-26 | 6FS+10d |  |  | 2023-03-26 | 2023-03-26 | 0d | 2023-03-26 | 2023-03-26 | 1022d |  |  |  |  | TRANSELEC | 26-03-2023 | 26-03-2023 | 0 días | 0,00% | 100,00% | 100% | 00 HI - HITOS | día 30,25 |
| 22 | 1.1.1.19 | Entrega de Formulario Unico de Ingreso (F.U.I.) | milestone | 0d | 2025-12-11 | 2025-12-11 | 263FS+20d |  |  | 2025-12-11 | 2025-12-11 | 0d | 2023-03-26 | 2023-03-26 | 31d |  |  |  |  | TRANSELEC | 26-03-2023 | 26-03-2023 | 0 días | 0,00% | 0,00% | 0% | 00 HI - HITOS | día 1145,125 |
| 23 | 1.1.2 | **Hitos de Pago** |  | 924d | 2023-06-30 | 2026-01-09 |  |  |  | 2023-06-30 | 2026-01-09 | 924d | 2023-06-30 | 2025-09-02 | 2d |  |  |  |  | TRANSELEC | 30-06-2023 | 02-09-2025 | 795 días | 0,00% | 0,00% | 87% | 00 HI - HITOS |  |
| 24 | 1.1.2.1 | (Hito de Pago N°1) Aprobación Programa Maestro y Lista de entregables de Ingeniería | milestone | 0d | 2023-06-30 | 2023-06-30 | 6, 11 |  |  | 2023-06-30 | 2023-06-30 | 0d | 2023-06-30 | 2023-06-30 | 844d | 0d |  |  |  | TRANSELEC | 30-06-2023 | 30-06-2023 | 0 días | 0,00% | 100,00% | 100% | 00 HI - HITOS | día 138,25 |
| 25 | 1.1.2.2 | (Hito de Pago N°2) Revisión y Aprobación de Ingeniería Básica | milestone | 0d | 2024-02-15 | 2024-02-15 | 37FS+15d |  |  | 2024-02-15 | 2024-02-15 | 0d | 2024-02-15 | 2024-02-15 | 696d |  |  |  |  | TRANSELEC | 15-02-2024 | 15-02-2024 | 0 días | 0,00% | 100,00% | 100% | 00 HI - HITOS | día 397 |
| 26 | 1.1.2.3 | (Hito de Pago N°3) Revisión y Aprobación de Ingeniería de Detalle | milestone | 0d | 2024-09-02 | 2024-09-02 | 39FS+15d |  |  | 2024-09-02 | 2024-09-02 | 0d | 2024-09-02 | 2024-09-02 | 496d |  |  |  |  | TRANSELEC | 02-09-2024 | 02-09-2024 | 0 días | 0,00% | 100,00% | 100% | 00 HI - HITOS | día 622 |
| 27 | 1.1.2.4 | (Hito de Pago N°4) Autorización Medio Ambiental para inicio construcción | milestone | 0d | 2024-11-01 | 2024-11-01 | 38FS+15d |  |  | 2024-11-01 | 2024-11-01 | 0d | 2024-11-01 | 2024-11-01 | 436d |  |  |  |  | TRANSELEC | 01-11-2024 | 01-11-2024 | 0 días | 0,00% | 100,00% | 100% | 00 HI - HITOS | día 689,5 |
| 28 | 1.1.2.5 | (Hito de Pago N°5) Entrega en terreno del 100% equipamiento primario | milestone | 0d | 2025-02-28 | 2025-02-28 | 93FS+30d, 99, 105 |  |  | 2025-02-28 | 2025-02-28 | 0d | 2024-12-16 | 2024-12-16 | 317d |  |  |  |  | TRANSELEC | 14-02-2025 | 14-02-2025 | 0 días | 0,00% | 100,00% | 100% | 00 HI - HITOS | día 823,375 |
| 29 | 1.1.2.6 | (Hito de Pago N°6) Entrega en terreno del 100% suministro principal ferretería AT | milestone | 0d | 2025-03-14 | 2025-03-14 | 109FS+15d |  |  | 2025-03-14 | 2025-03-14 | 0d | 2024-10-27 | 2024-10-27 | 303d |  |  |  |  | TRANSELEC | 25-01-2025 | 25-01-2025 | 0 días | 0,00% | 100,00% | 100% | 00 HI - HITOS | día 839,125 |
| 30 | 1.1.2.7 | (Hito de Pago N°7) Aprobación del 100% Fundaciones, Estructuras y Caseta de SS.GG y/o celdas | milestone | 0d | 2025-11-22 | 2025-11-22 | 42 |  |  | 2025-11-22 | 2025-11-22 | 0d | 2025-04-15 | 2025-04-15 | 50d |  |  |  |  | TRANSELEC | 09-06-2025 | 09-06-2025 | 0 días | 0,00% | 0,00% | 0% | 00 HI - HITOS | día 1123,75 |
| 31 | 1.1.2.8 | (Hito de Pago N°8) Tendido de conductor de línea y/o Montaje Equipos principales AT | milestone | 0d | 2026-01-09 | 2026-01-09 | 43FS+19d |  |  | 2026-01-09 | 2026-01-09 | 0d | 2025-05-24 | 2025-05-24 | 2d |  |  |  |  | TRANSELEC | 05-08-2025 | 05-08-2025 | 0 días | 0,00% | 0,00% | 0% | 00 HI - HITOS | día 1177,75 |
| 32 | 1.1.2.9 | (Hito de Pago N°9) Aprobación del 100% Pruebas SAT Equipos de Control, Protecciones y Telecomunicaciones | milestone | 0d | 2025-12-18 | 2025-12-18 | 182FS+30d, 237FS+30d, 149FS+30d, 205FS+30d, 260FS+30d |  |  | 2025-12-18 | 2025-12-18 | 0d | 2025-06-18 | 2025-06-18 | 24d |  | start no earlier than 2025-07-07 |  |  | TRANSELEC | 13-08-2025 | 13-08-2025 | 0 días | 0,00% | 0,00% | 0% | 00 HI - HITOS | día 1153 |
| 33 | 1.1.2.10 | (Hito de Pago N°10) Aprobación y recepción provisional del 100% de protocolos de puesta en servicio | milestone | 0d | 2025-12-12 | 2025-12-12 | 600, 394 |  |  | 2025-12-12 | 2025-12-12 | 0d | 2025-07-18 | 2025-07-18 | 30d |  |  |  |  | TRANSELEC | 11-08-2025 | 11-08-2025 | 0 días | 0,00% | 0,00% | 0% | 00 HI - HITOS | día 1146,25 |
| 34 | 1.1.2.11 | (Hito de Pago N°11) Estado de Pago Final: Finalización del 100% de la lista de pendientes y firma acta devolución del terreno. | milestone | 0d | 2026-01-06 | 2026-01-06 | 265 |  |  | 2026-01-06 | 2026-01-06 | 0d | 2025-09-02 | 2025-09-02 | 5d |  |  |  |  | TRANSELEC | 02-09-2025 | 02-09-2025 | 0 días | 0,00% | 0,00% | 0% | 00 HI - HITOS | día 1174,375 |

| ID | WBS | Task | Type | Duration | Start | Finish | Predecessors | Complete | Remaining | Baseline start | Baseline finish | Baseline duration | Baseline 1 start | Baseline 1 finish | Total slack | Free slack | Work | Actual work | Propietario | Baseline Star Rev1 | Baseline Finish Rev1 | Baseline Duration Rev1 | : | % Complete Peso | % Baseline Peso | % Baseline (Tempo) | Text11 | Entrada Peso |
| --- | --- | --- | --- | --- | --- | --- | --- | --- | --- | --- | --- | --- | --- | --- | --- | --- | --- | --- | --- | --- | --- | --- | --- | --- | --- | --- | --- | --- |
| 35 | 1.1.3 | **Hitos Intermedios Multables** |  | 844d | 2023-09-20 | 2026-01-11 |  |  |  | 2023-09-20 | 2026-01-11 | 844d | 2023-09-20 | 2025-06-18 | 0d |  |  |  | TRANSELEC | 20-09-2023 | 08-08-2025 | 688 días | 00 HI - HITOS | 0,00% | 0,00% | 86% |  |  |
| 36 | 1.1.3.1 | (Hito Intermedio N°1) Entrega al Mandante de todos los estudios de terreno que se requieren para la correcta ejecución de la Obra en el Terreno, como, por ejemplo y sin que la lista sea taxativa, mecánica de suelos, Topografía u otro que aplicase. | milestone | 0d | 2023-09-20 | 2023-09-20 | 24FS+82d, 61, 62 |  |  | 2023-09-20 | 2023-09-20 | 0d | 2023-09-20 | 2023-09-20 | 844d |  |  |  | TRANSELEC | 20-09-2023 | 20-09-2023 | 0 días | 00 HI - HITOS | 0,00% | 100,00% | 100% | día 230,5 |  |
| 37 | 1.1.3.2 | (Hito Intermedio N°2) Entrega al Mandante de la Ingeniería Básica en Rev. 0 aceptada por el Mandante y de los estudios que solicite el Coordinador para verificar el cumplimiento de las especificaciones técnicas de la obra. | milestone | 0d | 2024-01-31 | 2024-01-31 | 61, 62, 64, 66FS+20d, 67FS+20d |  |  | 2024-01-31 | 2024-01-31 | 0d | 2024-01-31 | 2024-01-31 | 696d | 0d |  |  | TRANSELEC | 31-01-2024 | 31-01-2024 | 0 días | 00 HI - HITOS | 0,00% | 100,00% | 100% | día 380,125 |  |
| 38 | 1.1.3.3 | (Hito Intermedio N°3) Entrega al Mandante de los documentos que certifiquen la aprobación de los permisos necesarios para el inicio de la construcción de las obras. | milestone | 0d | 2024-10-17 | 2024-10-17 | 49FS+15d, 54FS+15d, 58FS+15d |  |  | 2024-10-17 | 2024-10-17 | 0d | 2024-10-17 | 2024-10-17 | 436d | 0d |  |  | TRANSELEC | 17-10-2024 | 17-10-2024 | 0 días | 00 HI - HITOS | 0,00% | 100,00% | 100% | día 672,625 |  |
| 39 | 1.1.3.4 | (Hito Intermedio N°4) Entrega al Mandante de todos los documentos asociados a la Ingeniería de detalle del proyecto Electromecánico y de OOCC en Revisión 0 aceptado por el Mandante. | milestone | 0d | 2024-08-18 | 2024-08-18 | 69FS+20d, 70FS+20d, 71FS+20d |  |  | 2024-08-18 | 2024-08-18 | 0d | 2024-08-18 | 2024-08-18 | 120d | 0d |  |  | TRANSELEC | 18-08-2024 | 18-08-2024 | 0 días | 00 HI - HITOS | 0,00% | 100,00% | 100% | día 605,125 |  |
| 40 | 1.1.3.5 | (Hito Intermedio N°5) Entrega al Mandante de una copia del contrato firmado entre el Contratista y la ITO designada por el Coordinador para la Obra adjudicada. | milestone | 0d | 2024-09-18 | 2024-09-18 | 77FS+10d |  |  | 2024-09-18 | 2024-09-18 | 0d | 2024-09-17 | 2024-09-17 | 480d |  |  |  | TRANSELEC | 18-09-2024 | 18-09-2024 | 0 días | 00 HI - HITOS | 0,00% | 100,00% | 100% | día 640 |  |
| 41 | 1.1.3.6 | (Hito Intermedio N°6) Entrega al Mandante de una copia de las Órdenes de Compra de los equipos y/o estructuras en caso que aplicase. | milestone | 0d | 2023-12-02 | 2023-12-02 | 89FS+15d, 95, 101 |  |  | 2023-12-02 | 2023-12-02 | 0d | 2023-12-02 | 2023-12-02 | 771d |  |  |  | TRANSELEC | 02-12-2023 | 02-12-2023 | 0 días | 00 HI - HITOS | 0,00% | 100,00% | 100% | día 312,625 |  |
| 42 | 1.1.3.7 | (Hito Intermedio N°7) Entrega al Mandante de documento emitido por la ITO que certifique que: recepción conforme del 100% de las fundaciones en el caso de ampliaciones de subestaciones; y tendido de conductor en caso de lineas. | milestone | 0d | 2025-11-22 | 2025-11-22 | 162FS+31d, 217FS+31d, 132FS+31d |  |  | 2025-11-22 | 2025-11-22 | 0d | 2025-04-15 | 2025-04-15 | 50d | 0d |  |  | TRANSELEC | 09-06-2025 | 09-06-2025 | 0 días | 00 HI - HITOS | 0,00% | 0,00% | 0% | día 1123,75 |  |
| 43 | 1.1.3.8 | (Hito Intermedio N°8) Entrega al Mandante de un documento que certifique que la ITO ha recibido conforme el montaje de los equipos primarios en SSEE y/o tendido de conductores en caso de líneas, según corresponda. | milestone | 0d | 2025-12-21 | 2025-12-21 | 168, 170, 172FS+45d, 223FS+45d, 225FS+45d, 227FS+45d, 137FS+45d, 139FS+45d, 193, 195FS+45d, 248FS+45d, 250FS+45d |  |  | 2025-12-21 | 2025-12-21 | 0d | 2025-05-05 | 2025-05-05 | 2d | 0d |  |  | TRANSELEC | 17-07-2025 | 17-07-2025 | 0 días | 00 HI - HITOS | 0,00% | 0,00% | 0% | día 1156,375 |  |
| 44 | 1.1.3.9 | (Hito Intermedio N°9) Entrega al Mandante de todos los estudios e información solicitada por el Coordinador Eléctrico Nacional para la Puesta en Servicio de la Obra de acuerdo a lo establecido en las Bases Técnicas de la Obra. | milestone | 0d | 2026-01-11 | 2026-01-11 | 579FS+60d, 591FS+60d, 595FS+60d, 585FS+60d, 375FS+60d, 386FS+60d |  |  | 2026-01-11 | 2026-01-11 | 0d | 2025-06-18 | 2025-06-18 | 0d |  |  |  | TRANSELEC | 08-08-2025 | 08-08-2025 | 0 días | 00 HI - HITOS | 0,00% | 0,00% | 0% | día 1180 |  |
| 45 | 1.2 | **MA - MEDIO AMBIENTE** |  | 405d | 2023-04-02 A | 2024-05-10 A |  | 100% |  | 2023-04-02 | 2024-05-10 | 405d | 2023-04-02 | 2024-05-10 |  |  | 2612h | 2612h | TRANSELEC | 02-04-2023 | 10-05-2024 | 405 días | 01 MA-GESTIÓN AMBIENTAL | 100,00% | 100,00% | 100% |  |  |
| 46 | 1.2.1 | **Análisis de Pertinencia** |  | 405d | 2023-04-02 A | 2024-05-10 A |  | 100% |  | 2023-04-02 | 2024-05-10 | 405d | 2023-04-02 | 2024-05-10 |  |  | 2612h | 2612h | TRANSELEC | 02-04-2023 | 10-05-2024 | 405 días | 01 MA-GESTIÓN AMBIENTAL | 100,00% | 100,00% | 100% |  |  |
| 47 | 1.2.1.1 | Elaboración de expediente |  | 210d | 2023-04-02 A | 2023-10-28 A | 5FS+30d | 100% |  | 2023-04-02 | 2023-10-28 | 210d | 2023-04-02 | 2023-10-28 |  |  | 2400h | 2400h | TRANSELEC | 02-04-2023 | 28-10-2023 | 210 días | 01 MA-GESTIÓN AMBIENTAL | 100,00% | 100,00% | 100% | día 37 | 4,58715596 |
| 48 | 1.2.1.2 | Revisión y aprobación del mandante |  | 15d | 2023-10-29 A | 2023-11-12 A | 47 | 100% |  | 2023-10-29 | 2023-11-12 | 15d | 2023-10-29 | 2023-11-12 |  |  | 72h | 72h | TRANSELEC | 29-10-2023 | 12-11-2023 | 15 días | 01 MA-GESTIÓN AMBIENTAL | 100,00% | 100,00% | 100% | día 273,25 | 0,13761468 |
| 49 | 1.2.1.3 | Firma de notarial |  | 180d | 2023-11-13 A | 2024-05-10 A | 48 | 100% |  | 2023-11-13 | 2024-05-10 | 180d | 2023-11-13 | 2024-05-10 |  |  | 140h | 140h | TRANSELEC | 13-11-2023 | 10-05-2024 | 180 días | 01 MA-GESTIÓN AMBIENTAL | 100,00% | 100,00% | 100% | día 290,125 | 0,27522936 |
| 50 | 1.3 | **PC - PERMISOS Y CONVENIOS** |  | 175d | 2024-04-11 A | 2024-10-02 |  | 90% | 18d | 2024-04-11 | 2024-10-02 | 175d | 2024-04-11 | 2024-10-02 | 195d |  | 1045h | 997h | TRANSELEC | 11-04-2024 | 02-10-2024 | 175 días | 02 PE-GESTIÓN PERMISOS | 95,56% | 100,00% | 100% |  |  |
| 51 | 1.3.1 | **PAS 140** |  | 175d | 2024-04-11 A | 2024-10-02 |  | 90% | 18d | 2024-04-11 | 2024-10-02 | 175d | 2024-04-11 | 2024-10-02 | 195d |  | 522h | 498h | TRANSELEC | 11-04-2024 | 02-10-2024 | 175 días | 02 PE-GESTIÓN PERMISOS | 95,56% | 100,00% | 100% |  |  |
| 52 | 1.3.1.1 | Elaboración de expediente |  | 70d | 2024-04-11 A | 2024-06-19 A | 49FS-30d | 100% |  | 2024-04-11 | 2024-06-19 | 70d | 2024-04-11 | 2024-06-19 |  |  | 375h | 375h | TRANSELEC | 11-04-2024 | 19-06-2024 | 70 días | 02 PE-GESTIÓN PERMISOS | 100,00% | 100,00% | 100% | día 458,875 | 0,74074074 |
| 53 | 1.3.1.2 | Tramitación |  | 15d | 2024-06-20 A | 2024-07-04 A | 52 | 100% |  | 2024-06-20 | 2024-07-04 | 15d | 2024-06-20 | 2024-07-04 |  |  | 27h | 27h | TRANSELEC | 20-06-2024 | 04-07-2024 | 15 días | 02 PE-GESTIÓN PERMISOS | 100,00% | 100,00% | 100% | día 537,625 | 0,03703704 |
| 54 | 1.3.1.3 | Aprobación de Proyecto |  | 90d | 2024-07-05 A | 2024-10-02 | 53 | 80% | 18d | 2024-07-05 | 2024-10-02 | 90d | 2024-07-05 | 2024-10-02 | 195d | 0d | 120h | 96h | TRANSELEC | 05-07-2024 | 02-10-2024 | 90 días | 02 PE-GESTIÓN PERMISOS | 80,00% | 100,00% | 100% | día 554,5 | 0,22222222 |
| 55 | 1.3.2 | **PAS 142** |  | 175d | 2024-04-11 A | 2024-10-02 |  | 90% | 18d | 2024-04-11 | 2024-10-02 | 175d | 2024-04-11 | 2024-10-02 | 195d |  | 523h | 499h | TRANSELEC | 11-04-2024 | 02-10-2024 | 175 días | 02 PE-GESTIÓN PERMISOS | 95,56% | 100,00% | 100% |  |  |
| 56 | 1.3.2.1 | Elaboración de expediente |  | 70d | 2024-04-11 A | 2024-06-19 A | 49FS-30d | 100% |  | 2024-04-11 | 2024-06-19 | 70d | 2024-04-11 | 2024-06-19 |  |  | 375h | 375h | TRANSELEC | 11-04-2024 | 19-06-2024 | 70 días | 02 PE-GESTIÓN PERMISOS | 100,00% | 100,00% | 100% | día 458,875 | 0,74074074 |
| 57 | 1.3.2.2 | Tramitación |  | 15d | 2024-06-20 A | 2024-07-04 A | 56 | 100% |  | 2024-06-20 | 2024-07-04 | 15d | 2024-06-20 | 2024-07-04 |  |  | 28h | 28h | TRANSELEC | 20-06-2024 | 04-07-2024 | 15 días | 02 PE-GESTIÓN PERMISOS | 100,00% | 100,00% | 100% | día 537,625 | 0,03703704 |
| 58 | 1.3.2.3 | Aprobación de Proyecto |  | 90d | 2024-07-05 A | 2024-10-02 | 57 | 80% | 18d | 2024-07-05 | 2024-10-02 | 90d | 2024-07-05 | 2024-10-02 | 195d | 0d | 120h | 96h | TRANSELEC | 05-07-2024 | 02-10-2024 | 90 días | 02 PE-GESTIÓN PERMISOS | 80,00% | 100,00% | 100% | día 554,5 | 0,22222222 |

| ID | WBS | Task | Duration | Start | Finish | Predecessors | Complete | Baseline start | Baseline finish | Baseline duration | Baseline 1 start | Baseline 1 finish | Constraint | Work | Actual work | Propietario | Baseline Star Rev1 | Baseline Finish Rev1 | Baseline Duration Rev1 | : | % Complete Peso | % Baseline Peso | % Baseline (Tempo) | Text11 | Entrada Peso |
| --- | --- | --- | --- | --- | --- | --- | --- | --- | --- | --- | --- | --- | --- | --- | --- | --- | --- | --- | --- | --- | --- | --- | --- | --- | --- |
| 59 | 1.4 | **IN - INGENIERIA** | 455d | 2023-05-02 A | 2024-07-29 A |  | 100% | 2023-05-02 | 2024-07-29 | 455d | 2023-05-02 | 2024-07-29 |  | 5224h | 5224h | TRANSELEC | 02-05-2023 | 29-07-2024 | 455 días | 04 IN-INGENIERÍA | 100,00% | 100,00% | 100% |  |  |
| 60 | 1.4.1 | **Estudios** | 120d | 2023-05-02 A | 2023-08-29 A |  | 100% | 2023-05-02 | 2023-08-29 | 120d | 2023-05-02 | 2023-08-29 |  | 1828h | 1828h | TRANSELEC | 02-05-2023 | 29-08-2023 | 120 días | 04 IN-INGENIERÍA | 100,00% | 100,00% | 100% |  |  |
| 61 | 1.4.1.1 | Estudios de Diseño Eléctrico | 120d | 2023-05-02 A | 2023-08-29 A | 5FS+60d | 100% | 2023-05-02 | 2023-08-29 | 120d | 2023-05-02 | 2023-08-29 |  | 1170h | 1170h | TRANSELEC | 02-05-2023 | 29-08-2023 | 120 días | 04 IN-INGENIERÍA | 100,00% | 100,00% | 100% | día 70,75 | 2,16346154 |
| 62 | 1.4.1.2 | Estudios de Diseño civil | 120d | 2023-05-02 A | 2023-08-29 A | 5FS+60d | 100% | 2023-05-02 | 2023-08-29 | 120d | 2023-05-02 | 2023-08-29 |  | 658h | 658h | TRANSELEC | 02-05-2023 | 29-08-2023 | 120 días | 04 IN-INGENIERÍA | 100,00% | 100,00% | 100% | día 70,75 | 1,20192308 |
| 63 | 1.4.2 | **Ingeniería Básica** | 225d | 2023-06-01 A | 2024-01-11 A |  | 100% | 2023-06-01 | 2024-01-11 | 225d | 2023-06-01 | 2024-01-11 |  | 784h | 784h | TRANSELEC | 01-06-2023 | 11-01-2024 | 225 días | 04 IN-INGENIERÍA | 100,00% | 100,00% | 100% |  |  |
| 64 | 1.4.2.1 | Proyecto de Obras Civiles y Estructura Metálica | 150d | 2023-06-01 A | 2023-10-28 A | 62FS-90d | 100% | 2023-06-01 | 2023-10-28 | 150d | 2023-06-01 | 2023-10-28 |  | 260h | 260h | TRANSELEC | 01-06-2023 | 28-10-2023 | 150 días | 04 IN-INGENIERÍA | 100,00% | 100,00% | 100% | día 104,5 | 0,57692308 |
| 65 | 1.4.2.2 | Especificaciones Técnicas de Equipamientos y Suministros | 150d | 2023-06-01 A | 2023-10-28 A | 61FS-90d | 100% | 2023-06-01 | 2023-10-28 | 150d | 2023-06-01 | 2023-10-28 |  | 310h | 310h | TRANSELEC | 01-06-2023 | 28-10-2023 | 150 días | 04 IN-INGENIERÍA | 100,00% | 100,00% | 100% | día 104,5 | 0,67307692 |
| 66 | 1.4.2.3 | Proyecto Electromecánico | 148d | 2023-06-16 A | 2023-11-10 A | 62FS-75d | 100% | 2023-06-16 | 2023-11-10 | 148d | 2023-06-16 | 2023-11-12 |  | 40h | 40h | TRANSELEC | 16-06-2023 | 10-11-2023 | 148 días | 04 IN-INGENIERÍA | 100,00% | 100,00% | 100% | día 121,375 | 0,09615385 |
| 67 | 1.4.2.4 | Proyectos Sistema de Control y Protección | 150d | 2023-08-15 A | 2024-01-11 A | 61FS-15d | 100% | 2023-08-15 | 2024-01-11 | 150d | 2023-08-15 | 2024-01-11 |  | 174h | 174h | TRANSELEC | 15-08-2023 | 11-01-2024 | 150 días | 04 IN-INGENIERÍA | 100,00% | 100,00% | 100% | día 188,875 | 0,38461538 |
| 68 | 1.4.3 | **Ingeniería Detalle** | 275d | 2023-10-29 A | 2024-07-29 A |  | 100% | 2023-10-29 | 2024-07-29 | 275d | 2023-10-29 | 2024-07-29 |  | 2612h | 2612h | TRANSELEC | 29-10-2023 | 29-07-2024 | 275 días | 04 IN-INGENIERÍA | 100,00% | 100,00% | 100% |  |  |
| 69 | 1.4.3.1 | Diseño Electromecánico | 202d | 2023-11-11 A | 2024-05-30 A | 66 | 100% | 2023-11-11 | 2024-05-30 | 202d | 2023-11-13 | 2024-05-30 |  | 680h | 680h | TRANSELEC | 11-11-2023 | 30-05-2024 | 202 días | 04 IN-INGENIERÍA | 100,00% | 100,00% | 100% | día 287,875 | 1,29807692 |
| 70 | 1.4.3.2 | Diseño Civil Estructural | 200d | 2023-10-29 A | 2024-05-15 A | 64 | 100% | 2023-10-29 | 2024-05-15 | 200d | 2023-10-29 | 2024-05-15 |  | 888h | 888h | TRANSELEC | 29-10-2023 | 15-05-2024 | 200 días | 04 IN-INGENIERÍA | 100,00% | 100,00% | 100% | día 273,25 | 1,68269231 |
| 71 | 1.4.3.3 | Control y Protecciones | 200d | 2024-01-12 A | 2024-07-29 A | 67 | 100% | 2024-01-12 | 2024-07-29 | 200d | 2024-01-12 | 2024-07-29 |  | 1044h | 1044h | TRANSELEC | 12-01-2024 | 29-07-2024 | 200 días | 04 IN-INGENIERÍA | 100,00% | 100,00% | 100% | día 357,625 | 1,92307692 |
| 72 | 1.5 | **PR - PROCUREMENT** | 510d | 2023-10-29 A | 2025-03-21 A |  | 100% | 2023-10-29 | 2025-03-21 | 510d | 2023-10-29 | 2024-11-16 |  | 14121h | 14121h | TRANSELEC | 29-10-2023 | 15-01-2025 | 445 días | 05 SU-SUMINISTRO | 100,00% | 100,00% | 100% |  |  |
| 73 | 1.5.1 | **Proveedores, consultores y servicios** | 156d | 2024-04-06 A | 2024-09-08 A |  | 100% | 2024-04-06 | 2024-09-08 | 156d | 2024-04-06 | 2024-09-07 |  | 1054h | 1054h | TRANSELEC | 06-04-2024 | 08-09-2024 | 155,11 días | 03 GC-GESTIÓN DE CONTRATOS | 100,00% | 100,00% | 100% |  |  |
| 74 | 1.5.1.1 | **Inspección Tecnica de Obra** | 156d | 2024-04-06 A | 2024-09-08 A |  | 100% | 2024-04-06 | 2024-09-08 | 156d | 2024-04-06 | 2024-09-07 |  | 1054h | 1054h | TRANSELEC | 06-04-2024 | 08-09-2024 | 155,11 días | 03 GC-GESTIÓN DE CONTRATOS | 100,00% | 100,00% | 100% |  |  |
| 75 | 1.5.1.1.1 | Presentación de Propuestas ITO al coordinador | 80d | 2024-04-06 A | 2024-06-24 A | 124FS-237d | 100% | 2024-04-06 | 2024-06-24 | 80d | 2024-04-06 | 2024-06-24 |  | 931h | 931h | TRANSELEC | 06-04-2024 | 24-06-2024 | 80 días | 03 GC-GESTIÓN DE CONTRATOS | 100,00% | 100,00% | 100% | día 453,25 | 1,78571429 |
| 76 | 1.5.1.1.2 | Evaluación y designación de ITO por parte del coordinador | 45d | 2024-06-25 A | 2024-08-08 A | 75 | 100% | 2024-06-25 | 2024-08-08 | 45d | 2024-06-25 | 2024-08-08 |  | 84h | 84h | TRANSELEC | 25-06-2024 | 08-08-2024 | 45 días | 03 GC-GESTIÓN DE CONTRATOS | 100,00% | 100,00% | 100% | día 543,25 | 0,16071429 |
| 77 | 1.5.1.1.3 | Firma del contrato con ITO designado | 31d | 2024-08-09 A | 2024-09-08 A | 76 | 100% | 2024-08-09 | 2024-09-08 | 31d | 2024-08-09 | 2024-09-07 |  | 39h | 39h | TRANSELEC | 09-08-2024 | 08-09-2024 | 30,11 días | 03 GC-GESTIÓN DE CONTRATOS | 100,00% | 100,00% | 100% | día 593,875 | 0,05357143 |
| 78 | 1.5.2 | **Suministro** | 510d | 2023-10-29 A | 2025-03-21 A |  | 100% | 2023-10-29 | 2025-03-21 | 510d | 2023-10-29 | 2024-11-16 |  | 13067h | 13067h | TRANSELEC | 29-10-2023 | 15-01-2025 | 445 días | 05 SU-SUMINISTRO | 100,00% | 100,00% | 100% |  |  |
| 79 | 1.5.2.1 | **Estructuras Metálicas para Equipos** | 299d | 2024-04-01 A | 2025-01-24 A |  | 100% | 2024-04-01 | 2025-01-24 | 299d | 2024-04-01 | 2024-11-16 |  | 1278h | 1278h | TRANSELEC | 01-04-2024 | 15-01-2025 | 290 días | 05 SU-SUMINISTRO | 100,00% | 100,00% | 100% |  |  |
| 80 | 1.5.2.1.1 | Proceso de compra Estructura Metálica | 20d | 2024-04-01 A | 2024-04-20 A | 65, 69FS-60d, 70FS-60d | 100% | 2024-04-01 | 2024-04-20 | 20d | 2024-04-01 | 2024-04-20 |  | 75h | 75h | TRANSELEC | 01-04-2024 | 20-04-2024 | 20 días | 05 SU-SUMINISTRO | 100,00% | 100,00% | 100% | día 447,625 | 0,14437885 |
| 81 | 1.5.2.1.2 | Ingeniería para fabricación aprobada | 56d | 2024-04-21 A | 2024-06-15 A | 80 | 100% | 2024-04-21 | 2024-06-15 | 56d | 2024-04-21 | 2024-06-15 |  | 42h | 42h | TRANSELEC | 21-04-2024 | 15-06-2024 | 56 días | 05 SU-SUMINISTRO | 100,00% | 100,00% | 100% | día 470,125 | 0,08021047 |
| 82 | 1.5.2.1.3 | Período de fabricación Estructura Metálica | 124d | 2024-06-16 A | 2024-10-17 A | 81 | 100% | 2024-06-16 | 2024-10-17 | 124d | 2024-06-16 | 2024-10-17 |  | 935h | 935h | TRANSELEC | 16-06-2024 | 17-10-2024 | 124 días | 05 SU-SUMINISTRO | 100,00% | 100,00% | 100% | día 533,125 | 1,79029774 |
| 83 | 1.5.2.1.4 | Transporte al sitio de la obra Estructura Metálica | 99d | 2024-10-18 A | 2025-01-24 A | 82 | 100% | 2024-10-18 | 2025-01-24 | 99d | 2024-10-18 | 2024-11-16 | finish no earlier than 2025-01-24 | 226h | 226h | TRANSELEC | 18-10-2024 | 15-01-2025 | 90 días | 05 SU-SUMINISTRO | 100,00% | 100,00% | 100% | día 672,625 | 0,43313655 |

| ID | WBS | Task | Duration | Start | Finish | Predecessors | Complete | Baseline start | Baseline finish | Baseline duration | Baseline 1 start | Baseline 1 finish | Constraint | Work | Actual work | Propietario | Baseline Star Rev1 | Baseline Finish Rev1 | Baseline Duration Rev1 | : | % Complete Peso | % Baseline Peso | % Baseline (Tempo) | Text11 | Entrada Peso |
| --- | --- | --- | --- | --- | --- | --- | --- | --- | --- | --- | --- | --- | --- | --- | --- | --- | --- | --- | --- | --- | --- | --- | --- | --- | --- |
| 84 | 1.5.2.2 | **Cables de Control, Fuerza y Conductor AT** | 465d | 2023-12-13 A | 2025-03-21 A |  | 100% | 2023-12-13 | 2025-03-21 | 465d | 2023-12-13 | 2024-10-27 |  | 2346h | 2346h | TRANSELEC | 13-12-2023 | 15-01-2025 | 400 días | 05 SU-SUMINISTRO | 100,00% | 100,00% | 100% |  |  |
| 85 | 1.5.2.2.1 | Proceso de compra Conductor AT | 20d | 2023-12-13 A | 2024-01-01 A | 65FS+45d | 100% | 2023-12-13 | 2024-01-01 | 20d | 2023-12-13 | 2024-01-01 |  | 75h | 75h | TRANSELEC | 13-12-2023 | 01-01-2024 | 20 días | 05 SU-SUMINISTRO | 100,00% | 100,00% | 100% | día 323,875 | 0,14437885 |
| 86 | 1.5.2.2.2 | Período de fabricación Conductor AT | 270d | 2024-01-02 A | 2024-09-27 A | 85 | 100% | 2024-01-02 | 2024-09-27 | 270d | 2024-01-02 | 2024-09-27 |  | 2036h | 2036h | TRANSELEC | 02-01-2024 | 27-09-2024 | 270 días | 05 SU-SUMINISTRO | 100,00% | 100,00% | 100% | día 346,375 | 3,89822895 |
| 87 | 1.5.2.2.3 | Transporte al sitio de la obra Conductor AT | 175d | 2024-09-28 A | 2025-03-21 A | 86 | 100% | 2024-09-28 | 2025-03-21 | 175d | 2024-09-28 | 2024-10-27 | finish no earlier than 2025-03-21 | 235h | 235h | TRANSELEC | 28-09-2024 | 15-01-2025 | 110 días | 05 SU-SUMINISTRO | 100,00% | 100,00% | 100% | día 650,125 | 0,43313655 |
| 88 | 1.5.2.3 | **Interruptores** | 453d | 2023-10-29 A | 2025-01-23 A |  | 100% | 2023-10-29 | 2025-01-23 | 453d | 2023-10-29 | 2024-11-16 |  | 2519h | 2519h | TRANSELEC | 29-10-2023 | 15-01-2025 | 445 días | 05 SU-SUMINISTRO | 100,00% | 100,00% | 100% |  |  |
| 89 | 1.5.2.3.1 | Proceso de compra de Interruptores | 20d | 2023-10-29 A | 2023-11-17 A | 65 | 100% | 2023-10-29 | 2023-11-17 | 20d | 2023-10-29 | 2023-11-17 |  | 151h | 151h | TRANSELEC | 29-10-2023 | 17-11-2023 | 20 días | 05 SU-SUMINISTRO | 100,00% | 100,00% | 100% | día 273,25 | 0,2887577 |
| 90 | 1.5.2.3.2 | Ingeniería para fabricación aprobada | 56d | 2023-11-18 A | 2024-01-12 A | 89 | 100% | 2023-11-18 | 2024-01-12 | 56d | 2023-11-18 | 2024-01-12 |  | 75h | 75h | TRANSELEC | 18-11-2023 | 12-01-2024 | 56 días | 05 SU-SUMINISTRO | 100,00% | 100,00% | 100% | día 295,75 | 0,14437885 |
| 91 | 1.5.2.3.3 | Periodo de Fabricación de Interruptores | 234d | 2024-01-13 A | 2024-09-02 A | 90 | 100% | 2024-01-13 | 2024-09-02 | 234d | 2024-01-13 | 2024-09-02 |  | 1765h | 1765h | TRANSELEC | 13-01-2024 | 02-09-2024 | 234 días | 05 SU-SUMINISTRO | 100,00% | 100,00% | 100% | día 358,75 | 3,37846509 |
| 92 | 1.5.2.3.4 | Pruebas FAT | 15d | 2024-09-03 A | 2024-09-17 A | 91 | 100% | 2024-09-03 | 2024-09-17 | 15d | 2024-09-03 | 2024-09-17 |  | 75h | 75h | TRANSELEC | 03-09-2024 | 17-09-2024 | 15 días | 05 SU-SUMINISTRO | 100,00% | 100,00% | 100% | día 622 | 0,14437885 |
| 93 | 1.5.2.3.5 | Transporte al sitio de la obra Interruptores | 128d | 2024-09-18 A | 2025-01-23 A | 92 | 100% | 2024-09-18 | 2025-01-23 | 128d | 2024-09-18 | 2024-11-16 | finish no earlier than 2025-01-23 | 453h | 453h | TRANSELEC | 18-09-2024 | 15-01-2025 | 120 días | 05 SU-SUMINISTRO | 100,00% | 100,00% | 100% | día 638,875 | 0,8662731 |
| 94 | 1.5.2.4 | **Transformadores de Corriente** | 489d | 2023-10-29 A | 2025-02-28 A |  | 100% | 2023-10-29 | 2025-02-28 | 489d | 2023-10-29 | 2024-11-16 |  | 2519h | 2519h | TRANSELEC | 29-10-2023 | 15-01-2025 | 445 días | 05 SU-SUMINISTRO | 100,00% | 100,00% | 100% |  |  |
| 95 | 1.5.2.4.1 | Proceso de compra Transformadores de Corriente | 20d | 2023-10-29 A | 2023-11-17 A | 65 | 100% | 2023-10-29 | 2023-11-17 | 20d | 2023-10-29 | 2023-11-17 |  | 151h | 151h | TRANSELEC | 29-10-2023 | 17-11-2023 | 20 días | 05 SU-SUMINISTRO | 100,00% | 100,00% | 100% | día 273,25 | 0,2887577 |
| 96 | 1.5.2.4.2 | Ingeniería para fabricación aprobada | 56d | 2023-11-18 A | 2024-01-12 A | 95 | 100% | 2023-11-18 | 2024-01-12 | 56d | 2023-11-18 | 2024-01-12 |  | 75h | 75h | TRANSELEC | 18-11-2023 | 12-01-2024 | 56 días | 05 SU-SUMINISTRO | 100,00% | 100,00% | 100% | día 295,75 | 0,14437885 |
| 97 | 1.5.2.4.3 | Periodo de Fabricación de Transformadores de Corriente | 234d | 2024-01-13 A | 2024-09-02 A | 96 | 100% | 2024-01-13 | 2024-09-02 | 234d | 2024-01-13 | 2024-09-02 |  | 1765h | 1765h | TRANSELEC | 13-01-2024 | 02-09-2024 | 234 días | 05 SU-SUMINISTRO | 100,00% | 100,00% | 100% | día 358,75 | 3,37846509 |
| 98 | 1.5.2.4.4 | Pruebas FAT | 15d | 2024-09-03 A | 2024-09-17 A | 97 | 100% | 2024-09-03 | 2024-09-17 | 15d | 2024-09-03 | 2024-09-17 |  | 75h | 75h | TRANSELEC | 03-09-2024 | 17-09-2024 | 15 días | 05 SU-SUMINISTRO | 100,00% | 100,00% | 100% | día 622 | 0,14437885 |
| 99 | 1.5.2.4.5 | Transporte al sitio de la obra Transformadores de Corriente | 164d | 2024-09-18 A | 2025-02-28 A | 98 | 100% | 2024-09-18 | 2025-02-28 | 164d | 2024-09-18 | 2024-11-16 | finish no earlier than 2025-02-28 | 453h | 453h | TRANSELEC | 18-09-2024 | 15-01-2025 | 120 días | 05 SU-SUMINISTRO | 100,00% | 100,00% | 100% | día 638,875 | 0,8662731 |
| 100 | 1.5.2.5 | **Desconectadores** | 488d | 2023-10-29 A | 2025-02-27 A |  | 100% | 2023-10-29 | 2025-02-27 | 488d | 2023-10-29 | 2024-11-16 |  | 2519h | 2519h | TRANSELEC | 29-10-2023 | 15-01-2025 | 445 días | 05 SU-SUMINISTRO | 100,00% | 100,00% | 100% |  |  |
| 101 | 1.5.2.5.1 | Proceso de compra de Desconectadores | 20d | 2023-10-29 A | 2023-11-17 A | 65 | 100% | 2023-10-29 | 2023-11-17 | 20d | 2023-10-29 | 2023-11-17 |  | 151h | 151h | TRANSELEC | 29-10-2023 | 17-11-2023 | 20 días | 05 SU-SUMINISTRO | 100,00% | 100,00% | 100% | día 273,25 | 0,2887577 |
| 102 | 1.5.2.5.2 | Ingeniería para fabricación aprobada | 56d | 2023-11-18 A | 2024-01-12 A | 101 | 100% | 2023-11-18 | 2024-01-12 | 56d | 2023-11-18 | 2024-01-12 |  | 75h | 75h | TRANSELEC | 18-11-2023 | 12-01-2024 | 56 días | 05 SU-SUMINISTRO | 100,00% | 100,00% | 100% | día 295,75 | 0,14437885 |
| 103 | 1.5.2.5.3 | Periodo de Fabricación de Desconectadores | 234d | 2024-01-13 A | 2024-09-02 A | 102 | 100% | 2024-01-13 | 2024-09-02 | 234d | 2024-01-13 | 2024-09-02 |  | 1765h | 1765h | TRANSELEC | 13-01-2024 | 02-09-2024 | 234 días | 05 SU-SUMINISTRO | 100,00% | 100,00% | 100% | día 358,75 | 3,37846509 |
| 104 | 1.5.2.5.4 | Pruebas FAT | 15d | 2024-09-03 A | 2024-09-17 A | 103 | 100% | 2024-09-03 | 2024-09-17 | 15d | 2024-09-03 | 2024-09-17 |  | 75h | 75h | TRANSELEC | 03-09-2024 | 17-09-2024 | 15 días | 05 SU-SUMINISTRO | 100,00% | 100,00% | 100% | día 622 | 0,14437885 |
| 105 | 1.5.2.5.5 | Transporte al sitio de la obra Desconectadores | 163d | 2024-09-18 A | 2025-02-27 A | 104 | 100% | 2024-09-18 | 2025-02-27 | 163d | 2024-09-18 | 2024-11-16 | finish no earlier than 2025-02-27 | 453h | 453h | TRANSELEC | 18-09-2024 | 15-01-2025 | 120 días | 05 SU-SUMINISTRO | 100,00% | 100,00% | 100% | día 638,875 | 0,8662731 |
| 106 | 1.5.2.6 | **Conectores y Herrajes** | 368d | 2024-02-26 A | 2025-02-27 A |  | 100% | 2024-02-26 | 2025-02-27 | 368d | 2024-02-26 | 2024-10-12 |  | 1886h | 1886h | TRANSELEC | 26-02-2024 | 10-01-2025 | 320 días | 05 SU-SUMINISTRO | 100,00% | 100,00% | 100% |  |  |
| 107 | 1.5.2.6.1 | Proceso de compra conectores y herrajes | 20d | 2024-02-26 A | 2024-03-16 A | 65FS+120d | 100% | 2024-02-26 | 2024-03-16 | 20d | 2024-02-26 | 2024-03-16 |  | 75h | 75h | TRANSELEC | 26-02-2024 | 16-03-2024 | 20 días | 05 SU-SUMINISTRO | 100,00% | 100,00% | 100% | día 408,25 | 0,14437885 |
| 108 | 1.5.2.6.2 | Período de fabricación conectores y herrajes | 180d | 2024-03-17 A | 2024-09-12 A | 107 | 100% | 2024-03-17 | 2024-09-12 | 180d | 2024-03-17 | 2024-09-12 |  | 1358h | 1358h | TRANSELEC | 17-03-2024 | 12-09-2024 | 180 días | 05 SU-SUMINISTRO | 100,00% | 100,00% | 100% | día 430,75 | 2,5988193 |
| 109 | 1.5.2.6.3 | Transporte al sitio de la obra conectores y herrajes | 168d | 2024-09-13 A | 2025-02-27 A | 108 | 100% | 2024-09-13 | 2025-02-27 | 168d | 2024-09-13 | 2024-10-12 | finish no earlier than 2025-02-27 | 453h | 453h | TRANSELEC | 13-09-2024 | 10-01-2025 | 120 días | 05 SU-SUMINISTRO | 100,00% | 100,00% | 100% | día 633,25 | 0,8662731 |

| ID | WBS | Task | Type | Duration | Start | Finish | Predecessors | Complete | Remaining | Baseline start | Baseline finish | Baseline duration | Baseline 1 start | Baseline 1 finish | Total slack | Free slack | Constraint | Calendar | Work | Actual work | Propietario | Baseline Star Rev1 | Text11 | Baseline Finish Rev1 | Baseline Duration Rev1 | : | % Complete Peso | % Baseline Peso | % Baseline (Tempo) | Entrada Peso |
| --- | --- | --- | --- | --- | --- | --- | --- | --- | --- | --- | --- | --- | --- | --- | --- | --- | --- | --- | --- | --- | --- | --- | --- | --- | --- | --- | --- | --- | --- | --- |
| 110 | 1.6 | **ID - INTERVENCIONES Y DESCONEXIONES** |  | 268d | 2025-02-27 A | 2025-11-21 |  | 26% | 199.14d | 2025-02-27 | 2025-11-21 | 268d | 2024-10-22 | 2025-04-19 | 21d |  |  |  |  |  | TRANSELEC | 14-01-2025 | día 1 | 19-06-2025 | 157 días | 00 ID - INTERVENCIONES Y DESCONEXIONES | 0,00% | 0,00% | 76% |  |
| 111 | 1.6.1 | **Paño acoplador** |  | 38d | 2025-02-27 A | 2025-04-05 A |  | 100% |  | 2025-02-27 | 2025-04-05 | 38d | 2024-10-22 | 2025-01-07 |  |  |  |  |  |  | TRANSELEC | 14-01-2025 |  | 19-02-2025 | 37 días | 00 ID - INTERVENCIONES Y DESCONEXIONES | 0,00% | 0,00% | 100% |  |
| 112 | 1.6.1.1 | Desconexión de CTO. Paño acoplador |  | 32d | 2025-02-28 A | 2025-04-05 A | 125FS+7d | 100% |  | 2025-02-28 | 2025-04-05 | 32d | 2024-10-22 | 2025-01-07 |  |  |  | ENKI - ELECNOR L_S |  |  | TRANSELEC | 14-01-2025 | día 579,25 | 19-02-2025 | 32 días | 00 ID - INTERVENCIONES Y DESCONEXIONES | 100,00% | 100,00% | 100% |  |
| 113 | 1.6.1.2 | Desconexión Barra Principal Sección 1 (Retiro chicotes) |  | 1d | 2025-02-27 A | 2025-02-27 A | 112SS-1d | 100% |  | 2025-02-27 | 2025-02-27 | 1d | 2024-10-25 | 2024-10-25 |  |  |  | ENKI - ELECNOR L_S |  |  | TRANSELEC | 15-01-2025 | día 578,125 | 15-01-2025 | 1 día | 00 ID - INTERVENCIONES Y DESCONEXIONES | 100,00% | 100,00% | 100% |  |
| 114 | 1.6.1.3 | Desconexión Barra Principal Sección 2 (Retiro chicotes) |  | 1d | 2025-02-27 A | 2025-02-27 A | 113SS | 100% |  | 2025-02-27 | 2025-02-27 | 1d | 2024-10-26 | 2024-10-26 |  |  |  | ENKI - ELECNOR L_S |  |  | TRANSELEC | 15-01-2025 | día 578,125 | 15-01-2025 | 1 día | 00 ID - INTERVENCIONES Y DESCONEXIONES | 100,00% | 100,00% | 100% |  |
| 115 | 1.6.2 | **Circuito 1** |  | 53d | 2025-06-24 A | 2025-09-04 |  | 4% | 51.07d | 2025-06-24 | 2025-09-04 | 53d | 2024-10-22 | 2025-01-19 | 15d |  |  | ENKI - ELECNOR L_S |  |  | TRANSELEC | 22-02-2025 |  | 21-04-2025 | 50 días | 00 ID - INTERVENCIONES Y DESCONEXIONES | 0,00% | 0,00% | 100% |  |
| 116 | 1.6.2.1 | Desconexión CTO. 1 Encuentro - Kimal |  | 53d | 2025-06-24 | 2025-09-04 | 153FS+2d, 112FS+2d |  |  | 2025-06-24 | 2025-09-04 | 53d | 2024-10-22 | 2025-01-19 | 15d | 0d | finish no earlier than 2025-08-12 | ENKI - ELECNOR L_S |  |  | TRANSELEC | 22-02-2025 | día 671,5 | 21-04-2025 | 50 días | 00 ID - INTERVENCIONES Y DESCONEXIONES | 0,00% | 100,00% | 100% |  |
| 117 | 1.6.2.2 | Desconexión Barra Transferencia (Retiro chicotes) |  | 1d | 2025-06-24 A | 2025-06-24 A | 116SS | 100% |  | 2025-06-24 | 2025-06-24 | 1d | 2024-10-23 | 2024-10-23 |  |  | start no earlier than 2025-05-01 | ENKI - ELECNOR L_S |  |  | TRANSELEC | 24-02-2025 | día 671,5 | 24-02-2025 | 1 día | 00 ID - INTERVENCIONES Y DESCONEXIONES | 100,00% | 100,00% | 100% |  |
| 118 | 1.6.2.3 | Desconexión Barra Principal Sección 2 (Retiro chicotes) |  | 1d | 2025-06-24 A | 2025-06-24 A | 117SS | 100% |  | 2025-06-24 | 2025-06-24 | 1d | 2024-10-24 | 2024-10-24 |  |  |  | ENKI - ELECNOR L_S |  |  | TRANSELEC | 24-02-2025 | día 671,5 | 24-02-2025 | 1 día | 00 ID - INTERVENCIONES Y DESCONEXIONES | 100,00% | 100,00% | 100% |  |
| 119 | 1.6.3 | **Circuito 2** |  | 53d | 2025-09-05 A | 2025-11-21 |  | 2% | 52.04d | 2025-09-05 | 2025-11-21 | 53d | 2025-01-20 | 2025-04-19 | 15d |  |  | ENKI - ELECNOR L_S |  |  | TRANSELEC | 22-04-2025 |  | 19-06-2025 | 51 días | 00 ID - INTERVENCIONES Y DESCONEXIONES | 0,00% | 0,00% | 16% |  |
| 120 | 1.6.3.1 | Desconexión CTO. 2 Encuentro - Kimal |  | 53d | 2025-09-05 | 2025-11-21 | 125, 116, 208, 180FS+1d |  |  | 2025-09-05 | 2025-11-21 | 53d | 2025-01-20 | 2025-04-19 | 15d | 0d |  | ENKI - ELECNOR L_S |  |  | TRANSELEC | 22-04-2025 | día 731,125 | 19-06-2025 | 51 días | 00 ID - INTERVENCIONES Y DESCONEXIONES | 0,00% | 16,00% | 16% |  |
| 121 | 1.6.3.2 | Desconexión Barra Transferencia (Retiro chicotes) |  | 1d | 2025-09-06 | 2025-09-06 | 120SS+1d |  |  | 2025-09-06 | 2025-09-06 | 1d | 2025-01-21 | 2025-01-21 | 15d | 14d |  | ENKI - ELECNOR L_S |  |  | TRANSELEC | 23-04-2025 | día 732,25 | 23-04-2025 | 1 día | 00 ID - INTERVENCIONES Y DESCONEXIONES | 0,00% | 100,00% | 100% |  |
| 122 | 1.6.3.3 | Desconexión Barra Principal Sección 2 (Retiro chicotes) |  | 1d | 2025-09-06 A | 2025-09-06 A | 121SS | 100% |  | 2025-09-06 | 2025-09-06 | 1d | 2025-01-22 | 2025-01-22 |  |  |  | ENKI - ELECNOR L_S |  |  | TRANSELEC | 23-04-2025 | día 732,25 | 23-04-2025 | 1 día | 00 ID - INTERVENCIONES Y DESCONEXIONES | 100,00% | 100,00% | 100% |  |
| 123 | 1.7 | **CT - CONSTRUCCIÓN** |  | 277d | 2024-11-29 A | 2026-01-06 |  | 71% | 81.53d | 2024-11-29 | 2026-01-06 | 277d | 2024-10-02 | 2025-09-02 | 4d |  |  | ENKI - ELECNOR L_S | 25596h | 16885.5h | TRANSELEC | 29-11-2024 |  | 02-09-2025 | 228 días | 06 CO-CONSTRUCCIÓN | 65,83% | 65,19% | 72% |  |
| 124 | 1.7.1 | Entrega del Terreno | milestone | 0d | 2024-11-29 | 2024-11-29 | 49, 54, 58, 69, 70, 71 |  |  | 2024-11-29 | 2024-11-29 | 0d | 2024-10-02 | 2024-10-02 | 90d | 0d | start no earlier than 2024-11-29 | ENKI - ELECNOR L_S |  |  | TRANSELEC | 29-11-2024 | día 515,125 | 29-11-2024 | 0 días | 06 CO-CONSTRUCCIÓN | 0,00% | 100,00% | 100% |  |
| 125 | 1.7.2 | Movilización e Instalación de Faena |  | 47d | 2024-12-16 A | 2025-02-19 A | 77, 124FS+1d | 100% |  | 2024-12-16 | 2025-02-19 | 47d | 2024-10-03 | 2024-10-22 |  |  | start no earlier than 2024-12-16 | ENKI - ELECNOR L_S | 2215h | 2215h | TRANSELEC | 16-12-2024 | día 528,625 | 11-01-2025 | 14 días | 06 CO-CONSTRUCCIÓN | 100,00% | 100,00% | 100% | 4,052165395 |
| 126 | 1.7.3 | **Paño JR - Acoplador** |  | 60d | 2025-03-28 A | 2025-06-19 A |  | 100% |  | 2025-03-28 | 2025-06-19 | 60d | 2024-10-27 | 2025-01-12 |  |  |  | ENKI - ELECNOR L_S | 5706h | 5706h | TRANSELEC | 16-01-2025 |  | 18-02-2025 | 29 días | 06 CO-CONSTRUCCIÓN | 100,00% | 100,00% | 100% |  |
| 127 | 1.7.3.1 | **Adecuaciones** |  | 14d | 2025-03-28 A | 2025-04-16 A |  | 100% |  | 2025-03-28 | 2025-04-16 | 14d | 2024-10-27 | 2024-11-16 |  |  |  | ENKI - ELECNOR L_S | 1370h | 1370h | TRANSELEC | 16-01-2025 |  | 21-01-2025 | 5 días | 06 CO-CONSTRUCCIÓN | 100,00% | 100,00% | 100% |  |
| 128 | 1.7.3.1.1 | Desmontaje de Interruptor (1) |  | 3d | 2025-03-28 A | 2025-03-31 A | 125, 114 | 100% |  | 2025-03-28 | 2025-03-31 | 3d | 2024-11-02 | 2024-11-04 |  |  | finish no earlier than 2025-03-31 | ENKI - ELECNOR L_S | 388h | 388h | TRANSELEC | 16-01-2025 | día 601,75 | 17-01-2025 | 2 días | 06 CO-CONSTRUCCIÓN | 100,00% | 100,00% | 100% | 0,74603045 |
| 129 | 1.7.3.1.2 | Desmontaje de Desconectadores SPAT (3) |  | 4d | 2025-04-11 A | 2025-04-15 A | 128 | 100% |  | 2025-04-11 | 2025-04-15 | 4d | 2024-10-27 | 2024-11-01 |  |  | start no earlier than 2025-04-11 | ENKI - ELECNOR L_S | 580h | 580h | TRANSELEC | 17-01-2025 | día 613 | 21-01-2025 | 4 días | 06 CO-CONSTRUCCIÓN | 100,00% | 100,00% | 100% | 1,116045553 |
| 130 | 1.7.3.1.3 | Demolición de Fundación de Interruptor |  | 14d | 2025-04-01 A | 2025-04-16 A | 128 | 100% |  | 2025-04-01 | 2025-04-16 | 14d | 2024-11-05 | 2024-11-14 |  |  |  | ENKI - ELECNOR L_S | 402h | 402h | TRANSELEC | 18-01-2025 | día 604 | 21-01-2025 | 3 días | 06 CO-CONSTRUCCIÓN | 100,00% | 100,00% | 100% | 0,774031593 |
| 131 | 1.7.3.2 | **Fundaciones Bajas** |  | 23d | 2025-04-01 A | 2025-05-01 A |  | 100% |  | 2025-04-01 | 2025-05-01 | 23d | 2024-11-15 | 2024-11-28 |  |  |  | ENKI - ELECNOR L_S | 402h | 402h | TRANSELEC | 22-01-2025 |  | 03-02-2025 | 11 días | 06 CO-CONSTRUCCIÓN | 100,00% | 100,00% | 100% |  |
| 132 | 1.7.3.2.1 | Fundación Interruptor |  | 27d | 2025-04-01 A | 2025-05-01 A | 130SS-1d | 100% |  | 2025-04-01 | 2025-05-01 | 27d | 2024-11-15 | 2024-11-23 |  |  | start no earlier than 2025-04-01 | ENKI - ELECNOR L_S | 402h | 402h | TRANSELEC | 22-01-2025 | día 604 | 03-02-2025 | 11 días | 06 CO-CONSTRUCCIÓN | 100,00% | 100,00% | 100% | 0,774031593 |
| 133 | 1.7.3.3 | **Estructuras Bajas** |  | 14d | 2025-04-16 A | 2025-05-03 A |  | 100% |  | 2025-04-16 | 2025-05-03 | 14d | 2024-11-24 | 2024-12-04 |  |  |  | ENKI - ELECNOR L_S | 434h | 434h | TRANSELEC | 22-01-2025 |  | 05-02-2025 | 13 días | 06 CO-CONSTRUCCIÓN | 100,00% | 100,00% | 100% |  |
| 134 | 1.7.3.3.1 | Refuerzo de Estructura Desconectadores SPAT |  | 6d | 2025-04-16 A | 2025-04-22 A | 83, 129 | 100% |  | 2025-04-16 | 2025-04-22 | 6d | 2024-11-29 | 2024-12-04 |  |  | start no earlier than 2025-04-15 | ENKI - ELECNOR L_S | 260h | 260h | TRANSELEC | 22-01-2025 | día 616,375 | 28-01-2025 | 6 días | 06 CO-CONSTRUCCIÓN | 100,00% | 100,00% | 100% | 0,500020409 |
| 135 | 1.7.3.3.2 | Montaje de Estructura Interruptor |  | 2d | 2025-05-02 A | 2025-05-03 A | 132, 83, 93 | 100% |  | 2025-05-02 | 2025-05-03 | 2d | 2024-11-24 | 2024-11-27 |  |  |  | ENKI - ELECNOR L_S | 174h | 174h | TRANSELEC | 04-02-2025 | día 629,875 | 05-02-2025 | 2 días | 06 CO-CONSTRUCCIÓN | 100,00% | 100,00% | 100% | 0,334013633 |

| ID | WBS | Task | Duration | Start | Finish | Predecessors | Complete | Baseline start | Baseline finish | Baseline duration | Baseline 1 start | Baseline 1 finish | Constraint | Calendar | Work | Actual work | Propietario | Baseline Star Rev1 | Baseline Finish Rev1 | Baseline Duration Rev1 | : | % Complete Peso | % Baseline Peso | % Baseline (Tempo) | Text11 | Entrada Peso |
| --- | --- | --- | --- | --- | --- | --- | --- | --- | --- | --- | --- | --- | --- | --- | --- | --- | --- | --- | --- | --- | --- | --- | --- | --- | --- | --- |
| 136 | 1.7.3.4 | **Equipos Primarios** | 11d | 2025-04-29 A | 2025-05-13 A |  | 100% | 2025-04-29 | 2025-05-13 | 11d | 2024-12-05 | 2024-12-20 |  | ENKI - ELECNOR L_S | 1381h | 1381h | TRANSELEC | 24-01-2025 | 14-02-2025 | 19 días | 06 CO-CONSTRUCCIÓN | 100,00% | 100,00% | 100% |  |  |
| 137 | 1.7.3.4.1 | Montaje de Desconectadores SPAT | 6d | 2025-04-29 A | 2025-05-05 A | 134FS-4d, 105 | 100% | 2025-04-29 | 2025-05-05 | 6d | 2024-12-05 | 2024-12-10 | finish no earlier than 2025-05-05 | ENKI - ELECNOR L_S | 306h | 306h | TRANSELEC | 24-01-2025 | 30-01-2025 | 6 días | 06 CO-CONSTRUCCIÓN | 100,00% | 100,00% | 100% | día 626,5 | 0,588024001 |
| 138 | 1.7.3.4.2 | Pruebas SAT Desconectadores SPAT | 3d | 2025-05-02 A | 2025-05-05 A | 137FS-3d | 100% | 2025-05-02 | 2025-05-05 | 3d | 2024-12-11 | 2024-12-16 |  | ENKI - ELECNOR L_S | 69h | 69h | TRANSELEC | 28-01-2025 | 30-01-2025 | 3 días | 06 CO-CONSTRUCCIÓN | 100,00% | 100,00% | 100% | día 629,875 | 0,132005388 |
| 139 | 1.7.3.4.3 | Montaje Interruptor | 6d | 2025-05-05 A | 2025-05-10 A | 135, 93 | 100% | 2025-05-05 | 2025-05-10 | 6d | 2024-12-05 | 2024-12-08 |  | ENKI - ELECNOR L_S | 102h | 102h | TRANSELEC | 06-02-2025 | 12-02-2025 | 6 días | 06 CO-CONSTRUCCIÓN | 100,00% | 100,00% | 100% | día 632,125 | 0,196008 |
| 140 | 1.7.3.4.4 | Pruebas SAT Interruptor | 2d | 2025-05-12 A | 2025-05-13 A | 139, 143 | 100% | 2025-05-12 | 2025-05-13 | 2d | 2024-12-09 | 2024-12-11 |  | ENKI - ELECNOR L_S | 26h | 26h | TRANSELEC | 13-02-2025 | 14-02-2025 | 2 días | 06 CO-CONSTRUCCIÓN | 100,00% | 100,00% | 100% | día 637,75 | 0,050002041 |
| 141 | 1.7.3.4.5 | Conexionado de equipos y estructura a MPT | 3d | 2025-05-08 A | 2025-05-10 A | 137FF, 139FF | 100% | 2025-05-08 | 2025-05-10 | 3d | 2024-12-11 | 2024-12-20 | start no earlier than 2025-01-24 | ENKI - ELECNOR L_S | 878h | 878h | TRANSELEC | 10-02-2025 | 12-02-2025 | 3 días | 06 CO-CONSTRUCCIÓN | 100,00% | 100,00% | 100% | día 634,375 | 1,688068901 |
| 142 | 1.7.3.5 | **Cables de Control, Fuerza y Conductor AT** | 9d | 2025-04-29 A | 2025-05-09 A |  | 100% | 2025-04-29 | 2025-05-09 | 9d | 2024-12-11 | 2024-12-25 |  | ENKI - ELECNOR L_S | 1602h | 1602h | TRANSELEC | 24-01-2025 | 04-02-2025 | 10 días | 06 CO-CONSTRUCCIÓN | 100,00% | 100,00% | 100% |  |  |
| 143 | 1.7.3.5.1 | Tendido Cable de Control y Fuerza | 10d | 2025-04-29 A | 2025-05-09 A | 137SS | 100% | 2025-04-29 | 2025-05-09 | 10d | 2024-12-11 | 2024-12-25 |  | ENKI - ELECNOR L_S | 1335h | 1335h | TRANSELEC | 24-01-2025 | 04-02-2025 | 10 días | 06 CO-CONSTRUCCIÓN | 100,00% | 100,00% | 100% | día 626,5 | 2,568104821 |
| 144 | 1.7.3.5.2 | Tendido y Conexionado Conductor AT | 4d | 2025-04-29 A | 2025-05-02 A | 143SS | 100% | 2025-04-29 | 2025-05-02 | 4d | 2024-12-11 | 2024-12-25 |  | ENKI - ELECNOR L_S | 267h | 267h | TRANSELEC | 24-01-2025 | 28-01-2025 | 4 días | 06 CO-CONSTRUCCIÓN | 100,00% | 100,00% | 100% | día 626,5 | 0,51402098 |
| 145 | 1.7.3.6 | **Sistema de Control y Protección** | 9d | 2025-05-06 A | 2025-05-16 A |  | 100% | 2025-05-06 | 2025-05-16 | 9d | 2024-12-26 | 2025-01-01 |  | ENKI - ELECNOR L_S | 76h | 76h | TRANSELEC | 31-01-2025 | 06-02-2025 | 6 días | 06 CO-CONSTRUCCIÓN | 100,00% | 100,00% | 100% |  |  |
| 146 | 1.7.3.6.1 | Carga de ajustes y Pruebas de Funcionalidad | 10d | 2025-05-06 A | 2025-05-16 A | 143FS-4d, 144FS-4d | 100% | 2025-05-06 | 2025-05-16 | 10d | 2024-12-26 | 2025-01-01 |  | ENKI - ELECNOR L_S | 76h | 76h | TRANSELEC | 31-01-2025 | 06-02-2025 | 6 días | 06 CO-CONSTRUCCIÓN | 100,00% | 100,00% | 100% | día 632,125 | 0,146005959 |
| 147 | 1.7.3.7 | **Comisionamiento** | 24d | 2025-05-17 A | 2025-06-19 A |  | 100% | 2025-05-17 | 2025-06-19 | 24d | 2025-01-02 | 2025-01-12 |  | ENKI - ELECNOR L_S | 441h | 441h | TRANSELEC | 07-02-2025 | 18-02-2025 | 10 días | 08 PES-PUESTA EN SERVICIO | 100,00% | 100,00% | 100% |  |  |
| 148 | 1.7.3.7.1 | Pruebas finales | 1d | 2025-05-17 A | 2025-05-17 A | 146 | 100% | 2025-05-17 | 2025-05-17 | 1d | 2025-01-02 | 2025-01-02 |  | ENKI - ELECNOR L_S | 114h | 114h | TRANSELEC | 07-02-2025 | 07-02-2025 | 1 día | 08 PES-PUESTA EN SERVICIO | 100,00% | 100,00% | 100% | día 642,25 | 0,22000898 |
| 149 | 1.7.3.7.2 | Pruebas de funciones de protección | 6d | 2025-05-17 A | 2025-05-23 A | 146 | 100% | 2025-05-17 | 2025-05-23 | 6d | 2025-01-02 | 2025-01-08 |  | ENKI - ELECNOR L_S | 145h | 145h | TRANSELEC | 07-02-2025 | 13-02-2025 | 6 días | 08 PES-PUESTA EN SERVICIO | 100,00% | 100,00% | 100% | día 642,25 | 0,278011347 |
| 150 | 1.7.3.7.3 | Conexión de los bajantes a Barra de Transferencia | 1d | 2025-05-24 A | 2025-05-24 A | 149 | 100% | 2025-05-24 | 2025-05-24 | 1d | 2025-01-09 | 2025-01-09 |  | ENKI - ELECNOR L_S | 53h | 53h | TRANSELEC | 14-02-2025 | 14-02-2025 | 1 día | 08 PES-PUESTA EN SERVICIO | 100,00% | 100,00% | 100% | día 647,875 | 0,102004163 |
| 151 | 1.7.3.7.4 | Conexión de los bajantes a Barra de Principal Sección 1 | 1d | 2025-05-26 A | 2025-05-26 A | 149, 150 | 100% | 2025-05-26 | 2025-05-26 | 1d | 2025-01-10 | 2025-01-10 |  | ENKI - ELECNOR L_S | 53h | 53h | TRANSELEC | 15-02-2025 | 15-02-2025 | 1 día | 08 PES-PUESTA EN SERVICIO | 100,00% | 100,00% | 100% | día 649 | 0,102004163 |
| 152 | 1.7.3.7.5 | Conexión de los bajantes a Barra de Principal Sección 2 | 1d | 2025-05-27 A | 2025-05-27 A | 149, 151 | 100% | 2025-05-27 | 2025-05-27 | 1d | 2025-01-11 | 2025-01-11 |  | ENKI - ELECNOR L_S | 53h | 53h | TRANSELEC | 17-02-2025 | 17-02-2025 | 1 día | 08 PES-PUESTA EN SERVICIO | 100,00% | 100,00% | 100% | día 649 | 0,102004163 |
| 153 | 1.7.3.7.6 | Energización de paño Acoplador | 1d | 2025-06-19 A | 2025-06-19 A | 141, 148, 149, 152, 324 | 100% | 2025-06-19 | 2025-06-19 | 1d | 2025-01-12 | 2025-01-22 | start no earlier than 2025-06-19 | ENKI - ELECNOR L_S | 23h | 23h | TRANSELEC | 18-02-2025 | 18-02-2025 | 1 día | 08 PES-PUESTA EN SERVICIO | 100,00% | 100,00% | 100% | día 668,125 | 0,044001796 |
| 154 | 1.7.4 | **Paño J2 - Circuito 1** | 44d | 2025-07-02 A | 2025-08-30 A |  | 100% | 2025-07-02 | 2025-08-30 | 44d | 2024-10-25 |  |  | ENKI - ELECNOR L_S | 8566h | 8566h | TRANSELEC | 25-02-2025 | 21-04-2025 | 48 días | 06 CO-CONSTRUCCIÓN | 100,00% | 100,00% | 100% |  |  |
| 155 | 1.7.4.1 | **Etapa 1 (Tramo Paño J2)** | 44d | 2025-07-02 A | 2025-08-30 A |  | 100% | 2025-07-02 | 2025-08-30 | 44d |  |  |  | ENKI - ELECNOR L_S | 5133h | 5133h |  | 25-02-2025 | 24-03-2025 | 24 días |  | 100,00% | 100,00% | 100% | día 1 |  |
| 156 | 1.7.4.1.1 | **Adecuaciones** | 11d | 2025-07-02 A | 2025-07-16 A |  | 100% | 2025-07-02 | 2025-07-16 | 11d | 2024-10-25 | 2024-11-13 |  | ENKI - ELECNOR L_S | 990h | 990h | TRANSELEC | 25-02-2025 | 01-03-2025 | 5 días | 06 CO-CONSTRUCCIÓN | 100,00% | 100,00% | 100% |  |  |
| 157 | 1.7.4.1.1.1 | Desmontaje de Interruptor | 8d | 2025-07-02 A | 2025-07-10 A | 124, 125, 116SS, 117, 118, 153 | 100% | 2025-07-02 | 2025-07-10 | 8d | 2024-10-30 | 2024-11-01 | start no earlier than 2025-06-02 | ENKI - ELECNOR L_S | 327h | 327h | TRANSELEC | 25-02-2025 | 26-02-2025 | 2 días | 06 CO-CONSTRUCCIÓN | 100,00% | 100,00% | 100% | día 678,25 | 0,628025634 |
| 158 | 1.7.4.1.1.2 | Desmontaje de Desconectador CPAT | 3d | 2025-07-02 A | 2025-07-04 A | 117, 118, 124, 125, 157FS-8d | 100% | 2025-07-02 | 2025-07-04 | 3d | 2024-10-25 | 2024-10-27 | start no earlier than 2025-07-02 | ENKI - ELECNOR L_S | 162h | 162h | TRANSELEC | 26-02-2025 | 27-02-2025 | 2 días | 06 CO-CONSTRUCCIÓN | 100,00% | 100,00% | 100% | día 678,25 | 0,312012735 |
| 159 | 1.7.4.1.1.3 | Desmontaje de Decconectador SPAT | 3d | 2025-07-03 A | 2025-07-05 A | 124, 125, 158FS-2d, 116SS, 117, 118 | 100% | 2025-07-03 | 2025-07-05 | 3d | 2024-10-28 | 2024-10-29 |  | ENKI - ELECNOR L_S | 162h | 162h | TRANSELEC | 27-02-2025 | 28-02-2025 | 2 días | 06 CO-CONSTRUCCIÓN | 100,00% | 100,00% | 100% | día 679,375 | 0,312012735 |
| 160 | 1.7.4.1.1.4 | Demolición de Fundación Interruptor | 6d | 2025-07-10 A | 2025-07-16 A | 157FS-1d | 100% | 2025-07-10 | 2025-07-16 | 6d | 2024-11-02 | 2024-11-11 |  | ENKI - ELECNOR L_S | 339h | 339h | TRANSELEC | 27-02-2025 | 01-03-2025 | 3 días | 06 CO-CONSTRUCCIÓN | 100,00% | 100,00% | 100% | día 685 | 0,652026613 |

| ID | WBS | Task | Duration | Start | Finish | Predecessors | Complete | Baseline start | Baseline finish | Baseline duration | Baseline 1 start | Baseline 1 finish | Calendar | Work | Actual work | Propietario | Baseline Star Rev1 | Baseline Finish Rev1 | Baseline Duration Rev1 | : | % Complete Peso | % Baseline Peso | % Baseline (Tempo) | Text11 | Entrada Peso |
| --- | --- | --- | --- | --- | --- | --- | --- | --- | --- | --- | --- | --- | --- | --- | --- | --- | --- | --- | --- | --- | --- | --- | --- | --- | --- |
| 161 | 1.7.4.1.2 | **Fundaciones Bajas** | 13d | 2025-07-10 A | 2025-07-26 A |  | 100% | 2025-07-10 | 2025-07-26 | 13d | 2024-11-14 | 2024-12-15 | ENKI - ELECNOR L_S | 962h | 962h | TRANSELEC | 03-03-2025 | 14-03-2025 | 11 días | 06 CO-CONSTRUCCIÓN | 100,00% | 100,00% | 100% |  |  |
| 162 | 1.7.4.1.2.1 | Fundación Interruptor | 13d | 2025-07-10 A | 2025-07-26 A | 160SS | 100% | 2025-07-10 | 2025-07-26 | 13d | 2024-11-30 | 2024-12-08 | ENKI - ELECNOR L_S | 962h | 962h | TRANSELEC | 03-03-2025 | 14-03-2025 | 11 días | 06 CO-CONSTRUCCIÓN | 100,00% | 100,00% | 100% | día 685 | 1,850075513 |
| 163 | 1.7.4.1.3 | **Estructuras Bajas** | 17.2d | 2025-07-05 A | 2025-07-30 A |  | 100% | 2025-07-05 | 2025-07-30 | 17.2d | 2024-11-24 | 2024-12-18 | ENKI - ELECNOR L_S | 293h | 293h | TRANSELEC | 28-02-2025 | 17-03-2025 | 15 días | 06 CO-CONSTRUCCIÓN | 100,00% | 100,00% | 100% |  |  |
| 164 | 1.7.4.1.3.1 | Refuerzo de Estructura Desconectador CPAT | 2d | 2025-07-05 A | 2025-07-07 A | 83, 158 | 100% | 2025-07-05 | 2025-07-07 | 2d | 2024-11-24 | 2024-11-27 | ENKI - ELECNOR L_S | 147h | 147h | TRANSELEC | 28-02-2025 | 01-03-2025 | 2 días | 06 CO-CONSTRUCCIÓN | 100,00% | 100,00% | 100% | día 681,625 | 0,282011511 |
| 165 | 1.7.4.1.3.2 | Refuerzo de Estructura Desconectador SPAT | 2d | 2025-07-09 A | 2025-07-10 A | 83, 159FS+2d | 100% | 2025-07-09 | 2025-07-10 | 2d | 2024-11-30 | 2024-12-02 | ENKI - ELECNOR L_S | 73h | 73h | TRANSELEC | 01-03-2025 | 03-03-2025 | 2 días | 06 CO-CONSTRUCCIÓN | 100,00% | 100,00% | 100% | día 683,875 | 0,140005715 |
| 166 | 1.7.4.1.3.3 | Montaje de Estructura Interruptor | 1d | 2025-07-26 A | 2025-07-30 A | 162FS+1d, 93FS+1d | 100% | 2025-07-26 | 2025-07-30 | 1d | 2024-12-09 | 2024-12-12 | ENKI - ELECNOR L_S | 73h | 73h | TRANSELEC | 15-03-2025 | 17-03-2025 | 2 días | 06 CO-CONSTRUCCIÓN | 100,00% | 100,00% | 100% | día 698,5 | 0,140005715 |
| 167 | 1.7.4.1.4 | **Equipos Primarios** | 25d | 2025-07-09 A | 2025-08-12 A |  | 100% | 2025-07-09 | 2025-08-12 | 25d | 2024-11-28 | 2024-12-31 | ENKI - ELECNOR L_S | 1146h | 1146h | TRANSELEC | 03-03-2025 | 24-03-2025 | 19 días | 06 CO-CONSTRUCCIÓN | 100,00% | 100,00% | 100% |  |  |
| 168 | 1.7.4.1.4.1 | Montaje de Desconectador CPAT | 3d | 2025-07-09 A | 2025-07-11 A | 105FS+1d, 164FS+1d | 100% | 2025-07-09 | 2025-07-11 | 3d | 2024-11-28 | 2024-12-01 | ENKI - ELECNOR L_S | 172h | 172h | TRANSELEC | 03-03-2025 | 04-03-2025 | 2 días | 06 CO-CONSTRUCCIÓN | 100,00% | 100,00% | 100% | día 683,875 | 0,33001347 |
| 169 | 1.7.4.1.4.2 | Pruebas SAT Desconectador CPAT | 2d | 2025-08-09 A | 2025-08-12 A | 168FS+20d | 100% | 2025-08-09 | 2025-08-12 | 2d | 2024-12-02 | 2024-12-03 | ENKI - ELECNOR L_S | 38h | 38h | TRANSELEC | 05-03-2025 | 06-03-2025 | 2 días | 06 CO-CONSTRUCCIÓN | 100,00% | 100,00% | 100% | día 709,75 | 0,074003021 |
| 170 | 1.7.4.1.4.3 | Montaje de Decconectador SPAT | 2d | 2025-07-09 A | 2025-07-10 A | 105, 165FS-2d, 168FS-5d | 100% | 2025-07-09 | 2025-07-10 | 2d | 2024-12-03 | 2024-12-05 | ENKI - ELECNOR L_S | 85h | 85h | TRANSELEC | 05-03-2025 | 06-03-2025 | 2 días | 06 CO-CONSTRUCCIÓN | 100,00% | 100,00% | 100% | día 683,875 | 0,164006694 |
| 171 | 1.7.4.1.4.4 | Pruebas SAT Desconectador SPAT | 2d | 2025-08-08 A | 2025-08-09 A | 170FS+20d | 100% | 2025-08-08 | 2025-08-09 | 2d | 2024-12-06 | 2024-12-07 | ENKI - ELECNOR L_S | 26h | 26h | TRANSELEC | 07-03-2025 | 08-03-2025 | 2 días | 06 CO-CONSTRUCCIÓN | 100,00% | 100,00% | 100% | día 708,625 | 0,050002041 |
| 172 | 1.7.4.1.4.5 | Montaje Interruptor | 3d | 2025-07-29 A | 2025-07-31 A | 93FS+1d, 166SS+1d | 100% | 2025-07-29 | 2025-07-31 | 3d | 2024-12-13 | 2024-12-16 | ENKI - ELECNOR L_S | 73h | 73h | TRANSELEC | 18-03-2025 | 20-03-2025 | 3 días | 06 CO-CONSTRUCCIÓN | 100,00% | 100,00% | 100% | día 699,625 | 0,140005715 |
| 173 | 1.7.4.1.4.6 | Pruebas SAT Interruptor | 2d | 2025-08-07 A | 2025-08-08 A | 172FS+4d | 100% | 2025-08-07 | 2025-08-08 | 2d | 2024-12-17 | 2024-12-19 | ENKI - ELECNOR L_S | 26h | 26h | TRANSELEC | 21-03-2025 | 24-03-2025 | 3 días | 06 CO-CONSTRUCCIÓN | 100,00% | 100,00% | 100% | día 707,5 | 0,050002041 |
| 174 | 1.7.4.1.4.7 | Conexionado de equipos y estructura a MPT | 2d | 2025-07-30 A | 2025-07-31 A | 168FF, 170FF, 172FF | 100% | 2025-07-30 | 2025-07-31 | 2d | 2024-12-22 | 2024-12-31 | ENKI - ELECNOR L_S | 726h | 726h | TRANSELEC | 19-03-2025 | 20-03-2025 | 2 días | 06 CO-CONSTRUCCIÓN | 100,00% | 100,00% | 100% | día 700,75 | 1,396056982 |
| 175 | 1.7.4.1.5 | **Cables de Control, Fuerza y Conductor AT** | 7d | 2025-07-30 A | 2025-08-07 A |  | 100% | 2025-07-30 | 2025-08-07 | 7d | 2024-12-22 | 2025-01-05 | ENKI - ELECNOR L_S | 1349h | 1349h | TRANSELEC | 05-03-2025 | 22-03-2025 | 16 días | 06 CO-CONSTRUCCIÓN | 100,00% | 100,00% | 100% |  |  |
| 176 | 1.7.4.1.5.1 | Tendido Cable de Control y Fuerza | 6d | 2025-07-31 A | 2025-08-07 A | 87FS+13d, 109FS+13d, 168FS+13d | 100% | 2025-07-31 | 2025-08-07 | 6d | 2024-12-22 | 2025-01-05 | ENKI - ELECNOR L_S | 1124h | 1124h | TRANSELEC | 05-03-2025 | 07-03-2025 | 3 días | 06 CO-CONSTRUCCIÓN | 100,00% | 100,00% | 100% | día 701,875 | 2,162088248 |
| 177 | 1.7.4.1.5.2 | Tendido y Conexionado Conductor AT | 5d | 2025-07-30 A | 2025-08-05 A | 109, 168, 170, 172FS-2d | 100% | 2025-07-30 | 2025-08-05 | 5d | 2024-12-22 | 2025-01-05 | ENKI - ELECNOR L_S | 225h | 225h | TRANSELEC | 19-03-2025 | 22-03-2025 | 4 días | 06 CO-CONSTRUCCIÓN | 100,00% | 100,00% | 100% | día 700,75 | 0,432017633 |
| 178 | 1.7.4.1.6 | **Sistema de Control y Protección** | 2d | 2025-08-21 A | 2025-08-22 A |  | 100% | 2025-08-21 | 2025-08-22 | 2d | 2025-01-06 | 2025-01-12 | ENKI - ELECNOR L_S | 64h | 64h | TRANSELEC | 04-03-2025 | 14-03-2025 | 10 días | 06 CO-CONSTRUCCIÓN | 100,00% | 100,00% | 100% |  |  |
| 179 | 1.7.4.1.6.1 | Carga de ajustes y Pruebas de Funcionalidad | 2d | 2025-08-21 A | 2025-08-22 A | 176FS+9d | 100% | 2025-08-21 | 2025-08-22 | 2d | 2025-01-06 | 2025-01-12 | ENKI - ELECNOR L_S | 64h | 64h | TRANSELEC | 04-03-2025 | 14-03-2025 | 10 días | 06 CO-CONSTRUCCIÓN | 100,00% | 100,00% | 100% | día 718,75 | 0,124005061 |
| 180 | 1.7.4.1.7 | **Comisionamiento** | 6d | 2025-08-23 A | 2025-08-30 A |  | 100% | 2025-08-23 | 2025-08-30 | 6d | 2025-01-13 | 2025-01-22 | ENKI - ELECNOR L_S | 329h | 329h | TRANSELEC | 15-03-2025 | 24-03-2025 | 8 días | 08 PES-PUESTA EN SERVICIO | 100,00% | 100,00% | 100% |  |  |
| 181 | 1.7.4.1.7.1 | Pruebas finales | 3d | 2025-08-23 A | 2025-08-27 A | 179 | 100% | 2025-08-23 | 2025-08-27 | 3d | 2025-01-13 | 2025-01-13 | ENKI - ELECNOR L_S | 97h | 97h | TRANSELEC | 15-03-2025 | 17-03-2025 | 2 días | 08 PES-PUESTA EN SERVICIO | 100,00% | 100,00% | 100% | día 721 | 0,186007592 |
| 182 | 1.7.4.1.7.2 | Pruebas de funciones de protección | 4d | 2025-08-23 A | 2025-08-28 A | 179 | 100% | 2025-08-23 | 2025-08-28 | 4d | 2025-01-13 | 2025-01-19 | ENKI - ELECNOR L_S | 122h | 122h | TRANSELEC | 15-03-2025 | 21-03-2025 | 6 días | 08 PES-PUESTA EN SERVICIO | 100,00% | 100,00% | 100% | día 721 | 0,234009551 |
| 183 | 1.7.4.1.7.3 | Conexión de los bajantes a Barra de Transferencia | 1d | 2025-08-29 A | 2025-08-29 A | 182 | 100% | 2025-08-29 | 2025-08-29 | 1d | 2025-01-20 | 2025-01-20 | ENKI - ELECNOR L_S | 45h | 45h | TRANSELEC | 22-03-2025 | 22-03-2025 | 1 día | 08 PES-PUESTA EN SERVICIO | 100,00% | 100,00% | 100% | día 725,5 | 0,08600351 |
| 184 | 1.7.4.1.7.4 | Conexión de los bajantes a Barra de Principal Sección 2 | 1d | 2025-08-29 A | 2025-08-29 A | 183SS | 100% | 2025-08-29 | 2025-08-29 | 1d | 2025-01-21 | 2025-01-21 | ENKI - ELECNOR L_S | 45h | 45h | TRANSELEC | 22-03-2025 | 22-03-2025 | 1 día | 08 PES-PUESTA EN SERVICIO | 100,00% | 100,00% | 100% | día 725,5 | 0,08600351 |
| 185 | 1.7.4.1.7.5 | Pre-energización de paño J2 | 1d | 2025-08-30 A | 2025-08-30 A | 182, 183, 184, 174, 181, 177 | 100% | 2025-08-30 | 2025-08-30 | 1d | 2025-01-22 | 2025-01-22 | ENKI - ELECNOR L_S | 20h | 20h | TRANSELEC | 24-03-2025 | 24-03-2025 | 1 día | 08 PES-PUESTA EN SERVICIO | 100,00% | 100,00% | 100% | día 726,625 | 0,038001551 |

| ID | WBS | Task | Duration | Start | Finish | Predecessors | Complete | Remaining | Baseline start | Baseline finish | Baseline duration | Baseline 1 start | Baseline 1 finish | Total slack | Free slack | Constraint | Calendar | Work | Actual work | Propietario | Baseline Star Rev1 | Baseline Finish Rev1 | Baseline Duration Rev1 | : | % Complete Peso | % Baseline Peso | % Baseline (Tempo) | Text11 | Entrada Peso |
| --- | --- | --- | --- | --- | --- | --- | --- | --- | --- | --- | --- | --- | --- | --- | --- | --- | --- | --- | --- | --- | --- | --- | --- | --- | --- | --- | --- | --- | --- |
| 186 | 1.7.4.2 | **Etapa 2 (Tramo Transferencia)** | 17d | 2025-07-31 A | 2025-08-22 A |  | 100% |  | 2025-07-31 | 2025-08-22 | 17d | 2024-10-25 | 2025-01-22 |  |  |  | ENKI - ELECNOR L_S | 3433h | 3433h | TRANSELEC | 25-03-2025 | 21-04-2025 | 24 días | 06 CO-CONSTRUCCIÓN | 100,00% | 100,00% | 100% |  |  |
| 187 | 1.7.4.2.1 | **Adecuaciones** | 4d | 2025-08-08 A | 2025-08-13 A |  | 100% |  | 2025-08-08 | 2025-08-13 | 4d | 2024-10-25 | 2024-11-13 |  |  |  | ENKI - ELECNOR L_S | 344h | 344h | TRANSELEC | 25-03-2025 | 29-03-2025 | 5 días | 06 CO-CONSTRUCCIÓN | 100,00% | 100,00% | 100% |  |  |
| 188 | 1.7.4.2.1.1 | Desmontaje de Desconectadores SPAT (1) | 1d | 2025-08-08 A | 2025-08-08 A | 185FS-17d | 100% |  | 2025-08-08 | 2025-08-08 | 1d | 2024-10-25 | 2024-10-27 |  |  | start no earlier than 2025-07-28 | ENKI - ELECNOR L_S | 172h | 172h | TRANSELEC | 25-03-2025 | 27-03-2025 | 3 días | 06 CO-CONSTRUCCIÓN | 100,00% | 100,00% | 100% | día 708,625 | 0,33001347 |
| 189 | 1.7.4.2.1.2 | Desmontaje de TTCC | 1d | 2025-08-13 A | 2025-08-13 A | 188FS+2d | 100% |  | 2025-08-13 | 2025-08-13 | 1d | 2024-11-02 | 2024-11-03 |  |  |  | ENKI - ELECNOR L_S | 172h | 172h | TRANSELEC | 28-03-2025 | 29-03-2025 | 2 días | 06 CO-CONSTRUCCIÓN | 100,00% | 100,00% | 100% | día 712 | 0,33001347 |
| 190 | 1.7.4.2.2 | **Estructuras Bajas** | 1d | 2025-08-09 A | 2025-08-09 A |  | 100% |  | 2025-08-09 | 2025-08-09 | 1d | 2024-11-24 | 2024-12-18 |  |  |  | ENKI - ELECNOR L_S | 154h | 154h | TRANSELEC | 28-03-2025 | 29-03-2025 | 2 días | 06 CO-CONSTRUCCIÓN | 100,00% | 100,00% | 100% |  |  |
| 191 | 1.7.4.2.2.1 | Refuerzo de Estructura Desconectadores SPAT | 1d | 2025-08-09 A | 2025-08-09 A | 83, 188 | 100% |  | 2025-08-09 | 2025-08-09 | 1d | 2024-11-24 | 2024-11-27 |  |  |  | ENKI - ELECNOR L_S | 154h | 154h | TRANSELEC | 28-03-2025 | 29-03-2025 | 2 días | 06 CO-CONSTRUCCIÓN | 100,00% | 100,00% | 100% | día 709,75 | 0,296012082 |
| 192 | 1.7.4.2.3 | **Equipos Primarios** | 6d | 2025-08-09 A | 2025-08-16 A |  | 100% |  | 2025-08-09 | 2025-08-16 | 6d | 2024-11-28 | 2024-12-31 |  |  |  | ENKI - ELECNOR L_S | 1098h | 1098h | TRANSELEC | 31-03-2025 | 08-04-2025 | 8 días | 06 CO-CONSTRUCCIÓN | 100,00% | 100,00% | 100% |  |  |
| 193 | 1.7.4.2.3.1 | Montaje de Desconectadores SPAT | 2d | 2025-08-09 A | 2025-08-12 A | 191FS-1d, 105FS-1d | 100% |  | 2025-08-09 | 2025-08-12 | 2d | 2024-11-28 | 2024-12-01 |  |  |  | ENKI - ELECNOR L_S | 181h | 181h | TRANSELEC | 31-03-2025 | 02-04-2025 | 3 días | 06 CO-CONSTRUCCIÓN | 100,00% | 100,00% | 100% | día 709,75 | 0,348014205 |
| 194 | 1.7.4.2.3.2 | Pruebas SAT Desconectadores SPAT | 1d | 2025-08-13 A | 2025-08-13 A | 193 | 100% |  | 2025-08-13 | 2025-08-13 | 1d | 2024-12-02 | 2024-12-03 |  |  |  | ENKI - ELECNOR L_S | 41h | 41h | TRANSELEC | 03-04-2025 | 04-04-2025 | 2 días | 06 CO-CONSTRUCCIÓN | 100,00% | 100,00% | 100% | día 712 | 0,078003184 |
| 195 | 1.7.4.2.3.3 | Montaje de TTCC | 1d | 2025-08-14 A | 2025-08-14 A | 99, 189 | 100% |  | 2025-08-14 | 2025-08-14 | 1d | 2024-12-19 | 2024-12-21 |  |  |  | ENKI - ELECNOR L_S | 77h | 77h | TRANSELEC | 31-03-2025 | 02-04-2025 | 3 días | 06 CO-CONSTRUCCIÓN | 100,00% | 100,00% | 100% | día 713,125 | 0,148006041 |
| 196 | 1.7.4.2.3.4 | Pruebas SAT TTCC | 3d | 2025-08-13 A | 2025-08-15 A | 195FS-2d | 100% |  | 2025-08-13 | 2025-08-15 | 3d | 2024-12-22 | 2024-12-23 |  |  |  | ENKI - ELECNOR L_S | 21h | 21h | TRANSELEC | 03-04-2025 | 04-04-2025 | 2 días | 06 CO-CONSTRUCCIÓN | 100,00% | 100,00% | 100% | día 712 | 0,040001633 |
| 197 | 1.7.4.2.3.5 | Conexionado de equipos y estructura a MPT | 2d | 2025-08-15 A | 2025-08-16 A | 193, 195 | 100% |  | 2025-08-15 | 2025-08-16 | 2d | 2024-12-22 | 2024-12-31 |  |  |  | ENKI - ELECNOR L_S | 778h | 778h | TRANSELEC | 03-04-2025 | 08-04-2025 | 5 días | 06 CO-CONSTRUCCIÓN | 100,00% | 100,00% | 100% | día 714,25 | 1,496061064 |
| 198 | 1.7.4.2.4 | **Cables de Control, Fuerza y Conductor AT** | 4d | 2025-07-31 A | 2025-08-05 A |  | 100% |  | 2025-07-31 | 2025-08-05 | 4d | 2024-12-22 | 2025-01-05 |  |  |  | ENKI - ELECNOR L_S | 1421h | 1421h | TRANSELEC | 03-04-2025 | 05-04-2025 | 3 días | 06 CO-CONSTRUCCIÓN | 100,00% | 100,00% | 100% |  |  |
| 199 | 1.7.4.2.4.1 | Tendido Cable de Control y Fuerza | 2d | 2025-07-31 A | 2025-08-01 A | 193FS-11d, 195FS-11d, 87FS-11d, 109FS-11d | 100% |  | 2025-07-31 | 2025-08-01 | 2d | 2024-12-22 | 2025-01-05 |  |  |  | ENKI - ELECNOR L_S | 1184h | 1184h | TRANSELEC | 03-04-2025 | 05-04-2025 | 3 días | 06 CO-CONSTRUCCIÓN | 100,00% | 100,00% | 100% | día 701,875 | 2,276092902 |
| 200 | 1.7.4.2.4.2 | Tendido y Conexionado Conductor AT | 2d | 2025-08-02 A | 2025-08-05 A | 193FS-9d, 195FS-9d, 109FS-9d | 100% |  | 2025-08-02 | 2025-08-05 | 2d | 2024-12-22 | 2025-01-05 |  |  |  | ENKI - ELECNOR L_S | 237h | 237h | TRANSELEC | 03-04-2025 | 04-04-2025 | 2 días | 06 CO-CONSTRUCCIÓN | 100,00% | 100,00% | 100% | día 704,125 | 0,456018613 |
| 201 | 1.7.4.2.5 | **Sistema de Control y Protección** | 7d | 2025-08-12 A | 2025-08-20 A |  | 100% |  | 2025-08-12 | 2025-08-20 | 7d | 2025-01-06 | 2025-01-12 |  |  |  | ENKI - ELECNOR L_S | 68h | 68h | TRANSELEC | 07-04-2025 | 09-04-2025 | 3 días | 06 CO-CONSTRUCCIÓN | 100,00% | 100,00% | 100% |  |  |
| 202 | 1.7.4.2.5.1 | Carga de ajustes y Pruebas de Funcionalidad | 7d | 2025-08-12 A | 2025-08-20 A | 196FS-4d | 100% |  | 2025-08-12 | 2025-08-20 | 7d | 2025-01-06 | 2025-01-12 |  |  |  | ENKI - ELECNOR L_S | 68h | 68h | TRANSELEC | 07-04-2025 | 09-04-2025 | 3 días | 06 CO-CONSTRUCCIÓN | 100,00% | 100,00% | 100% | día 710,875 | 0,130005306 |
| 203 | 1.7.4.2.6 | **Comisionamiento** | 4d | 2025-08-19 A | 2025-08-22 A |  | 100% |  | 2025-08-19 | 2025-08-22 | 4d | 2025-01-13 | 2025-01-22 |  |  |  | ENKI - ELECNOR L_S | 348h | 348h | TRANSELEC | 10-04-2025 | 21-04-2025 | 10 días | 08 PES-PUESTA EN SERVICIO | 100,00% | 100,00% | 100% |  |  |
| 204 | 1.7.4.2.6.1 | Pruebas finales | 1d | 2025-08-20 A | 2025-08-20 A | 202FS-1d | 100% |  | 2025-08-20 | 2025-08-20 | 1d | 2025-01-13 | 2025-01-13 |  |  |  | ENKI - ELECNOR L_S | 102h | 102h | TRANSELEC | 10-04-2025 | 10-04-2025 | 1 día | 08 PES-PUESTA EN SERVICIO | 100,00% | 100,00% | 100% | día 717,625 | 0,196008 |
| 205 | 1.7.4.2.6.2 | Pruebas de funciones de protección | 4d | 2025-08-19 A | 2025-08-22 A | 202FS-2d | 100% |  | 2025-08-19 | 2025-08-22 | 4d | 2025-01-13 | 2025-01-19 |  |  |  | ENKI - ELECNOR L_S | 129h | 129h | TRANSELEC | 10-04-2025 | 17-04-2025 | 7 días | 08 PES-PUESTA EN SERVICIO | 100,00% | 100,00% | 100% | día 716,5 | 0,248010123 |
| 206 | 1.7.4.2.6.3 | Conexión de los bajantes a Barra de Transferencia | 3d | 2025-08-20 A | 2025-08-22 A | 205FF | 100% |  | 2025-08-20 | 2025-08-22 | 3d | 2025-01-20 | 2025-01-20 |  |  |  | ENKI - ELECNOR L_S | 48h | 48h | TRANSELEC | 18-04-2025 | 18-04-2025 | 1 día | 08 PES-PUESTA EN SERVICIO | 100,00% | 100,00% | 100% | día 717,625 | 0,092003755 |
| 207 | 1.7.4.2.6.4 | Conexión de los bajantes a Circuito 1 | 3d | 2025-08-20 A | 2025-08-22 A | 206SS | 100% |  | 2025-08-20 | 2025-08-22 | 3d | 2025-01-21 | 2025-01-21 |  |  |  | ENKI - ELECNOR L_S | 48h | 48h | TRANSELEC | 19-04-2025 | 19-04-2025 | 1 día | 08 PES-PUESTA EN SERVICIO | 100,00% | 100,00% | 100% | día 717,625 | 0,092003755 |
| 208 | 1.7.4.2.6.5 | Energización de paño J2 | 2d | 2025-08-21 A | 2025-08-22 A | 206FF | 100% |  | 2025-08-21 | 2025-08-22 | 2d | 2025-01-22 | 2025-01-22 |  |  |  | ENKI - ELECNOR L_S | 21h | 21h | TRANSELEC | 21-04-2025 | 21-04-2025 | 1 día | 08 PES-PUESTA EN SERVICIO | 100,00% | 100,00% | 100% | día 718,75 | 0,040001633 |
| 209 | 1.7.5 | **Paño J3 - Circuito 2** | 46d | 2025-09-16 A | 2025-11-21 |  | 4% | 44.08d | 2025-09-16 | 2025-11-21 | 46d | 2025-01-23 | 2025-04-22 | 36d |  |  | ENKI - ELECNOR L_S | 8566h | 398.54h | TRANSELEC | 24-04-2025 | 18-06-2025 | 48 días | 06 CO-CONSTRUCCIÓN | 4,66% | 2,75% | 4% |  |  |
| 210 | 1.7.5.1 | **Etapa 1 (Tramo Paño J2)** | 29d | 2025-09-16 A | 2025-10-29 |  | 6% | 27.12d | 2025-09-16 | 2025-10-29 | 29d | 2025-09-29 |  | 53d |  |  | ENKI - ELECNOR L_S | 5133h | 398.54h |  | 24-04-2025 | 21-05-2025 | 24 días |  | 7,77% | 4,58% | 6% | día 1 |  |
| 211 | 1.7.5.1.1 | **Adecuaciones** | 16d | 2025-09-16 A | 2025-10-10 |  | 10% | 14.4d | 2025-09-16 | 2025-10-10 | 16d | 2025-01-23 | 2025-02-11 | 2.21d |  |  | ENKI - ELECNOR L_S | 990h | 162h | TRANSELEC | 24-04-2025 | 29-04-2025 | 5 días | 06 CO-CONSTRUCCIÓN | 16,39% | 16,39% | 12% |  |  |
| 212 | 1.7.5.1.1.1 | Desmontaje de Interruptor (1) | 2d | 2025-10-02 | 2025-10-03 | 124, 125, 120SS, 121, 122, 208 |  |  | 2025-10-02 | 2025-10-03 | 2d | 2025-01-28 | 2025-01-30 | 1d | 0d | start no earlier than 2025-10-02 | ENKI - ELECNOR L_S | 327h |  | TRANSELEC | 24-04-2025 | 25-04-2025 | 2 días | 06 CO-CONSTRUCCIÓN | 0,00% | 0,00% | 0% | día 749,125 | 0,628025634 |
| 213 | 1.7.5.1.1.2 | Desmontaje de Desconectador CPAT | 2d | 2025-10-03 | 2025-10-04 | 121, 122, 124, 125, 212FS-1d |  |  | 2025-10-03 | 2025-10-04 | 2d | 2025-01-23 | 2025-01-25 | 1d | 0d |  | ENKI - ELECNOR L_S | 162h |  | TRANSELEC | 25-04-2025 | 26-04-2025 | 2 días | 06 CO-CONSTRUCCIÓN | 0,00% | 0,00% | 0% | día 750,25 | 0,312012735 |
| 214 | 1.7.5.1.1.3 | Desmontaje de Decconectador SPAT | 1d | 2025-09-16 A | 2025-09-16 A | 124FS-14d, 125FS-14d, 213FS-14d | 100% |  | 2025-09-16 | 2025-09-16 | 1d | 2025-01-26 | 2025-01-27 |  |  |  | ENKI - ELECNOR L_S | 162h | 162h | TRANSELEC | 28-04-2025 | 29-04-2025 | 2 días | 06 CO-CONSTRUCCIÓN | 100,00% | 100,00% | 100% | día 739 | 0,312012735 |
| 215 | 1.7.5.1.1.4 | Demolición de Fundación Interruptor | 5d | 2025-10-04 | 2025-10-10 | 212 |  |  | 2025-10-04 | 2025-10-10 | 5d | 2025-01-31 | 2025-02-09 | 2.21d | 0d |  | ENKI - ELECNOR L_S | 339h |  | TRANSELEC | 26-04-2025 | 29-04-2025 | 3 días | 06 CO-CONSTRUCCIÓN | 0,00% | 0,00% | 0% | día 751,375 | 0,652026613 |

| ID | WBS | Task | Duration | Start | Finish | Predecessors | Complete | Remaining | Baseline start | Baseline finish | Baseline duration | Baseline 1 start | Baseline 1 finish | Total slack | Free slack | Calendar | Work | Actual work | Propietario | Baseline Star Rev1 | Baseline Finish Rev1 | Baseline Duration Rev1 | : | % Complete Peso | % Baseline Peso | % Baseline (Tempo) | Text11 | Entrada Peso |
| --- | --- | --- | --- | --- | --- | --- | --- | --- | --- | --- | --- | --- | --- | --- | --- | --- | --- | --- | --- | --- | --- | --- | --- | --- | --- | --- | --- | --- |
| 216 | 1.7.5.1.2 | **Fundaciones Bajas** | 13d | 2025-10-04 A | 2025-10-22 |  | 17% | 10.79d | 2025-10-04 | 2025-10-22 | 13d | 2025-02-12 | 2025-03-15 | 0d |  | ENKI - ELECNOR L_S | 962h | 163.54h | TRANSELEC | 28-04-2025 | 09-05-2025 | 11 días | 06 CO-CONSTRUCCIÓN | 17,00% | 0,00% | 0% |  |  |
| 217 | 1.7.5.1.2.1 | Fundación Interruptor | 13d | 2025-10-04 A | 2025-10-22 | 215SS | 17% | 10.79d | 2025-10-04 | 2025-10-22 | 13d | 2025-02-28 | 2025-03-08 | 0d |  | ENKI - ELECNOR L_S | 962h | 163.54h | TRANSELEC | 28-04-2025 | 09-05-2025 | 11 días | 06 CO-CONSTRUCCIÓN | 17,00% | 0,00% | 0% | día 751,375 | 1,850075513 |
| 218 | 1.7.5.1.3 | **Estructuras Bajas** | 25d | 2025-09-16 A | 2025-10-23 |  | 33% | 16.67d | 2025-09-16 | 2025-10-23 | 25d | 2025-02-22 | 2025-03-18 | 0d |  | ENKI - ELECNOR L_S | 293h | 73h | TRANSELEC | 28-04-2025 | 12-05-2025 | 13 días | 06 CO-CONSTRUCCIÓN | 24,91% | 24,91% | 7% |  |  |
| 219 | 1.7.5.1.3.1 | Refuerzo de Estructura Desconectador CPAT | 1d | 2025-10-07 | 2025-10-07 | 213, 83 |  |  | 2025-10-07 | 2025-10-07 | 1d | 2025-02-22 | 2025-02-25 | 1d | 0d | ENKI - ELECNOR L_S | 147h |  | TRANSELEC | 28-04-2025 | 29-04-2025 | 2 días | 06 CO-CONSTRUCCIÓN | 0,00% | 0,00% | 0% | día 752,5 | 0,282011511 |
| 220 | 1.7.5.1.3.2 | Refuerzo de Estructura Desconectador SPAT | 1d | 2025-09-16 A | 2025-09-16 A | 214FS-1d, 83FS-1d | 100% |  | 2025-09-16 | 2025-09-16 | 1d | 2025-02-28 | 2025-03-02 |  |  | ENKI - ELECNOR L_S | 73h | 73h | TRANSELEC | 30-04-2025 | 01-05-2025 | 2 días | 06 CO-CONSTRUCCIÓN | 100,00% | 100,00% | 100% | día 739 | 0,140005715 |
| 221 | 1.7.5.1.3.3 | Montaje de Estructura Interruptor | 1d | 2025-10-23 | 2025-10-23 | 217, 93 |  |  | 2025-10-23 | 2025-10-23 | 1d | 2025-03-09 | 2025-03-12 | 0d |  | ENKI - ELECNOR L_S | 73h |  | TRANSELEC | 10-05-2025 | 12-05-2025 | 2 días | 06 CO-CONSTRUCCIÓN | 0,00% | 0,00% | 0% | día 766 | 0,140005715 |
| 222 | 1.7.5.1.4 | **Equipos Primarios** | 16d | 2025-10-08 | 2025-10-29 |  |  |  | 2025-10-08 | 2025-10-29 | 16d | 2025-02-26 | 2025-03-31 | 1d |  | ENKI - ELECNOR L_S | 1146h |  | TRANSELEC | 30-04-2025 | 19-05-2025 | 17 días | 06 CO-CONSTRUCCIÓN | 0,00% | 0,00% | 0% |  |  |
| 223 | 1.7.5.1.4.1 | Montaje de Desconectadores SPAT | 2d | 2025-10-08 | 2025-10-09 | 105, 219 |  |  | 2025-10-08 | 2025-10-09 | 2d | 2025-02-26 | 2025-03-01 | 1d | 0d | ENKI - ELECNOR L_S | 172h |  | TRANSELEC | 30-04-2025 | 01-05-2025 | 2 días | 06 CO-CONSTRUCCIÓN | 0,00% | 0,00% | 0% | día 753,625 | 0,33001347 |
| 224 | 1.7.5.1.4.2 | Pruebas SAT Desconectadores SPAT | 2d | 2025-10-10 | 2025-10-11 | 223 |  |  | 2025-10-10 | 2025-10-11 | 2d | 2025-03-02 | 2025-03-03 | 20d | 12d | ENKI - ELECNOR L_S | 38h |  | TRANSELEC | 02-05-2025 | 03-05-2025 | 2 días | 06 CO-CONSTRUCCIÓN | 0,00% | 0,00% | 0% | día 755,875 | 0,074003021 |
| 225 | 1.7.5.1.4.3 | Montaje de Decconectador CPAT | 3d | 2025-10-08 | 2025-10-10 | 105, 220FS+12d |  |  | 2025-10-08 | 2025-10-10 | 3d | 2025-03-03 | 2025-03-05 | 11d | 0d | ENKI - ELECNOR L_S | 85h |  | TRANSELEC | 02-05-2025 | 03-05-2025 | 2 días | 06 CO-CONSTRUCCIÓN | 0,00% | 0,00% | 0% | día 753,625 | 0,164006694 |
| 226 | 1.7.5.1.4.4 | Pruebas SAT Desconectadores CPAT | 2d | 2025-10-11 | 2025-10-14 | 225 |  |  | 2025-10-11 | 2025-10-14 | 2d | 2025-03-06 | 2025-03-07 | 19d | 11d | ENKI - ELECNOR L_S | 26h |  | TRANSELEC | 05-05-2025 | 06-05-2025 | 2 días | 06 CO-CONSTRUCCIÓN | 0,00% | 0,00% | 0% | día 757 | 0,050002041 |
| 227 | 1.7.5.1.4.5 | Montaje Interruptor | 3d | 2025-10-23 | 2025-10-25 | 93, 221SS |  |  | 2025-10-23 | 2025-10-25 | 3d | 2025-03-13 | 2025-03-16 | 0d |  | ENKI - ELECNOR L_S | 73h |  | TRANSELEC | 13-05-2025 | 15-05-2025 | 3 días | 06 CO-CONSTRUCCIÓN | 0,00% | 0,00% | 0% | día 766 | 0,140005715 |
| 228 | 1.7.5.1.4.6 | Pruebas SAT Interruptor | 2d | 2025-10-28 | 2025-10-29 | 227 |  |  | 2025-10-28 | 2025-10-29 | 2d | 2025-03-17 | 2025-03-19 | 8d | 0d | ENKI - ELECNOR L_S | 26h |  | TRANSELEC | 16-05-2025 | 19-05-2025 | 3 días | 06 CO-CONSTRUCCIÓN | 0,00% | 0,00% | 0% | día 769,375 | 0,050002041 |
| 229 | 1.7.5.1.4.7 | Conexionado de equipos y estructura a MPT | 2d | 2025-10-24 | 2025-10-25 | 223FF, 225FF, 227FF |  |  | 2025-10-24 | 2025-10-25 | 2d | 2025-03-22 | 2025-03-31 | 0d |  | ENKI - ELECNOR L_S | 726h |  | TRANSELEC | 14-05-2025 | 15-05-2025 | 2 días | 06 CO-CONSTRUCCIÓN | 0,00% | 0,00% | 0% | día 767,125 | 1,396056982 |
| 230 | 1.7.5.1.5 | **Cables de Control, Fuerza y Conductor AT** | 14d | 2025-10-10 | 2025-10-29 |  |  |  | 2025-10-10 | 2025-10-29 | 14d | 2025-03-22 | 2025-04-05 | 1d |  | ENKI - ELECNOR L_S | 1349h |  | TRANSELEC | 02-05-2025 | 17-05-2025 | 14 días | 06 CO-CONSTRUCCIÓN | 0,00% | 0,00% | 0% |  |  |
| 231 | 1.7.5.1.5.1 | Tendido Cable de Control y Fuerza | 4d | 2025-10-10 | 2025-10-15 | 223, 87, 109 |  |  | 2025-10-10 | 2025-10-15 | 4d | 2025-03-22 | 2025-04-05 | 1d | 0d | ENKI - ELECNOR L_S | 1124h |  | TRANSELEC | 02-05-2025 | 05-05-2025 | 3 días | 06 CO-CONSTRUCCIÓN | 0,00% | 0,00% | 0% | día 755,875 | 2,162088248 |
| 232 | 1.7.5.1.5.2 | Tendido y Conexionado Conductor AT | 4d | 2025-10-24 | 2025-10-29 | 223, 225, 227FS-2d |  |  | 2025-10-24 | 2025-10-29 | 4d | 2025-03-22 | 2025-04-05 | 53d |  | ENKI - ELECNOR L_S | 225h |  | TRANSELEC | 14-05-2025 | 17-05-2025 | 4 días | 06 CO-CONSTRUCCIÓN | 0,00% | 0,00% | 0% | día 767,125 | 0,432017633 |
| 233 | 1.7.5.1.6 | **Sistema de Control y Protección** | 5d | 2025-10-10 | 2025-10-16 |  |  |  | 2025-10-10 | 2025-10-16 | 5d | 2025-04-06 | 2025-04-12 | 1d |  | ENKI - ELECNOR L_S | 64h |  | TRANSELEC | 01-05-2025 | 12-05-2025 | 10 días | 06 CO-CONSTRUCCIÓN | 0,00% | 0,00% | 0% |  |  |
| 234 | 1.7.5.1.6.1 | Carga de ajustes y Pruebas de Funcionalidad | 5d | 2025-10-10 | 2025-10-16 | 231FS-4d |  |  | 2025-10-10 | 2025-10-16 | 5d | 2025-04-06 | 2025-04-12 | 1d | 0d | ENKI - ELECNOR L_S | 64h |  | TRANSELEC | 01-05-2025 | 12-05-2025 | 10 días | 06 CO-CONSTRUCCIÓN | 0,00% | 0,00% | 0% | día 755,875 | 0,124005061 |
| 235 | 1.7.5.1.7 | **Comisionamiento** | 8d | 2025-10-17 | 2025-10-28 |  |  |  | 2025-10-17 | 2025-10-28 | 8d | 2025-04-13 | 2025-04-22 | 0d |  | ENKI - ELECNOR L_S | 329h |  | TRANSELEC | 13-05-2025 | 21-05-2025 | 8 días | 08 PES-PUESTA EN SERVICIO | 0,00% | 0,00% | 0% |  |  |
| 236 | 1.7.5.1.7.1 | Pruebas finales | 2d | 2025-10-17 | 2025-10-18 | 234 |  |  | 2025-10-17 | 2025-10-18 | 2d | 2025-04-13 | 2025-04-13 | 5d |  | ENKI - ELECNOR L_S | 97h |  | TRANSELEC | 13-05-2025 | 14-05-2025 | 2 días | 08 PES-PUESTA EN SERVICIO | 0,00% | 0,00% | 0% | día 761,5 | 0,186007592 |
| 237 | 1.7.5.1.7.2 | Pruebas de funciones de protección | 5d | 2025-10-17 | 2025-10-23 | 234 |  |  | 2025-10-17 | 2025-10-23 | 5d | 2025-04-13 | 2025-04-19 | 1d | 0d | ENKI - ELECNOR L_S | 122h |  | TRANSELEC | 13-05-2025 | 19-05-2025 | 6 días | 08 PES-PUESTA EN SERVICIO | 0,00% | 0,00% | 0% | día 761,5 | 0,234009551 |
| 238 | 1.7.5.1.7.3 | Conexión de los bajantes a Barra de Transferencia | 1d | 2025-10-24 | 2025-10-24 | 237 |  |  | 2025-10-24 | 2025-10-24 | 1d | 2025-04-20 | 2025-04-20 | 1d | 0d | ENKI - ELECNOR L_S | 45h |  | TRANSELEC | 20-05-2025 | 20-05-2025 | 1 día | 08 PES-PUESTA EN SERVICIO | 0,00% | 0,00% | 0% | día 767,125 | 0,08600351 |
| 239 | 1.7.5.1.7.4 | Conexión de los bajantes a Barra de Principal Sección 2 | 1d | 2025-10-24 | 2025-10-24 | 238SS |  |  | 2025-10-24 | 2025-10-24 | 1d | 2025-04-21 | 2025-04-21 | 1d |  | ENKI - ELECNOR L_S | 45h |  | TRANSELEC | 20-05-2025 | 20-05-2025 | 1 día | 08 PES-PUESTA EN SERVICIO | 0,00% | 0,00% | 0% | día 767,125 | 0,08600351 |
| 240 | 1.7.5.1.7.5 | Pre-energización de Paño J3 | 1d | 2025-10-28 | 2025-10-28 | 237, 238, 239, 229, 236 |  |  | 2025-10-28 | 2025-10-28 | 1d | 2025-04-22 | 2025-04-22 | 0d |  | ENKI - ELECNOR L_S | 20h |  | TRANSELEC | 21-05-2025 | 21-05-2025 | 1 día | 08 PES-PUESTA EN SERVICIO | 0,00% | 0,00% | 0% | día 769,375 | 0,038001551 |

| ID | WBS | Task | Duration | Start | Finish | Predecessors | Baseline start | Baseline finish | Baseline duration | Baseline 1 start | Baseline 1 finish | Total slack | Free slack | Calendar | Work | Baseline Star Rev1 | Text11 | Baseline Finish Rev1 | Baseline Duration Rev1 | % Complete Peso | % Baseline Peso | % Baseline (Tempo) | Propietario | : | Entrada Peso |
| --- | --- | --- | --- | --- | --- | --- | --- | --- | --- | --- | --- | --- | --- | --- | --- | --- | --- | --- | --- | --- | --- | --- | --- | --- | --- |
| 241 | 1.7.5.2 | **Etapa 2 (Tramo Transferencia)** | 16d | 2025-10-31 | 2025-11-21 |  | 2025-10-31 | 2025-11-21 | 16d | 2025-10-31 |  | 0d |  | ENKI - ELECNOR L_S | 3433h | 24-05-2025 | día 1 | 18-06-2025 | 22 días | 0,00% | 0,00% | 0% |  |  |  |
| 242 | 1.7.5.2.1 | **Adecuaciones** | 2d | 2025-10-31 | 2025-11-01 |  | 2025-10-31 | 2025-11-01 | 2d | 2025-01-23 | 2025-02-11 | 0d |  | ENKI - ELECNOR L_S | 344h | 24-05-2025 |  | 27-05-2025 | 3 días | 0,00% | 0,00% | 0% | TRANSELEC | 06 CO-CONSTRUCCIÓN |  |
| 243 | 1.7.5.2.1.1 | Desmontaje de Desconectadores SPAT (1) | 2d | 2025-10-31 | 2025-11-01 | 240FS+2d | 2025-10-31 | 2025-11-01 | 2d | 2025-01-23 | 2025-01-25 | 0d |  | ENKI - ELECNOR L_S | 172h | 24-05-2025 | día 772,75 | 27-05-2025 | 3 días | 0,00% | 0,00% | 0% | TRANSELEC | 06 CO-CONSTRUCCIÓN | 0,33001347 |
| 244 | 1.7.5.2.1.2 | Desmontaje de TTCC | 2d | 2025-10-31 | 2025-11-01 | 243FS-2d | 2025-10-31 | 2025-11-01 | 2d | 2025-01-31 | 2025-02-01 | 1d | 0d | ENKI - ELECNOR L_S | 172h | 26-05-2025 | día 772,75 | 27-05-2025 | 2 días | 0,00% | 0,00% | 0% | TRANSELEC | 06 CO-CONSTRUCCIÓN | 0,33001347 |
| 245 | 1.7.5.2.2 | **Estructuras Bajas** | 1d | 2025-11-04 | 2025-11-04 |  | 2025-11-04 | 2025-11-04 | 1d | 2025-02-22 | 2025-03-18 | 0d |  | ENKI - ELECNOR L_S | 154h | 28-05-2025 |  | 29-05-2025 | 2 días | 0,00% | 0,00% | 0% | TRANSELEC | 06 CO-CONSTRUCCIÓN |  |
| 246 | 1.7.5.2.2.1 | Refuerzo de Estructura Desconectadores SPAT | 1d | 2025-11-04 | 2025-11-04 | 83, 243 | 2025-11-04 | 2025-11-04 | 1d | 2025-02-22 | 2025-02-25 | 0d |  | ENKI - ELECNOR L_S | 154h | 28-05-2025 | día 775 | 29-05-2025 | 2 días | 0,00% | 0,00% | 0% | TRANSELEC | 06 CO-CONSTRUCCIÓN | 0,296012082 |
| 247 | 1.7.5.2.3 | **Equipos Primarios** | 7d | 2025-11-04 | 2025-11-12 |  | 2025-11-04 | 2025-11-12 | 7d | 2025-02-26 | 2025-03-31 | 1d |  | ENKI - ELECNOR L_S | 1098h | 28-05-2025 |  | 07-06-2025 | 10 días | 0,00% | 0,00% | 0% | TRANSELEC | 06 CO-CONSTRUCCIÓN |  |
| 248 | 1.7.5.2.3.1 | Montaje de Desconectadores SPAT | 2d | 2025-11-05 | 2025-11-06 | 246, 105 | 2025-11-05 | 2025-11-06 | 2d | 2025-02-26 | 2025-03-01 | 0d |  | ENKI - ELECNOR L_S | 181h | 30-05-2025 | día 776,125 | 02-06-2025 | 3 días | 0,00% | 0,00% | 0% | TRANSELEC | 06 CO-CONSTRUCCIÓN | 0,348014205 |
| 249 | 1.7.5.2.3.2 | Pruebas SAT Desconectadores SPAT | 2d | 2025-11-07 | 2025-11-08 | 248 | 2025-11-07 | 2025-11-08 | 2d | 2025-03-02 | 2025-03-03 | 0d |  | ENKI - ELECNOR L_S | 41h | 03-06-2025 | día 778,375 | 04-06-2025 | 2 días | 0,00% | 0,00% | 0% | TRANSELEC | 06 CO-CONSTRUCCIÓN | 0,078003184 |
| 250 | 1.7.5.2.3.3 | Montaje de TTCC | 2d | 2025-11-04 | 2025-11-05 | 244, 99 | 2025-11-04 | 2025-11-05 | 2d | 2025-03-19 | 2025-03-21 | 1d | 0d | ENKI - ELECNOR L_S | 77h | 28-05-2025 | día 775 | 30-05-2025 | 3 días | 0,00% | 0,00% | 0% | TRANSELEC | 06 CO-CONSTRUCCIÓN | 0,148006041 |
| 251 | 1.7.5.2.3.4 | Pruebas SAT TTCC | 2d | 2025-11-06 | 2025-11-07 | 250 | 2025-11-06 | 2025-11-07 | 2d | 2025-03-22 | 2025-03-23 | 1d | 0d | ENKI - ELECNOR L_S | 21h | 31-05-2025 | día 777,25 | 02-06-2025 | 2 días | 0,00% | 0,00% | 0% | TRANSELEC | 06 CO-CONSTRUCCIÓN | 0,040001633 |
| 252 | 1.7.5.2.3.5 | Conexionado de equipos y estructura a MPT | 4d | 2025-11-07 | 2025-11-12 | 248, 250 | 2025-11-07 | 2025-11-12 | 4d | 2025-03-22 | 2025-03-31 | 27d | 6d | ENKI - ELECNOR L_S | 778h | 03-06-2025 | día 778,375 | 07-06-2025 | 5 días | 0,00% | 0,00% | 0% | TRANSELEC | 06 CO-CONSTRUCCIÓN | 1,496061064 |
| 253 | 1.7.5.2.4 | **Cables de Control, Fuerza y Conductor AT** | 3d | 2025-11-07 | 2025-11-11 |  | 2025-11-07 | 2025-11-11 | 3d | 2025-03-22 | 2025-04-05 | 0d |  | ENKI - ELECNOR L_S | 1421h | 03-06-2025 |  | 05-06-2025 | 3 días | 0,00% | 0,00% | 0% | TRANSELEC | 06 CO-CONSTRUCCIÓN |  |
| 254 | 1.7.5.2.4.1 | Tendido Cable de Control y Fuerza | 3d | 2025-11-07 | 2025-11-11 | 248, 250 | 2025-11-07 | 2025-11-11 | 3d | 2025-03-22 | 2025-04-05 | 0d |  | ENKI - ELECNOR L_S | 1184h | 03-06-2025 | día 778,375 | 05-06-2025 | 3 días | 0,00% | 0,00% | 0% | TRANSELEC | 06 CO-CONSTRUCCIÓN | 2,276092902 |
| 255 | 1.7.5.2.4.2 | Tendido y Conexionado Conductor AT | 3d | 2025-11-07 | 2025-11-11 | 248, 250 | 2025-11-07 | 2025-11-11 | 3d | 2025-03-22 | 2025-04-05 | 0d |  | ENKI - ELECNOR L_S | 237h | 03-06-2025 | día 778,375 | 04-06-2025 | 2 días | 0,00% | 0,00% | 0% | TRANSELEC | 06 CO-CONSTRUCCIÓN | 0,456018613 |
| 256 | 1.7.5.2.5 | **Sistema de Control y Protección** | 4d | 2025-11-06 | 2025-11-11 |  | 2025-11-06 | 2025-11-11 | 4d | 2025-04-06 | 2025-04-12 | 0d |  | ENKI - ELECNOR L_S | 68h | 02-06-2025 |  | 07-06-2025 | 6 días | 0,00% | 0,00% | 0% | TRANSELEC | 06 CO-CONSTRUCCIÓN |  |
| 257 | 1.7.5.2.5.1 | Carga de ajustes y Pruebas de Funcionalidad | 4d | 2025-11-06 | 2025-11-11 | 254FS-4d, 255FS-4d | 2025-11-06 | 2025-11-11 | 4d | 2025-04-06 | 2025-04-12 | 0d |  | ENKI - ELECNOR L_S | 68h | 02-06-2025 | día 777,25 | 07-06-2025 | 6 días | 0,00% | 0,00% | 0% | TRANSELEC | 06 CO-CONSTRUCCIÓN | 0,130005306 |
| 258 | 1.7.5.2.6 | **Comisionamiento** | 8d | 2025-11-12 | 2025-11-21 |  | 2025-11-12 | 2025-11-21 | 8d | 2025-04-13 | 2025-04-22 | 18d |  | ENKI - ELECNOR L_S | 348h | 09-06-2025 |  | 18-06-2025 | 9 días | 0,00% | 0,00% | 0% | TRANSELEC | 08 PES-PUESTA EN SERVICIO |  |
| 259 | 1.7.5.2.6.1 | Pruebas finales | 1d | 2025-11-12 | 2025-11-12 | 257 | 2025-11-12 | 2025-11-12 | 1d | 2025-04-13 | 2025-04-13 | 27d | 6d | ENKI - ELECNOR L_S | 102h | 09-06-2025 | día 781,75 | 09-06-2025 | 1 día | 0,00% | 0,00% | 0% | TRANSELEC | 08 PES-PUESTA EN SERVICIO | 0,196008 |
| 260 | 1.7.5.2.6.2 | Pruebas de funciones de protección | 5d | 2025-11-12 | 2025-11-18 | 257 | 2025-11-12 | 2025-11-18 | 5d | 2025-04-13 | 2025-04-19 | 18d | 0d | ENKI - ELECNOR L_S | 129h | 09-06-2025 | día 781,75 | 14-06-2025 | 6 días | 0,00% | 0,00% | 0% | TRANSELEC | 08 PES-PUESTA EN SERVICIO | 0,248010123 |
| 261 | 1.7.5.2.6.3 | Conexión de los bajantes a Barra de Transferencia | 1d | 2025-11-19 | 2025-11-19 | 260 | 2025-11-19 | 2025-11-19 | 1d | 2025-04-20 | 2025-04-20 | 21d | 0d | ENKI - ELECNOR L_S | 48h | 16-06-2025 | día 787,375 | 16-06-2025 | 1 día | 0,00% | 0,00% | 0% | TRANSELEC | 08 PES-PUESTA EN SERVICIO | 0,092003755 |
| 262 | 1.7.5.2.6.4 | Conexión de los bajantes a Barra de Principal Sección 2 | 1d | 2025-11-20 | 2025-11-20 | 261 | 2025-11-20 | 2025-11-20 | 1d | 2025-04-21 | 2025-04-21 | 21d | 0d | ENKI - ELECNOR L_S | 48h | 17-06-2025 | día 788,5 | 17-06-2025 | 1 día | 0,00% | 0,00% | 0% | TRANSELEC | 08 PES-PUESTA EN SERVICIO | 0,092003755 |
| 263 | 1.7.5.2.6.5 | Energización de Paño J3 | 1d | 2025-11-21 | 2025-11-21 | 251, 252, 259, 260, 261, 262 | 2025-11-21 | 2025-11-21 | 1d | 2025-04-22 | 2025-04-22 | 21d | 0d | ENKI - ELECNOR L_S | 21h | 18-06-2025 | día 789,625 | 18-06-2025 | 1 día | 0,00% | 0,00% | 0% | TRANSELEC | 08 PES-PUESTA EN SERVICIO | 0,040001633 |
| 264 | 1.7.6 | Hito Energización | 1d | 2025-12-13 | 2025-12-13 | 600, 394, 153, 208, 263 | 2025-12-13 | 2025-12-13 | 1d | 2025-07-18 | 2025-07-18 | 20d | 0d | ENKI - ELECNOR L_S |  | 12-08-2025 | día 807,625 | 12-08-2025 | 1 día | 0,00% | 0,00% | 0% | TRANSELEC | 08 PES-PUESTA EN SERVICIO |  |
| 265 | 1.7.7 | Desmovilización | 17d | 2025-12-13 | 2026-01-06 | 394, 410 | 2025-12-13 | 2026-01-06 | 17d | 2025-07-23 | 2025-09-02 | 4d | 0d | ENKI - ELECNOR L_S | 543h | 14-08-2025 | día 807,625 | 02-09-2025 | 17 días | 0,00% | 0,00% | 0% | TRANSELEC | 10 DE-DESMOVILIZACIÓN | 1,044042614 |

| ID | WBS | Task | Type | Duration | Start | Finish | Predecessors | Complete | Remaining | Baseline start | Baseline finish | Baseline duration | Baseline 1 start | Baseline 1 finish | Total slack | Calendar | Work | Actual work | Propietario | Baseline Star Rev1 | Baseline Finish Rev1 | Baseline Duration Rev1 | : | % Complete Peso | % Baseline Peso | % Baseline (Tempo) | Text11 | Entrada Peso |
| --- | --- | --- | --- | --- | --- | --- | --- | --- | --- | --- | --- | --- | --- | --- | --- | --- | --- | --- | --- | --- | --- | --- | --- | --- | --- | --- | --- | --- |
| 266 | 1.8 | **PROCESO DE INTERCONEXIÓN** |  | 729d | 2023-03-01 A | 2025-12-15 |  | 88% | 86.03d | 2023-03-01 | 2025-12-15 | 729d | 2024-08-12 | 2025-09-02 | 19d | ENKI - Días habiles | 3575h | 2483.7h | TRANSELEC | 05-02-2024 | 02-09-2025 | 412 días | 07 PI-PROCESO DE INTERCONEXIÓN | 65,65% | 63,66% | 91% |  |  |
| 267 | 1.8.1 | **CEM- Carta de Escenarios Mínimos** |  | 52d | 2024-02-05 A | 2024-04-16 A |  | 100% |  | 2024-02-05 | 2024-04-16 | 52d | 2024-08-12 | 2024-10-22 |  | ENKI - Días habiles | 32h | 32h | TRANSELEC | 05-02-2024 | 16-04-2024 | 52 días | 07 PI-PROCESO DE INTERCONEXIÓN | 100,00% | 100,00% | 100% |  |  |
| 268 | 1.8.1.1 | Solicitud y Anexos (carta conductora SIPC) |  | 1d | 2024-02-05 A | 2024-02-06 A |  | 100% |  | 2024-02-05 | 2024-02-06 | 1d | 2024-08-12 | 2024-08-12 |  | ENKI - Días habiles | 12h | 12h | TRANSELEC | 05-02-2024 | 05-02-2024 | 1 día | 07 PI-PROCESO DE INTERCONEXIÓN | 100,00% | 100,00% | 100% | día 274,375 | 0,089485459 |
| 269 | 1.8.1.2 | Observaciones del CEN a la SIPC |  | 10d | 2024-02-06 A | 2024-02-19 A | 268 | 100% |  | 2024-02-06 | 2024-02-19 | 10d | 2024-08-13 | 2024-08-26 |  | ENKI - Días habiles |  |  | TRANSELEC | 06-02-2024 | 19-02-2024 | 10 días | 07 PI-PROCESO DE INTERCONEXIÓN | 100,00% | 100,00% | 100% | día 275,5 |  |
| 270 | 1.8.1.3 | Notificación del CEN a Empresas Involucradas |  | 3d | 2024-02-20 A | 2024-02-22 A | 269 | 100% |  | 2024-02-20 | 2024-02-22 | 3d | 2024-08-27 | 2024-08-29 |  | ENKI - Días habiles |  |  | TRANSELEC | 20-02-2024 | 22-02-2024 | 3 días | 07 PI-PROCESO DE INTERCONEXIÓN | 100,00% | 100,00% | 100% | día 286,75 |  |
| 271 | 1.8.1.4 | Propuestas de Estudios para CEM por Empresas involucradas |  | 5d | 2024-02-23 A | 2024-02-29 A | 270 | 100% |  | 2024-02-23 | 2024-02-29 | 5d | 2024-08-30 | 2024-09-05 |  | ENKI - Días habiles |  |  | TRANSELEC | 23-02-2024 | 29-02-2024 | 5 días | 07 PI-PROCESO DE INTERCONEXIÓN | 100,00% | 100,00% | 100% | día 290,125 |  |
| 272 | 1.8.1.5 | Carta de Escenarios Mínimos Preliminar(CEM P) |  | 18d | 2024-03-01 A | 2024-03-26 A | 271 | 100% |  | 2024-03-01 | 2024-03-26 | 18d | 2024-09-06 | 2024-10-01 |  | ENKI - Días habiles |  |  | TRANSELEC | 01-03-2024 | 26-03-2024 | 18 días | 07 PI-PROCESO DE INTERCONEXIÓN | 100,00% | 100,00% | 100% | día 295,75 |  |
| 273 | 1.8.1.6 | Observaciones ES a la CEM |  | 4d | 2024-03-27 A | 2024-04-01 A | 272 | 100% |  | 2024-03-27 | 2024-04-01 | 4d | 2024-10-02 | 2024-10-08 |  | ENKI - Días habiles | 20h | 20h | TRANSELEC | 27-03-2024 | 02-04-2024 | 5 días | 07 PI-PROCESO DE INTERCONEXIÓN | 100,00% | 100,00% | 100% | día 316 | 0,178970917 |
| 274 | 1.8.1.7 | Carta de Escenarios Mínimos Definitiva (CEM D) |  | 10d | 2024-04-03 A | 2024-04-16 A | 273 | 100% |  | 2024-04-03 | 2024-04-16 | 10d | 2024-10-09 | 2024-10-22 |  | ENKI - Días habiles |  |  | TRANSELEC | 03-04-2024 | 16-04-2024 | 10 días | 07 PI-PROCESO DE INTERCONEXIÓN | 100,00% | 100,00% | 100% | día 321,625 |  |
| 275 | 1.8.2 | **DUF-Diagrama Unilineal Funcional** |  | 20d | 2024-08-19 A | 2024-09-13 A |  | 100% |  | 2024-08-19 | 2024-09-13 | 20d | 2024-08-19 | 2024-09-13 |  | ENKI - Días habiles | 24h | 24h | TRANSELEC | 19-08-2024 | 13-09-2024 | 20 días | 07 PI-PROCESO DE INTERCONEXIÓN | 100,00% | 100,00% | 100% |  |  |
| 276 | 1.8.2.1 | DUF para Revisión del CEN (junto con la SIPC) |  | 1d | 2024-08-19 A | 2024-08-19 A | 268SS, 39, 450 | 100% |  | 2024-08-19 | 2024-08-19 | 1d | 2024-08-19 | 2024-08-19 |  | ENKI - Días habiles | 12h | 12h | TRANSELEC | 19-08-2024 | 19-08-2024 | 1 día | 07 PI-PROCESO DE INTERCONEXIÓN | 100,00% | 100,00% | 100% | día 431,875 | 0,089485459 |
| 277 | 1.8.2.2 | Revisión del CEN del DUF |  | 7d | 2024-08-20 A | 2024-08-28 A | 276 | 100% |  | 2024-08-20 | 2024-08-28 | 7d | 2024-08-20 | 2024-08-28 |  | ENKI - Días habiles |  |  | TRANSELEC | 20-08-2024 | 28-08-2024 | 7 días | 07 PI-PROCESO DE INTERCONEXIÓN | 100,00% | 100,00% | 100% | día 433 |  |
| 278 | 1.8.2.3 | Respuesta ES a Observaciones DUF |  | 4d | 2024-08-29 A | 2024-09-03 A | 277 | 100% |  | 2024-08-29 | 2024-09-03 | 4d | 2024-08-29 | 2024-09-04 |  | ENKI - Días habiles | 12h | 12h | TRANSELEC | 29-08-2024 | 04-09-2024 | 5 días | 07 PI-PROCESO DE INTERCONEXIÓN | 100,00% | 100,00% | 100% | día 440,875 | 0,089485459 |
| 279 | 1.8.2.4 | Revisión DUF - 1era Iteración |  | 7d | 2024-09-05 A | 2024-09-13 A | 278 | 100% |  | 2024-09-05 | 2024-09-13 | 7d | 2024-09-05 | 2024-09-13 |  | ENKI - Días habiles |  |  | TRANSELEC | 05-09-2024 | 13-09-2024 | 7 días | 07 PI-PROCESO DE INTERCONEXIÓN | 100,00% | 100,00% | 100% | día 446,5 |  |
| 280 | 1.8.2.5 | Aprobación DUF | milestone | 0d | 2024-09-13 A | 2024-09-13 A | 279 | 100% |  | 2024-09-13 | 2024-09-13 | 0d | 2024-09-13 | 2024-09-13 |  | ENKI - Días habiles |  |  | TRANSELEC | 13-09-2024 | 13-09-2024 | 0 días | 07 PI-PROCESO DE INTERCONEXIÓN | 100,00% | 100,00% | 100% | día 454,375 |  |
| 281 | 1.8.3 | **RID- Revisión de Ingeniería de Diseño** |  | 37d | 2024-08-19 A | 2024-10-08 A |  | 100% |  | 2024-08-19 | 2024-10-08 | 37d | 2024-10-23 | 2024-12-12 |  | ENKI - Días habiles | 24h | 24h | TRANSELEC | 19-08-2024 | 08-10-2024 | 37 días | 07 PI-PROCESO DE INTERCONEXIÓN | 100,00% | 100,00% | 100% |  |  |
| 282 | 1.8.3.1 | Envío de Informe de RID a Empresa Solicitante (ES) |  | 1d | 2024-08-19 A | 2024-08-19 A | 274, 39, 450 | 100% |  | 2024-08-19 | 2024-08-19 | 1d | 2024-10-23 | 2024-10-23 |  | ENKI - Días habiles | 12h | 12h | TRANSELEC | 19-08-2024 | 19-08-2024 | 1 día | 07 PI-PROCESO DE INTERCONEXIÓN | 100,00% | 100,00% | 100% | día 431,875 | 0,089485459 |
| 283 | 1.8.3.2 | Respuesta de ES a RID |  | 1d | 2024-08-20 A | 2024-08-20 A | 282 | 100% |  | 2024-08-20 | 2024-08-20 | 1d | 2024-10-24 | 2024-10-24 |  | ENKI - Días habiles |  |  | TRANSELEC | 20-08-2024 | 20-08-2024 | 1 día | 07 PI-PROCESO DE INTERCONEXIÓN | 100,00% | 100,00% | 100% | día 433 |  |
| 284 | 1.8.3.3 | Revisión de Ingeniería de Diseño |  | 15d | 2024-08-21 A | 2024-09-10 A | 283 | 100% |  | 2024-08-21 | 2024-09-10 | 15d | 2024-10-25 | 2024-11-14 |  | ENKI - Días habiles |  |  | TRANSELEC | 21-08-2024 | 10-09-2024 | 15 días | 07 PI-PROCESO DE INTERCONEXIÓN | 100,00% | 100,00% | 100% | día 434,125 |  |
| 285 | 1.8.3.4 | Atención de Observaciones |  | 4d | 2024-09-11 A | 2024-09-16 A | 284 | 100% |  | 2024-09-11 | 2024-09-16 | 4d | 2024-11-15 | 2024-11-21 |  | ENKI - Días habiles | 12h | 12h | TRANSELEC | 11-09-2024 | 17-09-2024 | 5 días | 07 PI-PROCESO DE INTERCONEXIÓN | 100,00% | 100,00% | 100% | día 451 | 0,089485459 |
| 286 | 1.8.3.5 | Revisión de Ingeniería de Diseño 1Era Iteración |  | 15d | 2024-09-18 A | 2024-10-08 A | 285 | 100% |  | 2024-09-18 | 2024-10-08 | 15d | 2024-11-22 | 2024-12-12 |  | ENKI - Días habiles |  |  | TRANSELEC | 18-09-2024 | 08-10-2024 | 15 días | 07 PI-PROCESO DE INTERCONEXIÓN | 100,00% | 100,00% | 100% | día 456,625 |  |
| 287 | 1.8.3.6 | Aprobación de Ingeniería de diseño 1Era Iteración | milestone | 0d | 2024-10-08 A | 2024-10-08 A | 286 | 100% |  | 2024-10-08 | 2024-10-08 | 0d | 2024-12-12 | 2024-12-12 |  | ENKI - Días habiles |  |  | TRANSELEC | 08-10-2024 | 08-10-2024 | 0 días | 07 PI-PROCESO DE INTERCONEXIÓN | 100,00% | 100,00% | 100% | día 473,5 |  |
| 288 | 1.8.4 | **IT- Información Técnica Estudios** |  | 56d | 2024-04-17 A | 2024-07-03 A |  | 100% |  | 2024-04-17 | 2024-07-03 | 56d | 2024-10-23 | 2025-01-08 |  | ENKI - Días habiles | 52h | 52h | TRANSELEC | 17-04-2024 | 03-07-2024 | 56 días | 07 PI-PROCESO DE INTERCONEXIÓN | 100,00% | 100,00% | 100% |  |  |
| 289 | 1.8.4.1 | Preparación Infotécnica para Estudios de Interconexión |  | 15d | 2024-04-17 A | 2024-05-07 A | 274, 89, 95, 101, 483 | 100% |  | 2024-04-17 | 2024-05-07 | 15d | 2024-10-23 | 2024-11-12 |  | ENKI - Días habiles | 37h | 37h | TRANSELEC | 17-04-2024 | 07-05-2024 | 15 días | 07 PI-PROCESO DE INTERCONEXIÓN | 100,00% | 100,00% | 100% | día 332,875 | 0,302013423 |
| 290 | 1.8.4.2 | Entrega de Información Técnica para Estudios de Interconexión |  | 1d | 2024-05-08 A | 2024-05-08 A | 289 | 100% |  | 2024-05-08 | 2024-05-08 | 1d | 2024-11-13 | 2024-11-13 |  | ENKI - Días habiles | 3h | 3h | TRANSELEC | 08-05-2024 | 08-05-2024 | 1 día | 07 PI-PROCESO DE INTERCONEXIÓN | 100,00% | 100,00% | 100% | día 349,75 | 0,011185682 |
| 291 | 1.8.4.3 | Revisión de Completitud por el CEN |  | 5d | 2024-05-09 A | 2024-05-15 A | 290 | 100% |  | 2024-05-09 | 2024-05-15 | 5d | 2024-11-14 | 2024-11-20 |  | ENKI - Días habiles |  |  | TRANSELEC | 09-05-2024 | 15-05-2024 | 5 días | 07 PI-PROCESO DE INTERCONEXIÓN | 100,00% | 100,00% | 100% | día 350,875 |  |
| 292 | 1.8.4.4 | Revisión de Información Técnica EI - 1era Iteración |  | 15d | 2024-05-16 A | 2024-06-05 A | 291 | 100% |  | 2024-05-16 | 2024-06-05 | 15d | 2024-11-21 | 2024-12-11 |  | ENKI - Días habiles |  |  | TRANSELEC | 16-05-2024 | 05-06-2024 | 15 días | 07 PI-PROCESO DE INTERCONEXIÓN | 100,00% | 100,00% | 100% | día 356,5 |  |
| 293 | 1.8.4.5 | Respuesta a Comentarios de Revisión IT - 1era Iteración |  | 4d | 2024-06-06 A | 2024-06-11 A | 292 | 100% |  | 2024-06-06 | 2024-06-11 | 4d | 2024-12-12 | 2024-12-18 |  | ENKI - Días habiles | 12h | 12h | TRANSELEC | 06-06-2024 | 12-06-2024 | 5 días | 07 PI-PROCESO DE INTERCONEXIÓN | 100,00% | 100,00% | 100% | día 373,375 | 0,089485459 |
| 294 | 1.8.4.6 | Revisión de Información Técnica EI - 2da Iteración |  | 15d | 2024-06-13 A | 2024-07-03 A | 293 | 100% |  | 2024-06-13 | 2024-07-03 | 15d | 2024-12-19 | 2025-01-08 |  | ENKI - Días habiles |  |  | TRANSELEC | 13-06-2024 | 03-07-2024 | 15 días | 07 PI-PROCESO DE INTERCONEXIÓN | 100,00% | 100,00% | 100% | día 379 |  |
| 295 | 1.8.4.7 | Aprobación de IT para Estudios | milestone | 0d | 2024-07-03 A | 2024-07-03 A | 294 | 100% |  | 2024-07-03 | 2024-07-03 | 0d | 2025-01-08 | 2025-01-08 |  | ENKI - Días habiles |  |  | TRANSELEC | 03-07-2024 | 03-07-2024 | 0 días | 07 PI-PROCESO DE INTERCONEXIÓN | 100,00% | 100,00% | 100% | día 395,875 |  |

| ID | WBS | Task | Duration | Start | Finish | Predecessors | Complete | Baseline start | Baseline finish | Baseline duration | Baseline 1 start | Baseline 1 finish | Calendar | Work | Actual work | Propietario | Baseline Star Rev1 | Baseline Finish Rev1 | Baseline Duration Rev1 | : | % Complete Peso | % Baseline Peso | % Baseline (Tempo) | Text11 | Entrada Peso |
| --- | --- | --- | --- | --- | --- | --- | --- | --- | --- | --- | --- | --- | --- | --- | --- | --- | --- | --- | --- | --- | --- | --- | --- | --- | --- |
| 296 | 1.8.5 | **EI-Estudios de Interconexión (Definidos por CEM)** | 353d | 2024-04-17 A | 2025-08-22 A |  | 100% | 2024-04-17 | 2025-08-22 | 353d | 2024-10-23 | 2025-06-12 | ENKI - Días habiles | 1783h | 1783h | TRANSELEC | 17-04-2024 | 21-07-2025 | 329 días | 07 PI-PROCESO DE INTERCONEXIÓN | 100,00% | 100,00% | 100% |  |  |
| 297 | 1.8.5.1 | **Estudio de Cortocircuitos (ECC)** | 134d | 2024-04-17 A | 2024-10-21 A |  | 100% | 2024-04-17 | 2024-10-21 | 134d | 2024-10-23 | 2025-06-12 | ENKI - Días habiles | 291h | 291h | TRANSELEC | 17-04-2024 | 23-10-2024 | 136 días | 07 PI-PROCESO DE INTERCONEXIÓN | 100,00% | 100,00% | 100% |  |  |
| 298 | 1.8.5.1.1 | Elaboración de Estudio | 31d | 2024-04-17 A | 2024-05-29 A | 274 | 100% | 2024-04-17 | 2024-05-29 | 31d | 2024-10-23 | 2024-12-17 | ENKI - Días habiles | 241h | 241h | TRANSELEC | 17-04-2024 | 11-06-2024 | 40 días | 07 PI-PROCESO DE INTERCONEXIÓN | 100,00% | 100,00% | 100% | día 332,875 | 0,221887413 |
| 299 | 1.8.5.1.2 | Entrega y Revisión CEN de EI - 1era Iteración | 30d | 2024-07-04 A | 2024-08-14 A | 298, 295 | 100% | 2024-07-04 | 2024-08-14 | 30d | 2025-01-09 | 2025-02-19 | ENKI - Días habiles |  |  | TRANSELEC | 04-07-2024 | 14-08-2024 | 30 días | 07 PI-PROCESO DE INTERCONEXIÓN | 100,00% | 100,00% | 100% | día 395,875 |  |
| 300 | 1.8.5.1.3 | Envío de Levantamiento de Observaciones de Estudios de Interconexión N°1 | 4d | 2024-08-15 A | 2024-08-20 A | 299 | 100% | 2024-08-15 | 2024-08-20 | 4d | 2025-02-20 | 2025-02-26 | ENKI - Días habiles | 25h | 25h | TRANSELEC | 15-08-2024 | 21-08-2024 | 5 días | 07 PI-PROCESO DE INTERCONEXIÓN | 100,00% | 100,00% | 100% | día 429,625 | 0,110943706 |
| 301 | 1.8.5.1.4 | Entrega y Revisión CEN de EI - 2da Iteración | 20d | 2024-08-21 A | 2024-09-17 A | 300 | 100% | 2024-08-21 | 2024-09-17 | 20d | 2025-02-27 | 2025-03-26 | ENKI - Días habiles |  |  | TRANSELEC | 22-08-2024 | 18-09-2024 | 20 días | 07 PI-PROCESO DE INTERCONEXIÓN | 100,00% | 100,00% | 100% | día 434,125 |  |
| 302 | 1.8.5.1.5 | Envío y Levantamiento de Observaciones de EI - 2da Iteración | 4d | 2024-09-18 A | 2024-09-23 A | 301 | 100% | 2024-09-18 | 2024-09-23 | 4d | 2025-03-27 | 2025-04-02 | ENKI - Días habiles | 25h | 25h | TRANSELEC | 19-09-2024 | 25-09-2024 | 5 días | 07 PI-PROCESO DE INTERCONEXIÓN | 100,00% | 100,00% | 100% | día 456,625 | 0,110943706 |
| 303 | 1.8.5.1.6 | Aprobación por parte del CEN de Estudios de Interconexión | 20d | 2024-09-24 A | 2024-10-21 A | 302 | 100% | 2024-09-24 | 2024-10-21 | 20d | 2025-04-03 | 2025-04-30 | ENKI - Días habiles |  |  | TRANSELEC | 26-09-2024 | 23-10-2024 | 20 días | 07 PI-PROCESO DE INTERCONEXIÓN | 100,00% | 100,00% | 100% | día 461,125 |  |
| 304 | 1.8.5.2 | **Estudio de Coordinación de Aislamiento (ECA)** | 135d | 2024-10-23 A | 2025-04-29 A |  | 100% | 2024-10-23 | 2025-04-29 | 135d | 2024-10-23 | 2025-06-12 | ENKI - Días habiles | 300h | 300h | TRANSELEC | 23-10-2024 | 29-04-2025 | 135 días | 07 PI-PROCESO DE INTERCONEXIÓN | 100,00% | 100,00% | 100% |  |  |
| 305 | 1.8.5.2.1 | Elaboración de Estudio | 32d | 2024-10-23 A | 2024-12-06 A | 274, 303FS-1d | 100% | 2024-10-23 | 2024-12-06 | 32d | 2024-10-23 | 2024-12-17 | ENKI - Días habiles | 250h | 250h | TRANSELEC | 23-10-2024 | 17-12-2024 | 40 días | 07 PI-PROCESO DE INTERCONEXIÓN | 100,00% | 100,00% | 100% | día 484,75 | 0,221887413 |
| 306 | 1.8.5.2.2 | Entrega y Revisión CEN de EI - 1era Iteración | 30d | 2025-01-08 A | 2025-02-18 A | 305FS+15d, 295 | 100% | 2025-01-08 | 2025-02-18 | 30d | 2025-01-09 | 2025-02-19 | ENKI - Días habiles |  |  | TRANSELEC | 08-01-2025 | 18-02-2025 | 30 días | 07 PI-PROCESO DE INTERCONEXIÓN | 100,00% | 100,00% | 100% | día 546,625 |  |
| 307 | 1.8.5.2.3 | Envío de Levantamiento de Observaciones de Estudios de Interconexión N°1 | 4d | 2025-02-19 A | 2025-02-24 A | 306 | 100% | 2025-02-19 | 2025-02-24 | 4d | 2025-02-20 | 2025-02-26 | ENKI - Días habiles | 25h | 25h | TRANSELEC | 19-02-2025 | 25-02-2025 | 5 días | 07 PI-PROCESO DE INTERCONEXIÓN | 100,00% | 100,00% | 100% | día 580,375 | 0,110943706 |
| 308 | 1.8.5.2.4 | Entrega y Revisión CEN de EI - 2da Iteración | 20d | 2025-02-26 A | 2025-03-25 A | 307 | 100% | 2025-02-26 | 2025-03-25 | 20d | 2025-02-27 | 2025-03-26 | ENKI - Días habiles |  |  | TRANSELEC | 26-02-2025 | 25-03-2025 | 20 días | 07 PI-PROCESO DE INTERCONEXIÓN | 100,00% | 100,00% | 100% | día 586 |  |
| 309 | 1.8.5.2.5 | Envío y Levantamiento de Observaciones de EI - 2da Iteración | 5d | 2025-03-26 A | 2025-04-01 A | 308 | 100% | 2025-03-26 | 2025-04-01 | 5d | 2025-03-27 | 2025-04-02 | ENKI - Días habiles | 25h | 25h | TRANSELEC | 26-03-2025 | 01-04-2025 | 5 días | 07 PI-PROCESO DE INTERCONEXIÓN | 100,00% | 100,00% | 100% | día 608,5 | 0,110943706 |
| 310 | 1.8.5.2.6 | Aprobación por parte del CEN de Estudios de Interconexión | 20d | 2025-04-02 A | 2025-04-29 A | 309 | 100% | 2025-04-02 | 2025-04-29 | 20d | 2025-04-03 | 2025-04-30 | ENKI - Días habiles |  |  | TRANSELEC | 02-04-2025 | 29-04-2025 | 20 días | 07 PI-PROCESO DE INTERCONEXIÓN | 100,00% | 100,00% | 100% | día 614,125 |  |
| 311 | 1.8.5.3 | **Estudio de Capacidad de Barra (ECB)** | 136d | 2024-04-17 A | 2024-10-23 A |  | 100% | 2024-04-17 | 2024-10-23 | 136d | 2024-10-23 | 2025-06-12 | ENKI - Días habiles | 291h | 291h | TRANSELEC | 17-04-2024 | 23-10-2024 | 136 días | 07 PI-PROCESO DE INTERCONEXIÓN | 100,00% | 100,00% | 100% |  |  |
| 312 | 1.8.5.3.1 | Elaboración de Estudio | 31.1d | 2024-04-17 A | 2024-05-30 A | 274 | 100% | 2024-04-17 | 2024-05-30 | 31.1d | 2024-10-23 | 2024-12-17 | ENKI - Días habiles | 241h | 241h | TRANSELEC | 17-04-2024 | 11-06-2024 | 40 días | 07 PI-PROCESO DE INTERCONEXIÓN | 100,00% | 100,00% | 100% | día 332,875 | 0,221887413 |
| 313 | 1.8.5.3.2 | Entrega y Revisión CEN de EI - 1era Iteración | 30d | 2024-07-04 A | 2024-08-14 A | 312FS+15d, 295 | 100% | 2024-07-04 | 2024-08-14 | 30d | 2025-01-09 | 2025-02-19 | ENKI - Días habiles |  |  | TRANSELEC | 04-07-2024 | 14-08-2024 | 30 días | 07 PI-PROCESO DE INTERCONEXIÓN | 100,00% | 100,00% | 100% | día 395,875 |  |
| 314 | 1.8.5.3.3 | Envío de Levantamiento de Observaciones de Estudios de Interconexión N°1 | 3.91d | 2024-08-15 A | 2024-08-20 A | 313 | 100% | 2024-08-15 | 2024-08-20 | 3.91d | 2025-02-20 | 2025-02-26 | ENKI - Días habiles | 25h | 25h | TRANSELEC | 15-08-2024 | 21-08-2024 | 5 días | 07 PI-PROCESO DE INTERCONEXIÓN | 100,00% | 100,00% | 100% | día 429,625 | 0,110943706 |
| 315 | 1.8.5.3.4 | Entrega y Revisión CEN de EI - 2da Iteración | 20d | 2024-08-22 A | 2024-09-18 A | 314 | 100% | 2024-08-22 | 2024-09-18 | 20d | 2025-02-27 | 2025-03-26 | ENKI - Días habiles |  |  | TRANSELEC | 22-08-2024 | 18-09-2024 | 20 días | 07 PI-PROCESO DE INTERCONEXIÓN | 100,00% | 100,00% | 100% | día 435,25 |  |
| 316 | 1.8.5.3.5 | Envío y Levantamiento de Observaciones de EI - 2da Iteración | 3.91d | 2024-09-19 A | 2024-09-24 A | 315 | 100% | 2024-09-19 | 2024-09-24 | 3.91d | 2025-03-27 | 2025-04-02 | ENKI - Días habiles | 25h | 25h | TRANSELEC | 19-09-2024 | 25-09-2024 | 5 días | 07 PI-PROCESO DE INTERCONEXIÓN | 100,00% | 100,00% | 100% | día 457,75 | 0,110943706 |
| 317 | 1.8.5.3.6 | Aprobación por parte del CEN de Estudios de Interconexión | 20d | 2024-09-26 A | 2024-10-23 A | 316 | 100% | 2024-09-26 | 2024-10-23 | 20d | 2025-04-03 | 2025-04-30 | ENKI - Días habiles |  |  | TRANSELEC | 26-09-2024 | 23-10-2024 | 20 días | 07 PI-PROCESO DE INTERCONEXIÓN | 100,00% | 100,00% | 100% | día 463,375 |  |
| 318 | 1.8.5.4 | **Estudio de Saturación Magnetica (ESM)** | 136d | 2024-10-23 A | 2025-04-30 A |  | 100% | 2024-10-23 | 2025-04-30 | 136d | 2024-10-23 | 2025-06-12 | ENKI - Días habiles | 291h | 291h | TRANSELEC | 23-10-2024 | 30-04-2025 | 136 días | 07 PI-PROCESO DE INTERCONEXIÓN | 100,00% | 100,00% | 100% |  |  |
| 319 | 1.8.5.4.1 | Elaboración de Estudio | 32d | 2024-10-23 A | 2024-12-05 A | 274, 39, 450, 305FS-32d | 100% | 2024-10-23 | 2024-12-05 | 32d | 2024-10-23 | 2024-12-17 | ENKI - Días habiles | 241h | 241h | TRANSELEC | 23-10-2024 | 17-12-2024 | 40 días | 07 PI-PROCESO DE INTERCONEXIÓN | 100,00% | 100,00% | 100% | día 484,75 | 0,221887413 |
| 320 | 1.8.5.4.2 | Entrega y Revisión CEN de EI - 1era Iteración | 30d | 2025-01-09 A | 2025-02-19 A | 319FS+16d, 295 | 100% | 2025-01-09 | 2025-02-19 | 30d | 2025-01-09 | 2025-02-19 | ENKI - Días habiles |  |  | TRANSELEC | 09-01-2025 | 19-02-2025 | 30 días | 07 PI-PROCESO DE INTERCONEXIÓN | 100,00% | 100,00% | 100% | día 547,75 |  |
| 321 | 1.8.5.4.3 | Envío de Levantamiento de Observaciones de Estudios de Interconexión N°1 | 4d | 2025-02-20 A | 2025-02-25 A | 320 | 100% | 2025-02-20 | 2025-02-25 | 4d | 2025-02-20 | 2025-02-26 | ENKI - Días habiles | 25h | 25h | TRANSELEC | 20-02-2025 | 26-02-2025 | 5 días | 07 PI-PROCESO DE INTERCONEXIÓN | 100,00% | 100,00% | 100% | día 581,5 | 0,110943706 |
| 322 | 1.8.5.4.4 | Entrega y Revisión CEN de EI - 2da Iteración | 20d | 2025-02-27 A | 2025-03-26 A | 321 | 100% | 2025-02-27 | 2025-03-26 | 20d | 2025-02-27 | 2025-03-26 | ENKI - Días habiles |  |  | TRANSELEC | 27-02-2025 | 26-03-2025 | 20 días | 07 PI-PROCESO DE INTERCONEXIÓN | 100,00% | 100,00% | 100% | día 587,125 |  |
| 323 | 1.8.5.4.5 | Envío y Levantamiento de Observaciones de EI - 2da Iteración | 5d | 2025-03-27 A | 2025-04-02 A | 322 | 100% | 2025-03-27 | 2025-04-02 | 5d | 2025-03-27 | 2025-04-02 | ENKI - Días habiles | 25h | 25h | TRANSELEC | 27-03-2025 | 02-04-2025 | 5 días | 07 PI-PROCESO DE INTERCONEXIÓN | 100,00% | 100,00% | 100% | día 609,625 | 0,110943706 |
| 324 | 1.8.5.4.6 | Aprobación por parte del CEN de Estudios de Interconexión | 20d | 2025-04-03 A | 2025-04-30 A | 323 | 100% | 2025-04-03 | 2025-04-30 | 20d | 2025-04-03 | 2025-04-30 | ENKI - Días habiles |  |  | TRANSELEC | 03-04-2025 | 30-04-2025 | 20 días | 07 PI-PROCESO DE INTERCONEXIÓN | 100,00% | 100,00% | 100% | día 615,25 |  |

| ID | WBS | Task | Type | Duration | Start | Finish | Predecessors | Complete | Baseline start | Baseline finish | Baseline duration | Baseline 1 start | Baseline 1 finish | Constraint | Calendar | Work | Actual work | Propietario | Baseline Star Rev1 | Baseline Finish Rev1 | Baseline Duration Rev1 | : | % Complete Peso | % Baseline Peso | % Baseline (Tempo) | Text11 | Entrada Peso |
| --- | --- | --- | --- | --- | --- | --- | --- | --- | --- | --- | --- | --- | --- | --- | --- | --- | --- | --- | --- | --- | --- | --- | --- | --- | --- | --- | --- |
| 325 | 1.8.5.5 | **Estudio de Malla de Puesta a Tierra (EMT)** |  | 136d | 2024-04-17 A | 2024-10-23 A |  | 100% | 2024-04-17 | 2024-10-23 | 136d | 2024-10-23 | 2025-06-12 |  | ENKI - Días habiles | 291h | 291h | TRANSELEC | 17-04-2024 | 23-10-2024 | 136 días | 07 PI-PROCESO DE INTERCONEXIÓN | 100,00% | 100,00% | 100% |  |  |
| 326 | 1.8.5.5.1 | Elaboración de Estudio |  | 31d | 2024-04-17 A | 2024-05-29 A | 274 | 100% | 2024-04-17 | 2024-05-29 | 31d | 2024-10-23 | 2024-12-17 |  | ENKI - Días habiles | 241h | 241h | TRANSELEC | 17-04-2024 | 11-06-2024 | 40 días | 07 PI-PROCESO DE INTERCONEXIÓN | 100,00% | 100,00% | 100% | día 332,875 | 0,221887413 |
| 327 | 1.8.5.5.2 | Entrega y Revisión CEN de EI - 1era Iteración |  | 30d | 2024-07-04 A | 2024-08-14 A | 326, 295 | 100% | 2024-07-04 | 2024-08-14 | 30d | 2025-01-09 | 2025-02-19 |  | ENKI - Días habiles |  |  | TRANSELEC | 04-07-2024 | 14-08-2024 | 30 días | 07 PI-PROCESO DE INTERCONEXIÓN | 100,00% | 100,00% | 100% | día 395,875 |  |
| 328 | 1.8.5.5.3 | Envío de Levantamiento de Observaciones de Estudios de Interconexión N°1 |  | 4d | 2024-08-15 A | 2024-08-20 A | 327 | 100% | 2024-08-15 | 2024-08-20 | 4d | 2025-02-20 | 2025-02-26 |  | ENKI - Días habiles | 25h | 25h | TRANSELEC | 15-08-2024 | 21-08-2024 | 5 días | 07 PI-PROCESO DE INTERCONEXIÓN | 100,00% | 100,00% | 100% | día 429,625 | 0,110943706 |
| 329 | 1.8.5.5.4 | Entrega y Revisión CEN de EI - 2da Iteración |  | 20d | 2024-08-22 A | 2024-09-18 A | 328 | 100% | 2024-08-22 | 2024-09-18 | 20d | 2025-02-27 | 2025-03-26 |  | ENKI - Días habiles |  |  | TRANSELEC | 22-08-2024 | 18-09-2024 | 20 días | 07 PI-PROCESO DE INTERCONEXIÓN | 100,00% | 100,00% | 100% | día 435,25 |  |
| 330 | 1.8.5.5.5 | Envío y Levantamiento de Observaciones de EI - 2da Iteración |  | 4d | 2024-09-19 A | 2024-09-24 A | 329 | 100% | 2024-09-19 | 2024-09-24 | 4d | 2025-03-27 | 2025-04-02 |  | ENKI - Días habiles | 25h | 25h | TRANSELEC | 19-09-2024 | 25-09-2024 | 5 días | 07 PI-PROCESO DE INTERCONEXIÓN | 100,00% | 100,00% | 100% | día 457,75 | 0,110943706 |
| 331 | 1.8.5.5.6 | Aprobación por parte del CEN de Estudios de Interconexión |  | 20d | 2024-09-26 A | 2024-10-23 A | 330 | 100% | 2024-09-26 | 2024-10-23 | 20d | 2025-04-03 | 2025-04-30 |  | ENKI - Días habiles |  |  | TRANSELEC | 26-09-2024 | 23-10-2024 | 20 días | 07 PI-PROCESO DE INTERCONEXIÓN | 100,00% | 100,00% | 100% | día 463,375 |  |
| 332 | 1.8.5.6 | **Estudio de Coordinación de Ajuste y Protecciones (ECAP)** |  | 113d | 2024-10-23 A | 2025-03-28 A |  | 100% | 2024-10-23 | 2025-03-28 | 113d | 2024-10-23 | 2025-06-12 |  | ENKI - Días habiles | 282h | 282h | TRANSELEC | 23-10-2024 | 14-03-2025 | 103 días | 07 PI-PROCESO DE INTERCONEXIÓN | 100,00% | 100,00% | 100% |  |  |
| 333 | 1.8.5.6.1 | Elaboración de Estudio |  | 44d | 2024-10-23 A | 2024-12-23 A | 274, 39, 450, 331FS-1d | 100% | 2024-10-23 | 2024-12-23 | 44d | 2024-10-23 | 2024-12-17 |  | ENKI - Días habiles | 277h | 277h | TRANSELEC | 23-10-2024 | 17-12-2024 | 40 días | 07 PI-PROCESO DE INTERCONEXIÓN | 100,00% | 100,00% | 100% | día 484,75 | 0,221887413 |
| 334 | 1.8.5.6.2 | Entrega y Revisión CEN de EI - 1era Iteración |  | 22d | 2025-02-27 A | 2025-03-28 A | 333FS+47d, 295 | 100% | 2025-02-27 | 2025-03-28 | 22d | 2025-01-09 | 2025-02-19 |  | ENKI - Días habiles |  |  | TRANSELEC | 18-12-2024 | 28-01-2025 | 30 días | 07 PI-PROCESO DE INTERCONEXIÓN | 100,00% | 100,00% | 100% | día 587,125 |  |
| 335 | 1.8.5.6.3 | Envío de Levantamiento de Observaciones de Estudios de Interconexión N°1 |  | 1d | 2025-03-28 A | 2025-03-28 A | 334FS-1d | 100% | 2025-03-28 | 2025-03-28 | 1d | 2025-02-20 | 2025-02-26 |  | ENKI - Días habiles | 5h | 5h | TRANSELEC | 29-01-2025 | 31-01-2025 | 3 días | 07 PI-PROCESO DE INTERCONEXIÓN | 100,00% | 100,00% | 100% | día 610,75 | 0,110943706 |
| 336 | 1.8.5.6.4 | Entrega y Revisión CEN de EI - 2da Iteración | milestone | 0d | 2025-03-28 A | 2025-03-28 A | 335 | 100% | 2025-03-28 | 2025-03-28 | 0d | 2025-02-27 | 2025-03-26 |  | ENKI - Días habiles |  |  | TRANSELEC | 03-02-2025 | 26-02-2025 | 18 días | 07 PI-PROCESO DE INTERCONEXIÓN | 100,00% | 100,00% | 100% | día 611,875 |  |
| 337 | 1.8.5.6.5 | Envío y Levantamiento de Observaciones de EI - 2da Iteración | milestone | 0d | 2025-03-28 A | 2025-03-28 A | 336 | 100% | 2025-03-28 | 2025-03-28 | 0d | 2025-03-27 | 2025-04-02 |  | ENKI - Días habiles |  |  | TRANSELEC | 27-02-2025 | 04-03-2025 | 4 días | 07 PI-PROCESO DE INTERCONEXIÓN | 100,00% | 100,00% | 100% | día 611,875 | 0,110943706 |
| 338 | 1.8.5.6.6 | Aprobación por parte del CEN de Estudios de Interconexión | milestone | 0d | 2025-03-28 A | 2025-03-28 A | 337 | 100% | 2025-03-28 | 2025-03-28 | 0d | 2025-04-03 | 2025-04-30 |  | ENKI - Días habiles |  |  | TRANSELEC | 25-02-2025 | 14-03-2025 | 14 días | 07 PI-PROCESO DE INTERCONEXIÓN | 100,00% | 100,00% | 100% | día 611,875 |  |
| 339 | 1.8.5.7 | **Entrega de Print Outs (PO)** |  | 31d | 2025-07-11 A | 2025-08-22 A |  | 100% | 2025-07-11 | 2025-08-22 | 31d | 2025-05-01 | 2025-06-12 |  | ENKI - Días habiles | 37h | 37h | TRANSELEC | 09-06-2025 | 21-07-2025 | 31 días | 07 PI-PROCESO DE INTERCONEXIÓN | 100,00% | 100,00% | 100% |  |  |
| 340 | 1.8.5.7.1 | Revision ECAP y elaboracion de los PO |  | 15d | 2025-07-11 A | 2025-07-31 A | 179FS-80d, 234FS-80d, 146FS-80d, 202FS-80d, 257FS-80d, 303FS-80d, 310FS-80d, 317FS-80d, 324FS-80d, 331FS-80d, 338FS-80d | 100% | 2025-07-11 | 2025-07-31 | 15d | 2025-05-01 | 2025-05-21 | start no earlier than 2025-06-07 | ENKI - Días habiles | 37h | 37h | TRANSELEC | 09-06-2025 | 27-06-2025 | 15 días | 07 PI-PROCESO DE INTERCONEXIÓN | 100,00% | 100,00% | 100% | día 695,125 | 0,05547185 |
| 341 | 1.8.5.7.2 | Entrega y Revisión CEN de PO - 1era Iteración |  | 15d | 2025-08-01 A | 2025-08-21 A | 340 | 100% | 2025-08-01 | 2025-08-21 | 15d | 2025-05-22 | 2025-06-11 |  | ENKI - Días habiles |  |  | TRANSELEC | 30-06-2025 | 18-07-2025 | 15 días | 07 PI-PROCESO DE INTERCONEXIÓN | 100,00% | 100,00% | 100% | día 712 |  |
| 342 | 1.8.5.7.3 | Aprobación de Print Out |  | 1d | 2025-08-22 A | 2025-08-22 A | 341 | 100% | 2025-08-22 | 2025-08-22 | 1d | 2025-06-12 | 2025-06-12 |  | ENKI - Días habiles |  |  | TRANSELEC | 21-07-2025 | 21-07-2025 | 1 día | 07 PI-PROCESO DE INTERCONEXIÓN | 100,00% | 100,00% | 100% | día 728,875 |  |
| 343 | 1.8.6 | **Sistema de Información es Tiempo Real (SITR)** |  | 192d | 2025-02-27 A | 2025-11-21 A |  | 100% | 2025-02-27 | 2025-11-21 | 192d | 2025-01-09 | 2025-04-08 |  | ENKI - Días habiles | 43h | 43h | TRANSELEC | 09-01-2025 | 08-04-2025 | 64 días | 07 PI-PROCESO DE INTERCONEXIÓN | 100,00% | 75,76% | 76% |  |  |
| 344 | 1.8.6.1 | **Enlace** |  | 6d | 2025-02-27 A | 2025-03-06 A |  | 100% | 2025-02-27 | 2025-03-06 | 6d | 2025-01-09 | 2025-01-16 |  | ENKI - Días habiles | 14h | 14h | TRANSELEC | 09-01-2025 | 16-01-2025 | 6 días | 07 PI-PROCESO DE INTERCONEXIÓN | 100,00% | 100,00% | 100% |  |  |
| 345 | 1.8.6.1.1 | Definición del Enlace |  | 1d | 2025-02-27 A | 2025-02-27 A | 299SS, 306SS, 313SS, 320SS, 327SS, 334SS | 100% | 2025-02-27 | 2025-02-27 | 1d | 2025-01-09 | 2025-01-09 |  | ENKI - Días habiles |  |  | TRANSELEC | 09-01-2025 | 09-01-2025 | 1 día | 07 PI-PROCESO DE INTERCONEXIÓN | 100,00% | 100,00% | 100% | día 587,125 |  |
| 346 | 1.8.6.1.2 | Prueba de Enlace |  | 5d | 2025-02-28 A | 2025-03-06 A | 345 | 100% | 2025-02-28 | 2025-03-06 | 5d | 2025-01-10 | 2025-01-16 |  | ENKI - Días habiles | 14h | 14h | TRANSELEC | 10-01-2025 | 16-01-2025 | 5 días | 07 PI-PROCESO DE INTERCONEXIÓN | 100,00% | 100,00% | 100% | día 588,25 | 0,10067114 |
| 347 | 1.8.6.2 | Solicitud al CEN del Listado SITR |  | 1d | 2025-02-28 A | 2025-02-28 A | 345 | 100% | 2025-02-28 | 2025-02-28 | 1d | 2025-01-10 | 2025-01-10 |  | ENKI - Días habiles | 8h | 8h | TRANSELEC | 10-01-2025 | 10-01-2025 | 1 día | 07 PI-PROCESO DE INTERCONEXIÓN | 100,00% | 100,00% | 100% | día 588,25 | 0,055928412 |
| 348 | 1.8.6.3 | Definición del CEN del Listado SITR |  | 15d | 2025-03-03 A | 2025-03-21 A | 347 | 100% | 2025-03-03 | 2025-03-21 | 15d | 2025-01-13 | 2025-01-31 |  | ENKI - Días habiles |  |  | TRANSELEC | 13-01-2025 | 31-01-2025 | 15 días | 07 PI-PROCESO DE INTERCONEXIÓN | 100,00% | 100,00% | 100% | día 589,375 |  |
| 349 | 1.8.6.4 | Observaciones SE sobre el Listado SITR |  | 3d | 2025-03-24 A | 2025-03-26 A | 348 | 100% | 2025-03-24 | 2025-03-26 | 3d | 2025-02-03 | 2025-02-05 |  | ENKI - Días habiles | 8h | 8h | TRANSELEC | 03-02-2025 | 05-02-2025 | 3 días | 07 PI-PROCESO DE INTERCONEXIÓN | 100,00% | 100,00% | 100% | día 606,25 | 0,055928412 |
| 350 | 1.8.6.5 | Aprobación del Listado SITR |  | 10d | 2025-03-27 A | 2025-04-09 A | 349 | 100% | 2025-03-27 | 2025-04-09 | 10d | 2025-02-06 | 2025-02-19 |  | ENKI - Días habiles |  |  | TRANSELEC | 06-02-2025 | 19-02-2025 | 10 días | 07 PI-PROCESO DE INTERCONEXIÓN | 100,00% | 100,00% | 100% | día 609,625 |  |
| 351 | 1.8.6.6 | Emision CEN del Listado SITR Definitivo |  | 1d | 2025-04-10 A | 2025-04-10 A | 350 | 100% | 2025-04-10 | 2025-04-10 | 1d | 2025-02-20 | 2025-02-20 |  | ENKI - Días habiles |  |  | TRANSELEC | 20-02-2025 | 20-02-2025 | 1 día | 07 PI-PROCESO DE INTERCONEXIÓN | 100,00% | 100,00% | 100% | día 620,875 |  |

| ID | WBS | Task | Duration | Start | Finish | Predecessors | Complete | Remaining | Baseline start | Baseline finish | Baseline duration | Baseline 1 start | Baseline 1 finish | Total slack | Free slack | Calendar | Work | Actual work | Propietario | Baseline Star Rev1 | Baseline Finish Rev1 | Baseline Duration Rev1 | : | % Complete Peso | % Baseline Peso | % Baseline (Tempo) | Text11 | Entrada Peso |
| --- | --- | --- | --- | --- | --- | --- | --- | --- | --- | --- | --- | --- | --- | --- | --- | --- | --- | --- | --- | --- | --- | --- | --- | --- | --- | --- | --- | --- |
| 352 | 1.8.6.7 | **DIR/TAG** | 6d | 2025-04-11 A | 2025-04-18 A |  | 100% |  | 2025-04-11 | 2025-04-18 | 6d | 2025-02-21 | 2025-02-28 |  |  | ENKI - Días habiles | 8h | 8h | TRANSELEC | 21-02-2025 | 28-02-2025 | 6 días | 07 PI-PROCESO DE INTERCONEXIÓN | 100,00% | 100,00% | 100% |  |  |
| 353 | 1.8.6.7.1 | Solicitud de Tag ICCP o Direcciones IEC104/DNP | 1d | 2025-04-11 A | 2025-04-11 A | 351 | 100% |  | 2025-04-11 | 2025-04-11 | 1d | 2025-02-21 | 2025-02-21 |  |  | ENKI - Días habiles | 8h | 8h | TRANSELEC | 21-02-2025 | 21-02-2025 | 1 día | 07 PI-PROCESO DE INTERCONEXIÓN | 100,00% | 100,00% | 100% | día 622 | 0,055928412 |
| 354 | 1.8.6.7.2 | Emisión o revisión de Tag ICCP o Direcciones IEC104/DNP | 5d | 2025-04-14 A | 2025-04-18 A | 353 | 100% |  | 2025-04-14 | 2025-04-18 | 5d | 2025-02-24 | 2025-02-28 |  |  | ENKI - Días habiles |  |  | TRANSELEC | 24-02-2025 | 28-02-2025 | 5 días | 07 PI-PROCESO DE INTERCONEXIÓN | 100,00% | 100,00% | 100% | día 623,125 |  |
| 355 | 1.8.6.8 | **Pruebas** | 150d | 2025-04-21 A | 2025-11-14 A |  | 100% |  | 2025-04-21 | 2025-11-14 | 150d | 2025-03-03 | 2025-03-11 |  |  | ENKI - Días habiles | 2h | 2h | TRANSELEC | 03-03-2025 | 11-03-2025 | 7 días | 07 PI-PROCESO DE INTERCONEXIÓN | 100,00% | 100,00% | 73% |  |  |
| 356 | 1.8.6.8.1 | Solicitud de Fecha de Pruebas SITR | 1d | 2025-04-21 A | 2025-04-21 A | 351, 354 | 100% |  | 2025-04-21 | 2025-04-21 | 1d | 2025-03-03 | 2025-03-03 |  |  | ENKI - Días habiles | 2h | 2h | TRANSELEC | 03-03-2025 | 03-03-2025 | 1 día | 07 PI-PROCESO DE INTERCONEXIÓN | 100,00% | 100,00% | 100% | día 628,75 | 0,011185682 |
| 357 | 1.8.6.8.2 | Confirmación de Fecha de Pruebas SITR | 3d | 2025-04-22 A | 2025-04-24 A | 356 | 100% |  | 2025-04-22 | 2025-04-24 | 3d | 2025-03-04 | 2025-03-06 |  |  | ENKI - Días habiles |  |  | TRANSELEC | 04-03-2025 | 06-03-2025 | 3 días | 07 PI-PROCESO DE INTERCONEXIÓN | 100,00% | 100,00% | 100% | día 629,875 |  |
| 358 | 1.8.6.8.3 | Resultados de Pruebas Internas SITR | 3d | 2025-11-12 A | 2025-11-14 A | 357, 356 | 100% |  | 2025-11-12 | 2025-11-14 | 3d | 2025-03-07 | 2025-03-11 |  |  | ENKI - Días habiles |  |  | TRANSELEC | 07-03-2025 | 11-03-2025 | 3 días | 07 PI-PROCESO DE INTERCONEXIÓN | 100,00% | 0,00% | 0% | día 794,125 |  |
| 359 | 1.8.6.9 | **Pruebas SITR** | 5d | 2025-11-17 A | 2025-11-21 A |  | 100% |  | 2025-11-17 | 2025-11-21 | 5d | 2025-03-12 | 2025-04-08 |  |  | ENKI - Días habiles | 3h | 3h | TRANSELEC | 12-03-2025 | 08-04-2025 | 20 días | 07 PI-PROCESO DE INTERCONEXIÓN | 100,00% | 0,00% | 0% |  |  |
| 360 | 1.8.6.9.1 | Resultados de Pruebas SITR | 5d | 2025-11-17 A | 2025-11-21 A | 358 | 100% |  | 2025-11-17 | 2025-11-21 | 5d | 2025-03-12 | 2025-04-08 |  |  | ENKI - Días habiles | 3h | 3h | TRANSELEC | 12-03-2025 | 08-04-2025 | 20 días | 07 PI-PROCESO DE INTERCONEXIÓN | 100,00% | 0,00% | 0% | día 797,5 | 0,089485459 |
| 361 | 1.8.7 | **Esquema de Medida de Energía (EME)** | 162d | 2025-04-10 A | 2025-11-21 |  | 56% | 71.04d | 2025-04-10 | 2025-11-21 | 162d | 2025-02-20 | 2025-06-03 | 4d |  | ENKI - Días habiles | 89h | 66.1h | TRANSELEC | 20-02-2025 | 03-06-2025 | 74 días | 07 PI-PROCESO DE INTERCONEXIÓN | 66,40% | 65,12% | 72% |  |  |
| 362 | 1.8.7.1 | Solicitud al CEN de Requisitos EME | 1d | 2025-04-10 A | 2025-04-10 A | 299, 306, 313, 320, 327, 334 | 100% |  | 2025-04-10 | 2025-04-10 | 1d | 2025-02-20 | 2025-02-20 |  |  | ENKI - Días habiles | 2h | 2h | TRANSELEC | 20-02-2025 | 20-02-2025 | 1 día | 07 PI-PROCESO DE INTERCONEXIÓN | 100,00% | 100,00% | 100% | día 620,875 | 0,011185682 |
| 363 | 1.8.7.2 | Envio de informe EME a Empresa Solicitante (ES) | 5d | 2025-04-11 A | 2025-04-17 A | 362 | 100% |  | 2025-04-11 | 2025-04-17 | 5d | 2025-02-21 | 2025-02-27 |  |  | ENKI - Días habiles |  |  | TRANSELEC | 21-02-2025 | 27-02-2025 | 5 días | 07 PI-PROCESO DE INTERCONEXIÓN | 100,00% | 100,00% | 100% | día 622 |  |
| 364 | 1.8.7.3 | Respuesta de ES a EME | 15d | 2025-04-18 A | 2025-05-08 A | 363 | 100% |  | 2025-04-18 | 2025-05-08 | 15d | 2025-02-28 | 2025-03-20 |  |  | ENKI - Días habiles | 63h | 63h | TRANSELEC | 28-02-2025 | 20-03-2025 | 15 días | 07 PI-PROCESO DE INTERCONEXIÓN | 100,00% | 100,00% | 100% | día 627,625 | 0,302013423 |
| 365 | 1.8.7.4 | Revision CEM de antecedentes EME - 1era Iteración | 15d | 2025-05-09 A | 2025-05-29 A | 364 | 100% |  | 2025-05-09 | 2025-05-29 | 15d | 2025-03-21 | 2025-04-10 |  |  | ENKI - Días habiles |  |  | TRANSELEC | 21-03-2025 | 10-04-2025 | 15 días | 07 PI-PROCESO DE INTERCONEXIÓN | 100,00% | 100,00% | 100% | día 644,5 |  |
| 366 | 1.8.7.5 | Definición y Pruebas de Enlace | 5d | 2025-05-30 A | 2025-06-05 A | 365 | 100% |  | 2025-05-30 | 2025-06-05 | 5d | 2025-04-11 | 2025-04-17 |  |  | ENKI - Días habiles |  |  | TRANSELEC | 11-04-2025 | 17-04-2025 | 5 días | 07 PI-PROCESO DE INTERCONEXIÓN | 100,00% | 100,00% | 100% | día 661,375 |  |
| 367 | 1.8.7.6 | Solicitud de Fecha de Pruebas PRMTE | 1d | 2025-10-08 A | 2025-10-08 | 254FS-25d, 255FS-25d | 55% | 0.45d | 2025-10-08 | 2025-10-08 | 1d | 2025-04-18 | 2025-04-18 | 4d | 0d | ENKI - Días habiles | 2h | 1.1h | TRANSELEC | 18-04-2025 | 18-04-2025 | 1 día | 07 PI-PROCESO DE INTERCONEXIÓN | 55,00% | 0,00% | 0% | día 766 | 0,011185682 |
| 368 | 1.8.7.7 | Confirmación de Fecha de Pruebas PRMTE | 5d | 2025-10-09 | 2025-10-15 | 367 |  |  | 2025-10-09 | 2025-10-15 | 5d | 2025-04-21 | 2025-04-25 | 4d | 0d | ENKI - Días habiles |  |  | TRANSELEC | 21-04-2025 | 25-04-2025 | 5 días | 07 PI-PROCESO DE INTERCONEXIÓN | 0,00% | 0,00% | 0% | día 767,125 |  |
| 369 | 1.8.7.8 | Pruebas PRMTE | 1d | 2025-10-16 | 2025-10-16 | 368 |  |  | 2025-10-16 | 2025-10-16 | 1d | 2025-04-28 | 2025-04-28 | 4d | 0d | ENKI - Días habiles | 14h |  | TRANSELEC | 28-04-2025 | 28-04-2025 | 1 día | 07 PI-PROCESO DE INTERCONEXIÓN | 0,00% | 0,00% | 0% | día 772,75 | 0,100671141 |
| 370 | 1.8.7.9 | Resultados PRMTE | 10d | 2025-10-17 | 2025-10-30 | 369 |  |  | 2025-10-17 | 2025-10-30 | 10d | 2025-04-29 | 2025-05-12 | 4d | 0d | ENKI - Días habiles |  |  | TRANSELEC | 29-04-2025 | 12-05-2025 | 10 días | 07 PI-PROCESO DE INTERCONEXIÓN | 0,00% | 0,00% | 0% | día 773,875 |  |
| 371 | 1.8.7.10 | Complemento ES de antecedentes EME | 1d | 2025-10-31 | 2025-10-31 | 370 |  |  | 2025-10-31 | 2025-10-31 | 1d | 2025-05-13 | 2025-05-13 | 4d | 0d | ENKI - Días habiles | 8h |  | TRANSELEC | 13-05-2025 | 13-05-2025 | 1 día | 07 PI-PROCESO DE INTERCONEXIÓN | 0,00% | 0,00% | 0% | día 785,125 | 0,055928412 |
| 372 | 1.8.7.11 | Aprobación de EME - 2da Iteración | 15d | 2025-11-03 | 2025-11-21 | 371 |  |  | 2025-11-03 | 2025-11-21 | 15d | 2025-05-14 | 2025-06-03 | 4d | 0d | ENKI - Días habiles |  |  | TRANSELEC | 14-05-2025 | 03-06-2025 | 15 días | 07 PI-PROCESO DE INTERCONEXIÓN | 0,00% | 0,00% | 0% | día 786,25 |  |
| 373 | 1.8.8 | **PES-Requisitos para PES (J3 última PES)** | 719d | 2023-03-01 A | 2025-12-01 |  | 57% | 308.14d | 2023-03-01 | 2025-12-01 | 719d | 2025-03-18 | 2025-07-18 | 29d |  | ENKI - Días habiles | 742h | 459.6h | TRANSELEC | 01-05-2025 | 11-08-2025 | 73 días | 07 PI-PROCESO DE INTERCONEXIÓN | 61,90% | 43,38% | 92% |  |  |
| 374 | 1.8.8.1 | **Guía de maniobras** | 42d | 2025-09-19 A | 2025-11-17 |  | 60% | 16.8d | 2025-09-19 | 2025-11-17 | 42d | 2025-05-01 | 2025-06-26 | 8d |  | ENKI - Días habiles | 354h | 212.4h | TRANSELEC | 01-05-2025 | 26-06-2025 | 41 días | 07 PI-PROCESO DE INTERCONEXIÓN | 60,00% | 1,10% | 2% |  |  |
| 375 | 1.8.8.1.1 | Envío de Guía de Maniobras | 1d | 2025-09-19 A | 2025-10-01 | 234FS-30d, 257FS-30d | 60% | 0.4d | 2025-09-19 | 2025-10-01 | 1d | 2025-05-01 | 2025-05-01 | 1.6d | 0d | ENKI - Días habiles | 36h | 21.6h | TRANSELEC | 01-05-2025 | 01-05-2025 | 1 día | 07 PI-PROCESO DE INTERCONEXIÓN | 60,00% | 11,00% | 11% | día 751,375 | 0,011185682 |
| 376 | 1.8.8.1.2 | Revisión de Guía de Maniobras - 1era Iteración | 15d | 2025-09-22 A | 2025-10-10 | 375 | 60% | 6d | 2025-09-22 | 2025-10-10 | 15d | 2025-05-01 | 2025-05-21 | 3d | 0d | ENKI - Días habiles |  |  | TRANSELEC | 01-05-2025 | 21-05-2025 | 15 días | 07 PI-PROCESO DE INTERCONEXIÓN | 60,00% | 0,00% | 0% | día 752,5 |  |
| 377 | 1.8.8.1.3 | Envío de Respuesta a Observaciones a Guia de Maniobras | 5d | 2025-10-13 A | 2025-10-17 | 376 | 60% | 2d | 2025-10-13 | 2025-10-17 | 5d | 2025-05-22 | 2025-05-28 | 12d | 0d | ENKI - Días habiles | 318h | 190.8h | TRANSELEC | 22-05-2025 | 28-05-2025 | 5 días | 07 PI-PROCESO DE INTERCONEXIÓN | 60,00% | 0,00% | 0% | día 769,375 | 0,100671141 |
| 378 | 1.8.8.1.4 | Revisión de Guía de Maniobras - 2da Iteración | 20d | 2025-10-20 A | 2025-11-14 | 377 | 60% | 8d | 2025-10-20 | 2025-11-14 | 20d | 2025-05-29 | 2025-06-25 | 0.6d | 0d | ENKI - Días habiles |  |  | TRANSELEC | 29-05-2025 | 25-06-2025 | 20 días | 07 PI-PROCESO DE INTERCONEXIÓN | 60,00% | 0,00% | 0% | día 775 |  |
| 379 | 1.8.8.1.5 | Aprobación de Guía de Maniobras | 1d | 2025-11-17 A | 2025-11-17 | 378 | 60% | 0.4d | 2025-11-17 | 2025-11-17 | 1d | 2025-06-26 | 2025-06-26 | 8d | 4d | ENKI - Días habiles |  |  | TRANSELEC | 26-06-2025 | 26-06-2025 | 1 día | 07 PI-PROCESO DE INTERCONEXIÓN | 60,00% | 0,00% | 0% | día 797,5 |  |

| ID | WBS | Task | Type | Duration | Start | Finish | Predecessors | Complete | Remaining | Baseline start | Baseline finish | Baseline duration | Baseline 1 start | Baseline 1 finish | Total slack | Free slack | Constraint | Calendar | Work | Actual work | Propietario | Baseline Star Rev1 | Baseline Finish Rev1 | Baseline Duration Rev1 | : | % Complete Peso | % Baseline Peso | % Baseline (Tempo) | Text11 | Entrada Peso |
| --- | --- | --- | --- | --- | --- | --- | --- | --- | --- | --- | --- | --- | --- | --- | --- | --- | --- | --- | --- | --- | --- | --- | --- | --- | --- | --- | --- | --- | --- | --- |
| 380 | 1.8.8.2 | **Programa de Pruebas (PROG P)** |  | 36d | 2023-03-01 A | 2023-04-19 |  | 60% | 14.4d | 2023-03-01 | 2023-04-19 | 36d | 2025-05-01 | 2025-06-20 | 712d |  |  | ENKI - Días habiles | 318h | 190.8h | TRANSELEC | 01-05-2025 | 20-06-2025 | 37 días | 07 PI-PROCESO DE INTERCONEXIÓN | 60,00% | 100,00% | 100% |  |  |
| 381 | 1.8.8.2.1 | Revisión de Programa de Pruebas- 1era Iteración |  | 15d | 2023-03-01 A | 2023-03-21 |  | 60% | 6d | 2023-03-01 | 2023-03-21 | 15d | 2025-05-02 | 2025-05-22 | 3d | 0d |  | ENKI - Días habiles |  |  | TRANSELEC | 02-05-2025 | 22-05-2025 | 15 días | 07 PI-PROCESO DE INTERCONEXIÓN | 60,00% | 100,00% | 100% | día 1 |  |
| 382 | 1.8.8.2.2 | Respuesta a Observaciones de Programa de Pruebas |  | 5d | 2023-03-22 A | 2023-03-28 | 381 | 60% | 2d | 2023-03-22 | 2023-03-28 | 5d | 2025-05-23 | 2025-05-29 | 9d | 0d |  | ENKI - Días habiles | 318h | 190.8h | TRANSELEC | 23-05-2025 | 29-05-2025 | 5 días | 07 PI-PROCESO DE INTERCONEXIÓN | 60,00% | 100,00% | 100% | día 17,875 | 0,100671141 |
| 383 | 1.8.8.2.3 | Revisión de Programa de Pruebas - 2da Iteración |  | 15d | 2023-03-29 A | 2023-04-18 | 382 | 60% | 6d | 2023-03-29 | 2023-04-18 | 15d | 2025-05-30 | 2025-06-19 | 0.6d | 0d |  | ENKI - Días habiles |  |  | TRANSELEC | 30-05-2025 | 19-06-2025 | 15 días | 07 PI-PROCESO DE INTERCONEXIÓN | 60,00% | 100,00% | 100% | día 23,5 |  |
| 384 | 1.8.8.2.4 | Aprobación de Programa de Pruebas |  | 1d | 2023-04-19 A | 2023-04-19 | 383 | 60% | 0.4d | 2023-04-19 | 2023-04-19 | 1d | 2025-06-20 | 2025-06-20 | 712d |  |  | ENKI - Días habiles |  |  | TRANSELEC | 20-06-2025 | 20-06-2025 | 1 día | 07 PI-PROCESO DE INTERCONEXIÓN | 60,00% | 100,00% | 100% | día 40,375 |  |
| 385 | 1.8.8.3 | **Protocolos SAT Equipos Primarios (PROT E)** |  | 12d | 2025-10-30 A | 2025-11-14 |  | 60% | 4.8d | 2025-10-30 | 2025-11-14 | 12d | 2025-03-18 | 2025-04-10 | 40d |  |  | ENKI - Días habiles | 34h | 20.4h | TRANSELEC | 04-06-2025 | 26-06-2025 | 17 días | 07 PI-PROCESO DE INTERCONEXIÓN | 60,00% | 0,00% | 0% |  |  |
| 386 | 1.8.8.3.1 | Solicitud de Revisión Protocolos SAT Equipos Primarios |  | 1d | 2025-10-30 A | 2025-11-10 | 169, 171, 173, 224, 226, 228, 138, 140, 194, 249, 251 | 60% | 0.4d | 2025-10-30 | 2025-11-10 | 1d | 2025-03-18 | 2025-03-19 | 0d |  |  | ENKI - Días habiles | 34h | 20.4h | TRANSELEC | 04-06-2025 | 04-06-2025 | 1 día | 07 PI-PROCESO DE INTERCONEXIÓN | 60,00% | 0,00% | 0% | día 784 | 0,011185682 |
| 387 | 1.8.8.3.2 | Revisión de Protocolos SAT Equipos Primarios - 1era Iteración |  | 10d | 2025-10-31 A | 2025-11-14 | 386 | 60% | 4d | 2025-10-31 | 2025-11-14 | 10d | 2025-03-19 | 2025-04-09 | 0.2d | 0d |  | ENKI - Días habiles |  |  | TRANSELEC | 05-06-2025 | 25-06-2025 | 15 días | 07 PI-PROCESO DE INTERCONEXIÓN | 60,00% | 0,00% | 0% | día 785,125 |  |
| 388 | 1.8.8.3.3 | Protocolos PROT E Aprobados |  | 1d | 2025-11-14 A | 2025-11-14 | 387 | 60% | 0.4d | 2025-11-14 | 2025-11-14 | 1d | 2025-04-09 | 2025-04-10 | 40d |  |  | ENKI - Días habiles |  |  | TRANSELEC | 26-06-2025 | 26-06-2025 | 1 día | 07 PI-PROCESO DE INTERCONEXIÓN | 60,00% | 0,00% | 0% | día 796,375 |  |
| 389 | 1.8.8.4 | **Protocolos Protecciones(PROT P)** |  | 15d | 2023-03-01 A | 2023-03-21 |  | 60% | 6d | 2023-03-01 | 2023-03-21 | 15d | 2025-04-14 | 2025-05-05 | 733d |  |  | ENKI - Días habiles |  |  | TRANSELEC | 09-06-2025 | 30-06-2025 | 16 días | 07 PI-PROCESO DE INTERCONEXIÓN | 0,00% | 0,00% | 100% |  |  |
| 390 | 1.8.8.4.1 | Revisión de Protocolos Protecciones - 1era Iteración |  | 15d | 2023-03-01 A | 2023-03-21 |  | 60% | 6d | 2023-03-01 | 2023-03-21 | 15d | 2025-04-15 | 2025-05-05 | 733d | 0d |  | ENKI - Días habiles |  |  | TRANSELEC | 10-06-2025 | 30-06-2025 | 15 días | 07 PI-PROCESO DE INTERCONEXIÓN | 60,00% | 100,00% | 100% | día 1 |  |
| 391 | 1.8.8.4.2 | Protocolos PROT P Aprobados | milestone | 0d | 2023-03-21 A | 2023-03-21 | 390 | 60% | 0d | 2023-03-21 | 2023-03-21 | 0d | 2025-05-05 | 2025-05-05 | 733d |  |  | ENKI - Días habiles |  |  | TRANSELEC | 30-06-2025 | 30-06-2025 | 0 días | 07 PI-PROCESO DE INTERCONEXIÓN | 60,00% | 100,00% | 100% | día 17,875 |  |
| 392 | 1.8.8.5 | **Comunicación a la SEC (CARTA SEC)** |  | 10d | 2025-11-18 A | 2025-12-01 |  | 14% | 8.57d | 2025-11-18 | 2025-12-01 | 10d | 2025-06-27 | 2025-07-18 | 4d |  |  | ENKI - Días habiles | 36h | 36h | TRANSELEC | 01-07-2025 | 11-08-2025 | 30 días | 07 PI-PROCESO DE INTERCONEXIÓN | 100,00% | 0,00% | 0% |  |  |
| 393 | 1.8.8.5.1 | Envío de Comunicación a la SEC |  | 1d | 2025-11-18 A | 2025-11-18 A | 379, 384, 388, 391, 185, 240, 498, 501, 153, 208, 263FS-100d | 100% |  | 2025-11-18 | 2025-11-18 | 1d | 2025-06-27 | 2025-06-27 |  |  | start no earlier than 2025-04-27 | ENKI - Días habiles | 36h | 36h | TRANSELEC | 01-07-2025 | 01-07-2025 | 1 día | 07 PI-PROCESO DE INTERCONEXIÓN | 100,00% | 0,00% | 0% | día 798,625 | 0,011185682 |
| 394 | 1.8.8.5.2 | Autorización para PES por parte del CEN |  | 6d | 2025-11-24 | 2025-12-01 | 280, 287, 342, 360, 372, 393, 494, 346, 379 |  |  | 2025-11-24 | 2025-12-01 | 6d | 2025-06-30 | 2025-07-18 | 4d | 0d |  | ENKI - Días habiles |  |  | TRANSELEC | 22-07-2025 | 11-08-2025 | 15 días | 07 PI-PROCESO DE INTERCONEXIÓN | 0,00% | 0,00% | 0% | día 803,125 |  |
| 395 | 1.8.9 | **Entrada en Operación** |  | 51d | 2025-10-06 | 2025-12-15 |  |  |  | 2025-10-06 | 2025-12-15 | 51d | 2025-01-09 | 2025-09-02 | 6d |  |  | ENKI - Días habiles | 786h |  | TRANSELEC | 11-03-2025 | 02-09-2025 | 126 días | 07 PI-PROCESO DE INTERCONEXIÓN | 0,00% | 0,00% | 0% |  |  |
| 396 | 1.8.9.1 | **Infotécnica para Puesta en Servicio (IT PES)** |  | 27d | 2025-10-06 | 2025-11-11 |  |  |  | 2025-10-06 | 2025-11-11 | 27d | 2025-01-09 | 2025-02-14 | 6d |  |  | ENKI - Días habiles |  |  | TRANSELEC | 11-03-2025 | 16-04-2025 | 27 días | 07 PI-PROCESO DE INTERCONEXIÓN | 0,00% | 0,00% | 0% |  |  |
| 397 | 1.8.9.1.1 | Solicitud de Verificación de Información Técnica PES - 1era Iteración |  | 1d | 2025-10-06 | 2025-10-06 | 295, 86, 91, 97, 103, 484, 208FS+30d |  |  | 2025-10-06 | 2025-10-06 | 1d | 2025-01-09 | 2025-01-09 | 6d | 0d |  | ENKI - Días habiles |  |  | TRANSELEC | 11-03-2025 | 11-03-2025 | 1 día | 07 PI-PROCESO DE INTERCONEXIÓN | 0,00% | 0,00% | 0% | día 763,75 | 0,011185682 |
| 398 | 1.8.9.1.2 | Solicitud de Revisión de Completitud PES |  | 5d | 2025-10-07 | 2025-10-13 | 397 |  |  | 2025-10-07 | 2025-10-13 | 5d | 2025-01-10 | 2025-01-16 | 6d | 0d |  | ENKI - Días habiles |  |  | TRANSELEC | 12-03-2025 | 18-03-2025 | 5 días | 07 PI-PROCESO DE INTERCONEXIÓN | 0,00% | 0,00% | 0% | día 764,875 | 0,011185682 |
| 399 | 1.8.9.1.3 | Revisión del CEN de Información Técnica PES - 1era Iteración |  | 5d | 2025-10-14 | 2025-10-20 | 398 |  |  | 2025-10-14 | 2025-10-20 | 5d | 2025-01-17 | 2025-01-23 | 6d | 0d |  | ENKI - Días habiles |  |  | TRANSELEC | 19-03-2025 | 25-03-2025 | 5 días | 07 PI-PROCESO DE INTERCONEXIÓN | 0,00% | 0,00% | 0% | día 770,5 |  |
| 400 | 1.8.9.1.4 | Respuesta a Observaciones del CEN de IT PES - 1era Iteración |  | 3d | 2025-10-21 | 2025-10-23 | 399 |  |  | 2025-10-21 | 2025-10-23 | 3d | 2025-01-24 | 2025-01-28 | 6d | 0d |  | ENKI - Días habiles |  |  | TRANSELEC | 26-03-2025 | 28-03-2025 | 3 días | 07 PI-PROCESO DE INTERCONEXIÓN | 0,00% | 0,00% | 0% | día 776,125 | 0,100671141 |
| 401 | 1.8.9.1.5 | Solicitud de Verificación de Información Técnica PES - 2da Iteración |  | 7d | 2025-10-24 | 2025-11-03 | 400 |  |  | 2025-10-24 | 2025-11-03 | 7d | 2025-01-29 | 2025-02-06 | 6d | 0d |  | ENKI - Días habiles |  |  | TRANSELEC | 31-03-2025 | 08-04-2025 | 7 días | 07 PI-PROCESO DE INTERCONEXIÓN | 0,00% | 0,00% | 0% | día 779,5 | 0,011185682 |
| 402 | 1.8.9.1.6 | Revisión de Información Técnica PES - 2da Iteración |  | 5d | 2025-11-04 | 2025-11-10 | 401 |  |  | 2025-11-04 | 2025-11-10 | 5d | 2025-02-07 | 2025-02-13 | 6d | 0d |  | ENKI - Días habiles |  |  | TRANSELEC | 09-04-2025 | 15-04-2025 | 5 días | 07 PI-PROCESO DE INTERCONEXIÓN | 0,00% | 0,00% | 0% | día 787,375 |  |
| 403 | 1.8.9.1.7 | Aprobación de IT PES |  | 1d | 2025-11-11 | 2025-11-11 | 402 |  |  | 2025-11-11 | 2025-11-11 | 1d | 2025-02-14 | 2025-02-14 | 6d | 0d |  | ENKI - Días habiles |  |  | TRANSELEC | 16-04-2025 | 16-04-2025 | 1 día | 07 PI-PROCESO DE INTERCONEXIÓN | 0,00% | 0,00% | 0% | día 793 |  |

| ID | WBS | Task | Type | Duration | Start | Finish | Predecessors | Complete | Remaining | Baseline start | Baseline finish | Baseline duration | Baseline 1 start | Baseline 1 finish | Total slack | Free slack | Calendar | Work | Propietario | Baseline Star Rev1 | Baseline Finish Rev1 | Baseline Duration Rev1 | : | % Complete Peso | % Baseline Peso | % Baseline (Tempo) | Text11 | Entrada Peso |
| --- | --- | --- | --- | --- | --- | --- | --- | --- | --- | --- | --- | --- | --- | --- | --- | --- | --- | --- | --- | --- | --- | --- | --- | --- | --- | --- | --- | --- |
| 404 | 1.8.9.2 | **Print Out Relés Existentes (PO E)** |  | 12d | 2025-11-12 | 2025-11-27 |  |  |  | 2025-11-12 | 2025-11-27 | 12d | 2025-07-21 | 2025-08-12 | 6d |  | ENKI - Días habiles | 393h | TRANSELEC | 01-07-2025 | 23-07-2025 | 17 días | 07 PI-PROCESO DE INTERCONEXIÓN | 0,00% | 0,00% | 0% |  |  |
| 405 | 1.8.9.2.1 | Solicitud de Revisión de PO Existentes |  | 1d | 2025-11-12 | 2025-11-12 | 394FS-30d, 403 |  |  | 2025-11-12 | 2025-11-12 | 1d | 2025-07-21 | 2025-07-21 | 6d | 0d | ENKI - Días habiles | 393h | TRANSELEC | 01-07-2025 | 01-07-2025 | 1 día | 07 PI-PROCESO DE INTERCONEXIÓN | 0,00% | 0,00% | 0% | día 794,125 | 0,011185682 |
| 406 | 1.8.9.2.2 | Revisión de Print Out Existentes |  | 10d | 2025-11-13 | 2025-11-26 | 405 |  |  | 2025-11-13 | 2025-11-26 | 10d | 2025-07-22 | 2025-08-11 | 6d | 0d | ENKI - Días habiles |  | TRANSELEC | 02-07-2025 | 22-07-2025 | 15 días | 07 PI-PROCESO DE INTERCONEXIÓN | 0,00% | 0,00% | 0% | día 795,25 |  |
| 407 | 1.8.9.2.3 | Aprobación de PO Existentes |  | 1d | 2025-11-27 | 2025-11-27 | 406 |  |  | 2025-11-27 | 2025-11-27 | 1d | 2025-08-12 | 2025-08-12 | 6d | 2d | ENKI - Días habiles |  | TRANSELEC | 23-07-2025 | 23-07-2025 | 1 día | 07 PI-PROCESO DE INTERCONEXIÓN | 0,00% | 0,00% | 0% | día 806,5 |  |
| 408 | 1.8.9.3 | **Solicitud de entrada en operación (SEO)** |  | 10d | 2025-12-02 | 2025-12-15 |  |  |  | 2025-12-02 | 2025-12-15 | 10d | 2025-08-12 | 2025-09-02 | 4d |  | ENKI - Días habiles | 393h | TRANSELEC | 12-08-2025 | 02-09-2025 | 16 días | 09 EO-ENTRADA EN OPERACIÓN | 0,00% | 0,00% | 0% |  |  |
| 409 | 1.8.9.3.1 | Solicitud de entrada en operación |  | 1d | 2025-12-02 | 2025-12-02 | 394, 403, 407 |  |  | 2025-12-02 | 2025-12-02 | 1d | 2025-08-12 | 2025-08-12 | 4d | 0d | ENKI - Días habiles | 393h | TRANSELEC | 12-08-2025 | 12-08-2025 | 1 día | 09 EO-ENTRADA EN OPERACIÓN | 0,00% | 0,00% | 0% | día 809,875 |  |
| 410 | 1.8.9.3.2 | Carta de respuesta de solicitud de entrada en operación |  | 8d | 2025-12-03 | 2025-12-12 | 409 |  |  | 2025-12-03 | 2025-12-12 | 8d | 2025-08-13 | 2025-09-02 | 4d | 0d | ENKI - Días habiles |  | TRANSELEC | 13-08-2025 | 02-09-2025 | 15 días | 09 EO-ENTRADA EN OPERACIÓN | 0,00% | 0,00% | 0% | día 811 |  |
| 411 | 1.8.9.3.3 | Declaración de Entrada en operación |  | 1d | 2025-12-15 | 2025-12-15 | 410 |  |  | 2025-12-15 | 2025-12-15 | 1d | 2025-09-02 | 2025-09-02 | 19d | 0d | ENKI - Días habiles |  | TRANSELEC | 02-09-2025 | 02-09-2025 | 0 días | 09 EO-ENTRADA EN OPERACIÓN | 0,00% | 0,00% | 0% | día 820 |  |
| 412 | 2 | **LT 2x220kV ENCUENTRO - KIMAL (SATT)** |  | 1043d | 2023-03-01 A | 2026-01-06 |  | 74% | 268.17d | 2023-03-01 | 2026-01-06 | 1043d | 2023-03-01 | 2025-09-02 | 5d |  |  |  | SATT | 01-03-2023 | 02-09-2025 | 917 días | SATT | 0,00% | 0,00% | 89% |  |  |
| 413 | 2.1 | Publicación en el Diario Oficial del Decreto de Adjudicación | milestone | 0d | 2023-03-01 A | 2023-03-01 A |  | 100% |  | 2023-03-01 | 2023-03-01 | 0d | 2023-03-01 | 2023-03-01 |  |  |  |  | SATT | 01-03-2023 | 01-03-2023 | 0 días | SATT | 100,00% | 100,00% | 100% | día 1 |  |
| 414 | 2.2 | Día siguiente a la fecha de publicación en el Diario Oficial del Decreto de Adjudicación | milestone | 0d | 2023-03-02 A | 2023-03-02 A | 413SS+2d | 100% |  | 2023-03-02 | 2023-03-02 | 0d | 2023-03-02 | 2023-03-02 |  |  |  |  | SATT | 02-03-2023 | 02-03-2023 | 0 días | SATT | 100,00% | 100,00% | 100% | día 3,25 |  |
| 415 | 2.3 | **HITOS DEL PROYECTO** |  | 1005d | 2023-03-16 A | 2025-12-15 |  |  | 1005d | 2023-03-16 | 2025-12-15 | 1005d | 2023-03-15 | 2025-09-02 | 27d |  |  |  | SATT | 16-03-2023 | 02-09-2025 | 901 días | SATT | 0,00% | 0,00% | 91% |  |  |
| 416 | 2.3.1 | Firma del Contrato con Propietario | milestone | 0d | 2023-03-16 A | 2023-03-16 A | 414FS+14d | 100% |  | 2023-03-16 | 2023-03-16 | 0d | 2023-03-15 | 2023-03-15 |  |  |  |  | SATT | 16-03-2023 | 16-03-2023 | 0 días | SATT | 100,00% | 100,00% | 100% | día 19 |  |
| 417 | 2.3.2 | Emisión de Boleta de Garantia | milestone | 0d | 2023-03-16 A | 2023-03-16 A | 414FS+14d | 100% |  | 2023-03-16 | 2023-03-16 | 0d | 2023-03-15 | 2023-03-15 |  |  |  |  | SATT | 16-03-2023 | 16-03-2023 | 0 días | SATT | 100,00% | 100,00% | 100% | día 19 |  |
| 418 | 2.3.3 | Entrega de Programa Maestro del Contrato | milestone | 0d | 2023-04-01 A | 2023-04-01 A | 414FS+30d | 100% |  | 2023-04-01 | 2023-04-01 | 0d | 2023-03-31 | 2023-03-31 |  |  |  |  | SATT | 01-04-2023 | 01-04-2023 | 0 días | SATT | 100,00% | 100,00% | 100% | día 37 |  |
| 419 | 2.3.4 | Entrega de Lista de Entregables de Ingeniería | milestone | 0d | 2023-04-01 A | 2023-04-01 A | 414FS+30d | 100% |  | 2023-04-01 | 2023-04-01 | 0d | 2023-03-31 | 2023-03-31 |  |  |  |  | SATT | 01-04-2023 | 01-04-2023 | 0 días | SATT | 100,00% | 100,00% | 100% | día 37 |  |
| 420 | 2.3.5 | Acceso sin restricción al terreno para realización de estudios de diseño | milestone | 0d | 2023-04-27 A | 2023-04-27 A |  | 100% |  | 2023-04-27 | 2023-04-27 | 0d | 2023-04-26 | 2023-04-26 |  |  |  |  | SATT | 27-04-2023 | 27-04-2023 | 0 días | SATT | 100,00% | 100,00% | 100% | día 65,125 |  |
| 421 | 2.3.6 | Revisión y Aprobación del Programa Maestro del Contrato y Lista de Entregables de Ingeniería | milestone | 0d | 2023-06-30 A | 2023-06-30 A | 418FS+90d | 100% |  | 2023-06-30 | 2023-06-30 | 0d | 2023-06-29 | 2023-06-29 |  |  |  |  | SATT | 30-06-2023 | 30-06-2023 | 0 días | SATT | 100,00% | 100,00% | 100% | día 138,25 |  |
| 422 | 2.3.7 | Contratación de seguros | milestone | 0d | 2024-11-14 A | 2024-11-14 A | 491FS-15d | 100% |  | 2024-11-14 | 2024-11-14 | 0d | 2024-09-18 | 2024-09-18 |  |  |  |  | SATT | 14-11-2024 | 14-11-2024 | 0 días | SATT | 100,00% | 100,00% | 100% | día 703 |  |
| 423 | 2.3.8 | Presentación Ofertas ITO al Coordinador | milestone | 0d | 2024-08-20 A | 2024-08-20 A | 465 | 100% |  | 2024-08-20 | 2024-08-20 | 0d | 2024-06-24 | 2024-06-24 |  |  |  |  | SATT | 20-08-2024 | 20-08-2024 | 0 días | SATT | 100,00% | 100,00% | 100% | día 607,375 |  |
| 424 | 2.3.9 | Firma Contrato con ITO designado | milestone | 0d | 2024-11-03 A | 2024-11-03 A | 467 | 100% |  | 2024-11-03 | 2024-11-03 | 0d | 2024-09-07 | 2024-09-07 |  |  |  |  | SATT | 03-11-2024 | 03-11-2024 | 0 días | SATT | 100,00% | 100,00% | 100% | día 691,75 |  |
| 425 | 2.3.10 | Recepción del Acta de Entrega de Terreno | milestone | 0d | 2024-11-29 | 2024-11-29 | 491 |  |  | 2024-11-29 | 2024-11-29 | 0d | 2024-10-02 | 2024-10-02 | 409d |  |  |  | SATT | 29-11-2024 | 29-11-2024 | 0 días | SATT | 0,00% | 100,00% | 100% | día 719,875 |  |
| 426 | 2.3.11 | Término comisionamiento del transformadores de medida, seccionadores, etc. | milestone | 0d | 2025-12-13 | 2025-12-13 | 264 |  |  | 2025-12-13 | 2025-12-13 | 0d | 2025-07-18 | 2025-07-18 | 29d |  |  |  | SATT | 12-08-2025 | 12-08-2025 | 0 días | SATT | 0,00% | 0,00% | 0% | día 1147,375 |  |
| 427 | 2.3.12 | Solicitud de conexión al Coordinador Eléctrico Nacional de acuerdo a lo indicado en el Anexo Técnico Requisitos Técnicos Mínimos de Instalaciones que se conectan al SI, de la NTSyCS, según se establece en numeral 2 romanillos xi o xii | milestone | 0d | 2024-08-12 | 2024-08-12 | 508SS, 268SS |  |  | 2024-08-12 | 2024-08-12 | 0d | 2024-08-12 | 2024-08-12 | 518d |  |  |  | SATT | 12-08-2024 | 12-08-2024 | 0 días | SATT | 0,00% | 100,00% | 100% | día 597,25 |  |
| 428 | 2.3.13 | Entrada en Operación de la Obra | milestone | 0d | 2025-12-15 | 2025-12-15 | 411 |  |  | 2025-12-15 | 2025-12-15 | 0d | 2025-09-02 | 2025-09-02 | 27d |  |  |  | SATT | 02-09-2025 | 02-09-2025 | 0 días | SATT | 0,00% | 0,00% | 0% | día 1149,625 |  |
| 429 | 2.3.14 | Entrega AS BUILT (Información) por parte del Coordinador, de las Subestaciones Colindantes | milestone | 0d | 2023-03-26 | 2023-03-26 | 416FS+10d |  |  | 2023-03-26 | 2023-03-26 | 0d | 2023-03-25 | 2023-03-25 | 1022d |  |  |  | SATT | 26-03-2023 | 26-03-2023 | 0 días | SATT | 0,00% | 100,00% | 100% | día 30,25 |  |

| ID | WBS | Task | Type | Duration | Start | Finish | Predecessors | Complete | Remaining | Baseline start | Baseline finish | Baseline duration | Baseline 1 start | Baseline 1 finish | Total slack | Free slack | Propietario | Baseline Star Rev1 | Baseline Finish Rev1 | Baseline Duration Rev1 | : | % Complete Peso | % Baseline Peso | % Baseline (Tempo) | Text11 |
| --- | --- | --- | --- | --- | --- | --- | --- | --- | --- | --- | --- | --- | --- | --- | --- | --- | --- | --- | --- | --- | --- | --- | --- | --- | --- |
| 430 | 2.4 | **DESCONEXIONES** |  | 91d | 2024-12-19 | 2025-03-19 |  |  |  | 2024-12-19 | 2025-03-19 | 91d | 2024-10-23 | 2025-01-21 | 138d |  | SATT | 19-12-2024 | 19-03-2025 | 91 días | SATT | 0,00% | 0,00% | 100% |  |
| 431 | 2.4.1 | Desconexión CTO. 1 Encuentro - Kimal | milestone | 0d | 2024-12-19 | 2024-12-19 | 496SS |  |  | 2024-12-19 | 2024-12-19 | 0d | 2024-10-23 | 2024-10-23 | 138d | 0d | SATT | 19-12-2024 | 19-12-2024 | 0 días | SATT | 0,00% | 100,00% | 100% | día 742,375 |
| 432 | 2.4.2 | Desconexión CTO. 2 Encuentro - Kimal | milestone | 0d | 2025-03-19 | 2025-03-19 | 431FS+91d |  |  | 2025-03-19 | 2025-03-19 | 0d | 2025-01-21 | 2025-01-21 | 138d | 0d | SATT | 19-03-2025 | 19-03-2025 | 0 días | SATT | 0,00% | 100,00% | 100% | día 844,75 |
| 433 | 2.4.3 | Desconexión de CTO. Paño acoplador | milestone | 0d | 2024-12-19 | 2024-12-19 | 431 |  |  | 2024-12-19 | 2024-12-19 | 0d | 2024-10-23 | 2024-10-23 | 209d | 70d | SATT | 19-12-2024 | 19-12-2024 | 0 días | SATT | 0,00% | 100,00% | 100% | día 742,375 |
| 434 | 2.5 | **HITOS DE PAGO** |  | 920d | 2023-06-30 A | 2026-01-05 |  |  | 920d | 2023-06-30 | 2026-01-05 | 920d | 2023-06-29 | 2025-09-02 | 6d |  | SATT | 30-06-2023 | 02-09-2025 | 795 días | SATT | 0,00% | 0,00% | 88% |  |
| 435 | 2.5.1 | (Hito de Pago N°1) Aprobación Programa Maestro y Lista de entregables de Ingeniería | milestone | 0d | 2023-06-30 A | 2023-06-30 A | 416, 421 | 100% |  | 2023-06-30 | 2023-06-30 | 0d | 2023-06-29 | 2023-06-29 |  |  | SATT | 30-06-2023 | 30-06-2023 | 0 días | SATT | 100,00% | 100,00% | 100% | día 138,25 |
| 436 | 2.5.2 | (Hito de Pago N°2) Revisión y Aprobación de Ingeniería Básica | milestone | 0d | 2024-02-15 A | 2024-02-15 A | 448FS+15d | 100% |  | 2024-02-15 | 2024-02-15 | 0d | 2024-02-14 | 2024-02-14 |  |  | SATT | 15-02-2024 | 15-02-2024 | 0 días | SATT | 100,00% | 100,00% | 100% | día 397 |
| 437 | 2.5.3 | (Hito de Pago N°3) Revisión y Aprobación de Ingeniería de Detalle | milestone | 0d | 2024-09-02 A | 2024-09-02 A | 450FS+15d | 100% |  | 2024-09-02 | 2024-09-02 | 0d | 2024-09-01 | 2024-09-01 |  |  | SATT | 02-09-2024 | 02-09-2024 | 0 días | SATT | 100,00% | 100,00% | 100% | día 622 |
| 438 | 2.5.4 | (Hito de Pago N°4) Autorización Medio Ambiental para inicio construcción | milestone | 0d | 2024-11-01 A | 2024-11-01 A | 449FS+15d | 100% |  | 2024-11-01 | 2024-11-01 | 0d | 2024-10-31 | 2024-10-31 |  |  | SATT | 01-11-2024 | 01-11-2024 | 0 días | SATT | 100,00% | 100,00% | 100% | día 689,5 |
| 439 | 2.5.5 | (Hito de Pago N°5) Entrega en terreno del 100% equipamiento primario | milestone | 0d | 2024-11-16 | 2024-11-16 | 485FS+235d |  |  | 2024-11-16 | 2024-11-16 | 0d | 2024-11-15 | 2024-11-15 | 421d |  | SATT | 16-11-2024 | 16-11-2024 | 0 días | SATT | 0,00% | 100,00% | 100% | día 706,375 |
| 440 | 2.5.6 | (Hito de Pago N°6) Entrega en terreno del 100% suministro principal ferretería AT | milestone | 0d | 2024-08-18 | 2024-08-18 | 489FS+15d, 485FS+15d |  |  | 2024-08-18 | 2024-08-18 | 0d | 2024-08-17 | 2024-08-17 | 511d |  | SATT | 18-08-2024 | 18-08-2024 | 0 días | SATT | 0,00% | 100,00% | 100% | día 605,125 |
| 441 | 2.5.7 | (Hito de Pago N°7) Aprobación del 100% Fundaciones, Estructuras y Caseta de SS.GG y/o celdas | milestone | 0d | 2025-06-12 | 2025-06-12 | 453 |  |  | 2025-06-12 | 2025-06-12 | 0d | 2025-04-16 | 2025-04-16 | 213d |  | SATT | 12-06-2025 | 12-06-2025 | 0 días | SATT | 0,00% | 100,00% | 100% | día 940,375 |
| 442 | 2.5.8 | (Hito de Pago N°8) Tendido de conductor de línea y/o Montaje Equipos principales AT | milestone | 0d | 2025-07-02 | 2025-07-02 | 454 |  |  | 2025-07-02 | 2025-07-02 | 0d | 2025-05-06 | 2025-05-06 | 193d |  | SATT | 02-07-2025 | 02-07-2025 | 0 días | SATT | 0,00% | 100,00% | 100% | día 962,875 |
| 443 | 2.5.9 | (Hito de Pago N°9) Aprobación del 100% Pruebas SAT Equipos de Control, Protecciones y Telecomunicaciones | milestone | 0d | 2025-08-26 | 2025-08-26 | 497FS+70d, 500FS+70d |  |  | 2025-08-26 | 2025-08-26 | 0d | 2025-06-30 | 2025-06-30 | 138d |  | SATT | 26-08-2025 | 26-08-2025 | 0 días | SATT | 0,00% | 100,00% | 100% | día 1024,75 |
| 444 | 2.5.10 | (Hito de Pago N°10) Aprobación y recepción provisional del 100% de protocolos de puesta en servicio | milestone | 0d | 2025-12-12 | 2025-12-12 | 600, 394 |  |  | 2025-12-12 | 2025-12-12 | 0d | 2025-07-18 | 2025-07-18 | 30d |  | SATT | 11-08-2025 | 11-08-2025 | 0 días | SATT | 0,00% | 0,00% | 0% | día 1146,25 |
| 445 | 2.5.11 | (Hito de Pago N°11) Estado de Pago Final: Finalización del 100% de la lista de pendientes y firma acta devolución del terreno. | milestone | 0d | 2026-01-05 | 2026-01-05 | 505 |  |  | 2026-01-05 | 2026-01-05 | 0d | 2025-09-02 | 2025-09-02 | 6d |  | SATT | 02-09-2025 | 02-09-2025 | 0 días | SATT | 0,00% | 0,00% | 0% | día 1173,25 |
| 446 | 2.6 | **HITOS INTERMEDIOS** |  | 814d | 2023-09-20 A | 2025-12-12 |  |  | 814d | 2023-09-20 | 2025-12-12 | 814d | 2023-09-19 | 2025-05-31 | 30d |  | SATT | 20-09-2023 | 09-07-2025 | 658 días | SATT | 0,00% | 0,00% | 89% |  |
| 447 | 2.6.1 | (Hito Intermedio N°1) Entrega al Mandante de todos los estudios de terreno que se requieren para la correcta ejecución de la Obra en el Terreno, como, por ejemplo y sin que la lista sea taxativa, mecánica de suelos, Topografía u otro que aplicase. | milestone | 0d | 2023-09-20 A | 2023-09-20 A | 435FS+82d, 470, 471 | 100% |  | 2023-09-20 | 2023-09-20 | 0d | 2023-09-19 | 2023-09-19 |  |  | SATT | 20-09-2023 | 20-09-2023 | 0 días | SATT | 100,00% | 100,00% | 100% | día 230,5 |
| 448 | 2.6.2 | (Hito Intermedio N°2) Entrega al Mandante de la Ingeniería Básica en Rev. 0 aceptada por el Mandante y de los estudios que solicite el Coordinador para verificar el cumplimiento de las especificaciones técnicas de la obra. | milestone | 0d | 2024-01-31 A | 2024-01-31 A |  | 100% |  | 2024-01-31 | 2024-01-31 | 0d | 2024-01-30 | 2024-01-30 |  |  | SATT | 31-01-2024 | 31-01-2024 | 0 días | SATT | 100,00% | 100,00% | 100% | día 380,125 |
| 449 | 2.6.3 | (Hito Intermedio N°3) Entrega al Mandante de los documentos que certifiquen la aprobación de los permisos necesarios para el inicio de la construcción de las obras. | milestone | 0d | 2024-10-17 A | 2024-10-17 A | 459FS+15d, 463FS+15d | 100% |  | 2024-10-17 | 2024-10-17 | 0d | 2024-10-16 | 2024-10-16 |  |  | SATT | 17-10-2024 | 17-10-2024 | 0 días | SATT | 100,00% | 100,00% | 100% | día 672,625 |
| 450 | 2.6.4 | (Hito Intermedio N°4) Entrega al Mandante de todos los documentos asociados a la Ingeniería de detalle del proyecto Electromecánico y de OOCC en Revisión 0 aceptado por el Mandante. | milestone | 0d | 2024-08-18 A | 2024-08-18 A |  | 100% |  | 2024-08-18 | 2024-08-18 | 0d | 2024-08-17 | 2024-08-17 |  |  | SATT | 18-08-2024 | 18-08-2024 | 0 días | SATT | 100,00% | 100,00% | 100% | día 605,125 |
| 451 | 2.6.5 | (Hito Intermedio N°5) Entrega al Mandante de una copia del contrato firmado entre el Contratista y la ITO designada por el Coordinador para la Obra adjudicada. | milestone | 0d | 2024-11-13 A | 2024-11-13 A | 467FS+10d | 100% |  | 2024-11-13 | 2024-11-13 | 0d | 2024-09-17 | 2024-09-17 |  |  | SATT | 13-11-2024 | 13-11-2024 | 0 días | SATT | 100,00% | 100,00% | 100% | día 703 |
| 452 | 2.6.6 | (Hito Intermedio N°6) Entrega al Mandante de una copia de las Órdenes de Compra de los equipos y/o estructuras en caso que aplicase. | milestone | 0d | 2023-12-02 A | 2023-12-02 A | 483FS+55d | 100% |  | 2023-12-02 | 2023-12-02 | 0d | 2023-12-01 | 2023-12-01 |  |  | SATT | 02-12-2023 | 02-12-2023 | 0 días | SATT | 100,00% | 100,00% | 100% | día 312,625 |
| 453 | 2.6.7 | (Hito Intermedio N°7) Entrega al Mandante de documento emitido por la ITO que certifique que: recepción conforme del 100% de las fundaciones en el caso de ampliaciones de subestaciones; y tendido de conductor en caso de lineas. | milestone | 0d | 2025-06-12 | 2025-06-12 | 496FS+15d, 499FS+15d |  |  | 2025-06-12 | 2025-06-12 | 0d | 2025-04-16 | 2025-04-16 | 213d | 0d | SATT | 12-06-2025 | 12-06-2025 | 0 días | SATT | 0,00% | 100,00% | 100% | día 940,375 |
| 454 | 2.6.8 | (Hito Intermedio N°8) Entrega al Mandante de un documento que certifique que la ITO ha recibido conforme el montaje de los equipos primarios en SSEE y/o tendido de conductores en caso de líneas, según corresponda. | milestone | 0d | 2025-07-02 | 2025-07-02 | 499FS+35d, 496FS+35d |  |  | 2025-07-02 | 2025-07-02 | 0d | 2025-05-06 | 2025-05-06 | 193d | 0d | SATT | 02-07-2025 | 02-07-2025 | 0 días | SATT | 0,00% | 100,00% | 100% | día 962,875 |
| 455 | 2.6.9 | (Hito Intermedio N°9) Entrega al Mandante de todos los estudios e información solicitada por el Coordinador Eléctrico Nacional para la Puesta en Servicio de la Obra de acuerdo a lo establecido en las Bases Técnicas de la Obra. | milestone | 0d | 2025-12-12 | 2025-12-12 | 579FS+30d, 585FS+30d, 591FS+30d, 595FS+30d, 375FS+30d, 386FS+30d |  |  | 2025-12-12 | 2025-12-12 | 0d | 2025-05-31 | 2025-05-31 | 30d |  | SATT | 09-07-2025 | 09-07-2025 | 0 días | SATT | 0,00% | 0,00% | 0% | día 1146,25 |

| ID | WBS | Task | Duration | Start | Finish | Predecessors | Complete | Baseline start | Baseline finish | Baseline duration | Baseline 1 start | Baseline 1 finish | Propietario | Baseline Star Rev1 | Baseline Finish Rev1 | Baseline Duration Rev1 | : | % Complete Peso | % Baseline Peso | % Baseline (Tempo) | Text11 |
| --- | --- | --- | --- | --- | --- | --- | --- | --- | --- | --- | --- | --- | --- | --- | --- | --- | --- | --- | --- | --- | --- |
| 456 | 2.7 | **TRAMITACIÓN AMBIENTAL** | 405d | 2023-04-02 A | 2024-05-10 A |  | 100% | 2023-04-02 | 2024-05-10 | 405d | 2023-04-01 | 2024-05-09 | SATT | 02-04-2023 | 10-05-2024 | 405 días | SATT | 0,00% | 0,00% | 100% |  |
| 457 | 2.7.1 | Elaboración de documento | 210d | 2023-04-02 A | 2023-10-28 A | 414FS+30d | 100% | 2023-04-02 | 2023-10-28 | 210d | 2023-04-01 | 2023-10-27 | SATT | 02-04-2023 | 28-10-2023 | 210 días | SATT | 100,00% | 100,00% | 100% | día 37 |
| 458 | 2.7.2 | Ingreso de CP al SEIA | 15d | 2023-10-29 A | 2023-11-12 A | 457 | 100% | 2023-10-29 | 2023-11-12 | 15d | 2023-10-28 | 2023-11-11 | SATT | 29-10-2023 | 12-11-2023 | 15 días | SATT | 100,00% | 100,00% | 100% | día 273,25 |
| 459 | 2.7.3 | Evaluación y Obtención de Permiso Ambiental (Respuesta Pertinencia/RCA) | 180d | 2023-11-13 A | 2024-05-10 A | 458 | 100% | 2023-11-13 | 2024-05-10 | 180d | 2023-11-12 | 2024-05-09 | SATT | 13-11-2023 | 10-05-2024 | 180 días | SATT | 100,00% | 100,00% | 100% | día 290,125 |
| 460 | 2.8 | **PERMISOS AMBIENTALES DE OBRA** | 175d | 2024-04-11 A | 2024-10-02 A |  | 100% | 2024-04-11 | 2024-10-02 | 175d | 2024-04-10 | 2024-10-01 | SATT | 11-04-2024 | 02-10-2024 | 175 días | SATT | 0,00% | 0,00% | 100% |  |
| 461 | 2.8.1 | Elaboración de Documento | 70d | 2024-04-11 A | 2024-06-19 A | 459FS-30d | 100% | 2024-04-11 | 2024-06-19 | 70d | 2024-04-10 | 2024-06-18 | SATT | 11-04-2024 | 19-06-2024 | 70 días | SATT | 100,00% | 100,00% | 100% | día 458,875 |
| 462 | 2.8.2 | Ingreso de Permiso ante la Autoridad | 15d | 2024-06-20 A | 2024-07-04 A | 461 | 100% | 2024-06-20 | 2024-07-04 | 15d | 2024-06-19 | 2024-07-03 | SATT | 20-06-2024 | 04-07-2024 | 15 días | SATT | 100,00% | 100,00% | 100% | día 537,625 |
| 463 | 2.8.3 | Evaluación de la autoridad y obtención del permiso | 90d | 2024-07-05 A | 2024-10-02 A | 462 | 100% | 2024-07-05 | 2024-10-02 | 90d | 2024-07-04 | 2024-10-01 | SATT | 05-07-2024 | 02-10-2024 | 90 días | SATT | 100,00% | 100,00% | 100% | día 554,5 |
| 464 | 2.9 | **GESTIÓN DE CONTRATO ITO** | 155d | 2024-06-02 A | 2024-11-03 A |  | 100% | 2024-06-02 | 2024-11-03 | 155d | 2024-04-06 | 2024-09-07 | SATT | 02-06-2024 | 03-11-2024 | 155 días | SATT | 0,00% | 0,00% | 100% |  |
| 465 | 2.9.1 | Presentación de Propuestas ITO al coordinador | 80d | 2024-06-02 A | 2024-08-20 A | 491FS-180d | 100% | 2024-06-02 | 2024-08-20 | 80d | 2024-04-06 | 2024-06-24 | SATT | 02-06-2024 | 20-08-2024 | 80 días | SATT | 100,00% | 100,00% | 100% | día 517,375 |
| 466 | 2.9.2 | Evaluación y designación de ITO por parte del coordinador | 45d | 2024-08-21 A | 2024-10-04 A | 465 | 100% | 2024-08-21 | 2024-10-04 | 45d | 2024-06-25 | 2024-08-08 | SATT | 21-08-2024 | 04-10-2024 | 45 días | SATT | 100,00% | 100,00% | 100% | día 607,375 |
| 467 | 2.9.3 | Firma del contrato con ITO designado | 30d | 2024-10-05 A | 2024-11-03 A | 466 | 100% | 2024-10-05 | 2024-11-03 | 30d | 2024-08-09 | 2024-09-07 | SATT | 05-10-2024 | 03-11-2024 | 30 días | SATT | 100,00% | 100,00% | 100% | día 658 |
| 468 | 2.10 | **Ingeniería** | 270d | 2023-05-02 A | 2024-01-26 A |  | 100% | 2023-05-02 | 2024-01-26 | 270d | 2023-05-01 | 2024-01-25 | SATT | 02-05-2023 | 26-01-2024 | 270 días | SATT | 0,00% | 0,00% | 100% |  |
| 469 | 2.10.1 | **Estudios** | 120d | 2023-05-02 A | 2023-08-29 A |  | 100% | 2023-05-02 | 2023-08-29 | 120d | 2023-05-01 | 2023-08-28 | SATT | 02-05-2023 | 29-08-2023 | 120 días | SATT | 0,00% | 0,00% | 100% |  |
| 470 | 2.10.1.1 | Topografia | 40d | 2023-05-02 A | 2023-06-10 A | 414FS+60d | 100% | 2023-05-02 | 2023-06-10 | 40d | 2023-05-01 | 2023-06-09 | SATT | 02-05-2023 | 10-06-2023 | 40 días | SATT | 100,00% | 100,00% | 100% | día 70,75 |
| 471 | 2.10.1.2 | Estudios Eléctricos | 120d | 2023-05-02 A | 2023-08-29 A | 414FS+60d | 100% | 2023-05-02 | 2023-08-29 | 120d | 2023-05-01 | 2023-08-28 | SATT | 02-05-2023 | 29-08-2023 | 120 días | SATT | 100,00% | 100,00% | 100% | día 70,75 |
| 472 | 2.10.2 | **Ingeniería Básica** | 100d | 2023-06-11 A | 2023-09-18 A |  | 100% | 2023-06-11 | 2023-09-18 | 100d | 2023-06-10 | 2023-09-17 | SATT | 11-06-2023 | 18-09-2023 | 100 días | SATT | 0,00% | 0,00% | 100% |  |
| 473 | 2.10.2.1 | Proyecto de Obras Civiles y Estructural | 80d | 2023-06-11 A | 2023-08-29 A | 470 | 100% | 2023-06-11 | 2023-08-29 | 80d | 2023-06-10 | 2023-08-28 | SATT | 11-06-2023 | 29-08-2023 | 80 días | SATT | 100,00% | 100,00% | 100% | día 115,75 |
| 474 | 2.10.2.2 | Proyecto Electromecánico | 80d | 2023-06-11 A | 2023-08-29 A | 470 | 100% | 2023-06-11 | 2023-08-29 | 80d | 2023-06-10 | 2023-08-28 | SATT | 11-06-2023 | 29-08-2023 | 80 días | SATT | 100,00% | 100,00% | 100% | día 115,75 |
| 475 | 2.10.2.3 | Especificaciones Técnicas de Conductor ACCC y Ferreteria | 80d | 2023-07-01 A | 2023-09-18 A | 471FS-60d | 100% | 2023-07-01 | 2023-09-18 | 80d | 2023-06-30 | 2023-09-17 | SATT | 01-07-2023 | 18-09-2023 | 80 días | SATT | 100,00% | 100,00% | 100% | día 138,25 |
| 476 | 2.10.3 | **Ingeniería de Detalle** | 150d | 2023-08-30 A | 2024-01-26 A |  | 100% | 2023-08-30 | 2024-01-26 | 150d | 2023-08-29 | 2024-01-25 | SATT | 30-08-2023 | 26-01-2024 | 150 días | SATT | 0,00% | 0,00% | 100% |  |
| 477 | 2.10.3.1 | Proyecto de Obras Civiles y Estructural | 150d | 2023-08-30 A | 2024-01-26 A | 473 | 100% | 2023-08-30 | 2024-01-26 | 150d | 2023-08-29 | 2024-01-25 | SATT | 30-08-2023 | 26-01-2024 | 150 días | SATT | 100,00% | 100,00% | 100% | día 205,75 |
| 478 | 2.10.3.2 | Especificaciones Técnicas de Ferretería y Herrajes AT SE Kimal | 150d | 2023-08-30 A | 2024-01-26 A | 474 | 100% | 2023-08-30 | 2024-01-26 | 150d | 2023-08-29 | 2024-01-25 | SATT | 30-08-2023 | 26-01-2024 | 150 días | SATT | 100,00% | 100,00% | 100% | día 205,75 |
| 479 | 2.10.3.3 | Proyecto Electromecánico | 150d | 2023-08-30 A | 2024-01-26 A | 474 | 100% | 2023-08-30 | 2024-01-26 | 150d | 2023-08-29 | 2024-01-25 | SATT | 30-08-2023 | 26-01-2024 | 150 días | SATT | 100,00% | 100,00% | 100% | día 205,75 |
| 480 | 2.10.3.4 | Proyecto Sistema de Control y Protección | 150d | 2023-08-30 A | 2024-01-26 A | 471 | 100% | 2023-08-30 | 2024-01-26 | 150d | 2023-08-29 | 2024-01-25 | SATT | 30-08-2023 | 26-01-2024 | 150 días | SATT | 100,00% | 100,00% | 100% | día 205,75 |

| ID | WBS | Task | Type | Duration | Start | Finish | Predecessors | Complete | Remaining | Baseline start | Baseline finish | Baseline duration | Baseline 1 start | Baseline 1 finish | Total slack | Free slack | Calendar | Propietario | Baseline Star Rev1 | Baseline Finish Rev1 | Baseline Duration Rev1 | : | % Complete Peso | % Baseline Peso | % Baseline (Tempo) | Text11 |
| --- | --- | --- | --- | --- | --- | --- | --- | --- | --- | --- | --- | --- | --- | --- | --- | --- | --- | --- | --- | --- | --- | --- | --- | --- | --- | --- |
| 481 | 2.11 | **Suministros** |  | 320d | 2023-09-19 A | 2024-08-03 |  | 98% | 6.74d | 2023-09-19 | 2024-08-03 | 320d | 2023-09-18 | 2024-08-02 | 275d |  |  | SATT | 19-09-2023 | 03-08-2024 | 320 días | SATT | 0,00% | 0,00% | 100% |  |
| 482 | 2.11.1 | **Conductor** |  | 190d | 2023-09-19 A | 2024-03-26 |  | 98% | 4d | 2023-09-19 | 2024-03-26 | 190d | 2023-09-18 | 2024-03-25 | 405d |  |  | SATT | 19-09-2023 | 26-03-2024 | 190 días | SATT | 0,00% | 0,00% | 100% |  |
| 483 | 2.11.1.1 | Proceso de compra conductor |  | 20d | 2023-09-19 A | 2023-10-08 A | 475 | 100% |  | 2023-09-19 | 2023-10-08 | 20d | 2023-09-18 | 2023-10-07 |  |  |  | SATT | 19-09-2023 | 08-10-2023 | 20 días | SATT | 100,00% | 100,00% | 100% | día 228,25 |
| 484 | 2.11.1.2 | Período de fabricación conductor |  | 150d | 2023-10-09 A | 2024-03-06 A | 483 | 100% |  | 2023-10-09 | 2024-03-06 | 150d | 2023-10-08 | 2024-03-05 |  |  |  | SATT | 09-10-2023 | 06-03-2024 | 150 días | SATT | 100,00% | 100,00% | 100% | día 250,75 |
| 485 | 2.11.1.3 | Transporte al sitio de la obra de conductor |  | 20d | 2024-03-07 A | 2024-03-26 | 484 | 80% | 4d | 2024-03-07 | 2024-03-26 | 20d | 2024-03-06 | 2024-03-25 | 405d | 0d |  | SATT | 07-03-2024 | 26-03-2024 | 20 días | SATT | 80,00% | 100,00% | 100% | día 419,5 |
| 486 | 2.11.2 | **Herrajes y Aisladores** |  | 190d | 2024-01-27 A | 2024-08-03 |  | 98% | 4d | 2024-01-27 | 2024-08-03 | 190d | 2024-01-26 | 2024-08-02 | 275d |  |  | SATT | 27-01-2024 | 03-08-2024 | 190 días | SATT | 0,00% | 0,00% | 100% |  |
| 487 | 2.11.2.1 | Proceso de compra de herrajes y aisladores |  | 20d | 2024-01-27 A | 2024-02-15 A | 478 | 100% |  | 2024-01-27 | 2024-02-15 | 20d | 2024-01-26 | 2024-02-14 |  |  |  | SATT | 27-01-2024 | 15-02-2024 | 20 días | SATT | 100,00% | 100,00% | 100% | día 374,5 |
| 488 | 2.11.2.2 | Período de fabricación herrajes y aisladores |  | 150d | 2024-02-16 A | 2024-07-14 A | 487 | 100% |  | 2024-02-16 | 2024-07-14 | 150d | 2024-02-15 | 2024-07-13 |  |  |  | SATT | 16-02-2024 | 14-07-2024 | 150 días | SATT | 100,00% | 100,00% | 100% | día 397 |
| 489 | 2.11.2.3 | Transporte al sitio de la obra herrajes y aisladores |  | 20d | 2024-07-15 A | 2024-08-03 | 488 | 80% | 4d | 2024-07-15 | 2024-08-03 | 20d | 2024-07-14 | 2024-08-02 | 275d | 0d |  | SATT | 15-07-2024 | 03-08-2024 | 20 días | SATT | 80,00% | 100,00% | 100% | día 565,75 |
| 490 | 2.12 | **Construcción** |  | 403d | 2024-11-29 | 2026-01-05 |  |  |  | 2024-11-29 | 2026-01-05 | 403d | 2024-10-02 | 2025-09-02 | 4d |  |  | SATT | 29-11-2024 | 02-09-2025 | 278 días | SATT | 0,00% | 0,00% | 73% |  |
| 491 | 2.12.1 | Entrega de terreno | milestone | 0d | 2024-11-29 | 2024-11-29 | 124, 459, 477, 478, 479, 480 |  |  | 2024-11-29 | 2024-11-29 | 0d | 2024-10-02 | 2024-10-02 | 138d | 0d |  | SATT | 29-11-2024 | 29-11-2024 | 0 días | SATT | 0,00% | 100,00% | 100% | día 719,875 |
| 492 | 2.12.2 | Movilización e Instalación de Faena |  | 20d | 2024-11-29 | 2024-12-18 | 467, 491 |  |  | 2024-11-29 | 2024-12-18 | 20d | 2024-10-03 | 2024-10-22 | 138d | 0d |  | SATT | 29-11-2024 | 18-12-2024 | 20 días | SATT | 0,00% | 100,00% | 100% | día 719,875 |
| 493 | 2.12.3 | **Obras Civiles** |  | 20d | 2025-05-29 | 2025-06-17 |  |  |  | 2025-05-29 | 2025-06-17 | 20d | 2025-04-02 | 2025-04-21 | 163d |  |  | SATT | 29-05-2025 | 17-06-2025 | 20 días | SATT | 0,00% | 0,00% | 100% |  |
| 494 | 2.12.3.1 | Puesta a Tierra |  | 20d | 2025-05-29 | 2025-06-17 | 496, 499 |  |  | 2025-05-29 | 2025-06-17 | 20d | 2025-04-02 | 2025-04-21 | 163d | 159d |  | SATT | 29-05-2025 | 17-06-2025 | 20 días | SATT | 0,00% | 100,00% | 100% | día 923,5 |
| 495 | 2.12.4 | **Cambio de Conductor** |  | 181d | 2024-12-19 | 2025-06-17 |  |  |  | 2024-12-19 | 2025-06-17 | 181d | 2024-10-23 | 2025-04-21 | 138d |  |  | SATT | 19-12-2024 | 17-06-2025 | 181 días | SATT | 0,00% | 0,00% | 100% |  |
| 496 | 2.12.4.1 | Tendido Circuito N°1 |  | 70d | 2024-12-19 | 2025-02-26 | 485, 489, 491, 492 |  |  | 2024-12-19 | 2025-02-26 | 70d | 2024-10-23 | 2024-12-31 | 138d | 0d |  | SATT | 19-12-2024 | 26-02-2025 | 70 días | SATT | 0,00% | 100,00% | 100% | día 742,375 |
| 497 | 2.12.4.2 | Pruebas previas a la puesta en servicio Circuito N°1 |  | 20d | 2025-02-27 | 2025-03-18 | 496, 433 |  |  | 2025-02-27 | 2025-03-18 | 20d | 2025-01-01 | 2025-01-20 | 139d | 0d |  | SATT | 27-02-2025 | 18-03-2025 | 20 días | SATT | 0,00% | 100,00% | 100% | día 821,125 |
| 498 | 2.12.4.3 | Circuito N°1 Listo para Energizar | milestone | 0d | 2025-03-18 | 2025-03-18 | 497, 503 |  |  | 2025-03-18 | 2025-03-18 | 0d | 2025-01-20 | 2025-01-20 | 139d | 1d |  | SATT | 18-03-2025 | 18-03-2025 | 0 días | SATT | 0,00% | 100,00% | 100% | día 843,625 |
| 499 | 2.12.4.4 | Tendido Circuito N°2 |  | 70d | 2025-03-20 | 2025-05-28 | 432, 485, 489, 491, 498 |  |  | 2025-03-20 | 2025-05-28 | 70d | 2025-01-22 | 2025-04-01 | 138d | 0d |  | SATT | 20-03-2025 | 28-05-2025 | 70 días | SATT | 0,00% | 100,00% | 100% | día 844,75 |
| 500 | 2.12.4.5 | Pruebas previas a la puesta en servicio Circuito N°2 |  | 20d | 2025-05-29 | 2025-06-17 | 499 |  |  | 2025-05-29 | 2025-06-17 | 20d | 2025-04-02 | 2025-04-21 | 138d | 0d |  | SATT | 29-05-2025 | 17-06-2025 | 20 días | SATT | 0,00% | 100,00% | 100% | día 923,5 |
| 501 | 2.12.4.6 | Circuito N°2 Listo para Energizar | milestone | 0d | 2025-06-17 | 2025-06-17 | 500, 504 |  |  | 2025-06-17 | 2025-06-17 | 0d | 2025-04-21 | 2025-04-21 | 205d | 169d |  | SATT | 17-06-2025 | 17-06-2025 | 0 días | SATT | 0,00% | 100,00% | 100% | día 946 |
| 502 | 2.12.5 | **Conexionado en SE Kimal** |  | 111d | 2025-01-18 | 2025-05-08 |  |  |  | 2025-01-18 | 2025-05-08 | 111d | 2024-11-22 | 2025-03-12 | 179d |  |  | SATT | 18-01-2025 | 08-05-2025 | 111 días | SATT | 0,00% | 0,00% | 100% |  |
| 503 | 2.12.5.1 | Conexionado entre equipos y derivación de conexión a línea Circuito N°1 |  | 20d | 2025-01-18 | 2025-02-06 | 491, 496SS+30d |  |  | 2025-01-18 | 2025-02-06 | 20d | 2024-11-22 | 2024-12-11 | 179d | 40d |  | SATT | 18-01-2025 | 06-02-2025 | 20 días | SATT | 0,00% | 100,00% | 100% | día 776,125 |
| 504 | 2.12.5.2 | Conexionado entre equipos y derivación de conexión a línea Circuito N°2 |  | 20d | 2025-04-19 | 2025-05-08 | 491, 499SS+30d |  |  | 2025-04-19 | 2025-05-08 | 20d | 2025-02-21 | 2025-03-12 | 245d | 40d |  | SATT | 19-04-2025 | 08-05-2025 | 20 días | SATT | 0,00% | 100,00% | 100% | día 878,5 |
| 505 | 2.12.6 | Desmovilización |  | 14d | 2025-12-17 | 2026-01-05 | 600FS+2d, 394FS+2d, 616FS-30d |  |  | 2025-12-17 | 2026-01-05 | 14d | 2025-07-23 | 2025-09-02 | 4d | 0d | ENKI - Días habiles | SATT | 14-08-2025 | 02-09-2025 | 14 días | SATT | 0,00% | 0,00% | 0% | día 822,25 |

| ID | WBS | Task | Type | Duration | Start | Finish | Predecessors | Complete | Remaining | Baseline start | Baseline finish | Baseline duration | Baseline 1 start | Baseline 1 finish | Total slack | Free slack | Calendar | Propietario | Baseline Star Rev1 | Baseline Finish Rev1 | Baseline Duration Rev1 | : | % Complete Peso | % Baseline Peso | % Baseline (Tempo) | Text11 |
| --- | --- | --- | --- | --- | --- | --- | --- | --- | --- | --- | --- | --- | --- | --- | --- | --- | --- | --- | --- | --- | --- | --- | --- | --- | --- | --- |
| 506 | 2.13 | **PROCESO DE INTERCONEXIÓN** |  | 367d | 2024-08-12 A | 2026-01-06 |  | 22% | 284.58d | 2024-08-12 | 2026-01-06 | 367d | 2024-08-12 | 2025-09-02 | 3d |  | ENKI - Días habiles | SATT | 12-08-2024 | 02-09-2025 | 277 días | SATT | 0,00% | 0,00% | 79% |  |
| 507 | 2.13.1 | **CEM- Carta de Escenarios Mínimos** |  | 52d | 2024-08-12 A | 2024-10-22 A |  | 100% |  | 2024-08-12 | 2024-10-22 | 52d | 2024-08-12 | 2024-10-22 |  |  | ENKI - Días habiles | SATT | 12-08-2024 | 22-10-2024 | 52 días | SATT | 0,00% | 0,00% | 100% |  |
| 508 | 2.13.1.1 | Solicitud y Anexos (carta conductora SIPC) |  | 1d | 2024-08-12 A | 2024-08-12 A | 428FS-277d | 100% |  | 2024-08-12 | 2024-08-12 | 1d | 2024-08-12 | 2024-08-12 |  |  | ENKI - Días habiles | SATT | 12-08-2024 | 12-08-2024 | 1 día | SATT | 100,00% | 100,00% | 100% | día 426,25 |
| 509 | 2.13.1.2 | Observaciones del CEN a la SIPC |  | 10d | 2024-08-13 A | 2024-08-26 A | 508 | 100% |  | 2024-08-13 | 2024-08-26 | 10d | 2024-08-13 | 2024-08-26 |  |  | ENKI - Días habiles | SATT | 13-08-2024 | 26-08-2024 | 10 días | SATT | 100,00% | 100,00% | 100% | día 427,375 |
| 510 | 2.13.1.3 | Notificación del CEN a Empresas Involucradas |  | 3d | 2024-08-27 A | 2024-08-29 A | 509 | 100% |  | 2024-08-27 | 2024-08-29 | 3d | 2024-08-27 | 2024-08-29 |  |  | ENKI - Días habiles | SATT | 27-08-2024 | 29-08-2024 | 3 días | SATT | 100,00% | 100,00% | 100% | día 438,625 |
| 511 | 2.13.1.4 | Propuestas de Estudios para CEM por Empresas involucradas |  | 5d | 2024-08-30 A | 2024-09-05 A | 510 | 100% |  | 2024-08-30 | 2024-09-05 | 5d | 2024-08-30 | 2024-09-05 |  |  | ENKI - Días habiles | SATT | 30-08-2024 | 05-09-2024 | 5 días | SATT | 100,00% | 100,00% | 100% | día 442 |
| 512 | 2.13.1.5 | Carta de Escenarios Mínimos Preliminar(CEM P) |  | 18d | 2024-09-06 A | 2024-10-01 A | 511 | 100% |  | 2024-09-06 | 2024-10-01 | 18d | 2024-09-06 | 2024-10-01 |  |  | ENKI - Días habiles | SATT | 06-09-2024 | 01-10-2024 | 18 días | SATT | 100,00% | 100,00% | 100% | día 447,625 |
| 513 | 2.13.1.6 | Observaciones ES a la CEM |  | 5d | 2024-10-02 A | 2024-10-08 A | 512 | 100% |  | 2024-10-02 | 2024-10-08 | 5d | 2024-10-02 | 2024-10-08 |  |  | ENKI - Días habiles | SATT | 02-10-2024 | 08-10-2024 | 5 días | SATT | 100,00% | 100,00% | 100% | día 467,875 |
| 514 | 2.13.1.7 | Carta de Escenarios Mínimos Definitiva (CEM D) |  | 10d | 2024-10-09 A | 2024-10-22 A | 513 | 100% |  | 2024-10-09 | 2024-10-22 | 10d | 2024-10-09 | 2024-10-22 |  |  | ENKI - Días habiles | SATT | 09-10-2024 | 22-10-2024 | 10 días | SATT | 100,00% | 100,00% | 100% | día 473,5 |
| 515 | 2.13.2 | **DUF-Diagrama Unilineal Funcional** |  | 20d | 2024-08-19 A | 2024-09-13 A |  | 100% |  | 2024-08-19 | 2024-09-13 | 20d | 2024-08-19 | 2024-09-13 |  |  | ENKI - Días habiles | SATT | 19-08-2024 | 13-09-2024 | 20 días | SATT | 0,00% | 0,00% | 100% |  |
| 516 | 2.13.2.1 | DUF para Revisión del CEN (junto con la SIPC) |  | 1d | 2024-08-19 A | 2024-08-19 A | 39, 450, 508SS | 100% |  | 2024-08-19 | 2024-08-19 | 1d | 2024-08-19 | 2024-08-19 |  |  | ENKI - Días habiles | SATT | 19-08-2024 | 19-08-2024 | 1 día | SATT | 100,00% | 100,00% | 100% | día 431,875 |
| 517 | 2.13.2.2 | Revisión del CEN del DUF |  | 7d | 2024-08-20 A | 2024-08-28 A | 516 | 100% |  | 2024-08-20 | 2024-08-28 | 7d | 2024-08-20 | 2024-08-28 |  |  | ENKI - Días habiles | SATT | 20-08-2024 | 28-08-2024 | 7 días | SATT | 100,00% | 100,00% | 100% | día 433 |
| 518 | 2.13.2.3 | Respuesta ES a Observaciones DUF |  | 5d | 2024-08-29 A | 2024-09-04 A | 517 | 100% |  | 2024-08-29 | 2024-09-04 | 5d | 2024-08-29 | 2024-09-04 |  |  | ENKI - Días habiles | SATT | 29-08-2024 | 04-09-2024 | 5 días | SATT | 100,00% | 100,00% | 100% | día 440,875 |
| 519 | 2.13.2.4 | Revisión DUF - 1era Iteración |  | 7d | 2024-09-05 A | 2024-09-13 A | 518 | 100% |  | 2024-09-05 | 2024-09-13 | 7d | 2024-09-05 | 2024-09-13 |  |  | ENKI - Días habiles | SATT | 05-09-2024 | 13-09-2024 | 7 días | SATT | 100,00% | 100,00% | 100% | día 446,5 |
| 520 | 2.13.2.5 | Aprobación DUF | milestone | 0d | 2024-09-13 A | 2024-09-13 A | 519 | 100% |  | 2024-09-13 | 2024-09-13 | 0d | 2024-09-13 | 2024-09-13 |  |  | ENKI - Días habiles | SATT | 13-09-2024 | 13-09-2024 | 0 días | SATT | 100,00% | 100,00% | 100% | día 454,375 |
| 521 | 2.13.3 | **RID- Revisión de Ingeniería de Diseño** |  | 37d | 2024-10-23 A | 2024-12-12 |  | 65% | 13.05d | 2024-10-23 | 2024-12-12 | 37d | 2024-10-23 | 2024-12-12 | 281d |  | ENKI - Días habiles | SATT | 23-10-2024 | 12-12-2024 | 37 días | SATT | 0,00% | 0,00% | 100% |  |
| 522 | 2.13.3.1 | Envío de Informe de RID a Empresa Solicitante (ES) |  | 1d | 2024-10-23 A | 2024-10-23 A | 39, 450, 514 | 100% |  | 2024-10-23 | 2024-10-23 | 1d | 2024-10-23 | 2024-10-23 |  |  | ENKI - Días habiles | SATT | 23-10-2024 | 23-10-2024 | 1 día | SATT | 100,00% | 100,00% | 100% | día 484,75 |
| 523 | 2.13.3.2 | Respuesta de ES a RID |  | 1d | 2024-10-24 A | 2024-10-24 A | 522 | 100% |  | 2024-10-24 | 2024-10-24 | 1d | 2024-10-24 | 2024-10-24 |  |  | ENKI - Días habiles | SATT | 24-10-2024 | 24-10-2024 | 1 día | SATT | 100,00% | 100,00% | 100% | día 485,875 |
| 524 | 2.13.3.3 | Revisión de Ingeniería de Diseño |  | 15d | 2024-10-25 A | 2024-11-14 A | 523 | 100% |  | 2024-10-25 | 2024-11-14 | 15d | 2024-10-25 | 2024-11-14 |  |  | ENKI - Días habiles | SATT | 25-10-2024 | 14-11-2024 | 15 días | SATT | 100,00% | 100,00% | 100% | día 487 |
| 525 | 2.13.3.4 | Atención de Observaciones |  | 5d | 2024-11-15 A | 2024-11-21 A | 524 | 100% |  | 2024-11-15 | 2024-11-21 | 5d | 2024-11-15 | 2024-11-21 |  |  | ENKI - Días habiles | SATT | 15-11-2024 | 21-11-2024 | 5 días | SATT | 100,00% | 100,00% | 100% | día 503,875 |
| 526 | 2.13.3.5 | Revisión de Ingeniería de Diseño 1Era Iteración |  | 15d | 2024-11-22 A | 2024-12-12 | 525 | 13% | 13.05d | 2024-11-22 | 2024-12-12 | 15d | 2024-11-22 | 2024-12-12 | 281d | 0d | ENKI - Días habiles | SATT | 22-11-2024 | 12-12-2024 | 15 días | SATT | 13,00% | 100,00% | 100% | día 509,5 |
| 527 | 2.13.3.6 | Aprobación de Ingeniería de diseño 1Era Iteración | milestone | 0d | 2024-12-12 | 2024-12-12 | 526 |  |  | 2024-12-12 | 2024-12-12 | 0d | 2024-12-12 | 2024-12-12 | 281d |  | ENKI - Días habiles | SATT | 12-12-2024 | 12-12-2024 | 0 días | SATT | 0,00% | 100,00% | 100% | día 526,375 |
| 528 | 2.13.4 | **IT- Información Técnica Estudios** |  | 56d | 2024-10-23 A | 2025-01-08 |  | 43% | 32d | 2024-10-23 | 2025-01-08 | 56d | 2024-10-23 | 2025-01-08 | 139d |  | ENKI - Días habiles | SATT | 23-10-2024 | 08-01-2025 | 56 días | SATT | 0,00% | 0,00% | 100% |  |
| 529 | 2.13.4.1 | Preparación Infotécnica para Estudios de Interconexión |  | 15d | 2024-10-23 A | 2024-11-12 A | 89, 95, 101, 483, 514 | 100% |  | 2024-10-23 | 2024-11-12 | 15d | 2024-10-23 | 2024-11-12 |  |  | ENKI - Días habiles | SATT | 23-10-2024 | 12-11-2024 | 15 días | SATT | 100,00% | 100,00% | 100% | día 484,75 |
| 530 | 2.13.4.2 | Entrega de Información Técnica para Estudios de Interconexión |  | 1d | 2024-11-13 A | 2024-11-13 A | 529 | 100% |  | 2024-11-13 | 2024-11-13 | 1d | 2024-11-13 | 2024-11-13 |  |  | ENKI - Días habiles | SATT | 13-11-2024 | 13-11-2024 | 1 día | SATT | 100,00% | 100,00% | 100% | día 501,625 |
| 531 | 2.13.4.3 | Revisión de Completitud por el CEN |  | 5d | 2024-11-14 A | 2024-11-20 A | 530 | 100% |  | 2024-11-14 | 2024-11-20 | 5d | 2024-11-14 | 2024-11-20 |  |  | ENKI - Días habiles | SATT | 14-11-2024 | 20-11-2024 | 5 días | SATT | 100,00% | 100,00% | 100% | día 502,75 |
| 532 | 2.13.4.4 | Revisión de Información Técnica EI - 1era Iteración |  | 15d | 2024-11-21 A | 2024-12-11 | 531 | 20% | 12d | 2024-11-21 | 2024-12-11 | 15d | 2024-11-21 | 2024-12-11 | 139d | 0d | ENKI - Días habiles | SATT | 21-11-2024 | 11-12-2024 | 15 días | SATT | 20,00% | 100,00% | 100% | día 508,375 |
| 533 | 2.13.4.5 | Respuesta a Comentarios de Revisión IT - 1era Iteración |  | 5d | 2024-12-12 | 2024-12-18 | 532 |  |  | 2024-12-12 | 2024-12-18 | 5d | 2024-12-12 | 2024-12-18 | 139d | 0d | ENKI - Días habiles | SATT | 12-12-2024 | 18-12-2024 | 5 días | SATT | 0,00% | 100,00% | 100% | día 525,25 |
| 534 | 2.13.4.6 | Revisión de Información Técnica EI - 2da Iteración |  | 15d | 2024-12-19 | 2025-01-08 | 533 |  |  | 2024-12-19 | 2025-01-08 | 15d | 2024-12-19 | 2025-01-08 | 139d | 0d | ENKI - Días habiles | SATT | 19-12-2024 | 08-01-2025 | 15 días | SATT | 0,00% | 100,00% | 100% | día 530,875 |
| 535 | 2.13.4.7 | Aprobación de IT para Estudios | milestone | 0d | 2025-01-08 | 2025-01-08 | 534 |  |  | 2025-01-08 | 2025-01-08 | 0d | 2025-01-08 | 2025-01-08 | 139d | 0d | ENKI - Días habiles | SATT | 08-01-2025 | 08-01-2025 | 0 días | SATT | 0,00% | 100,00% | 100% | día 547,75 |

| ID | WBS | Task | Duration | Start | Finish | Predecessors | Complete | Remaining | Baseline start | Baseline finish | Baseline duration | Baseline 1 start | Baseline 1 finish | Total slack | Free slack | Calendar | Propietario | Baseline Star Rev1 | Baseline Finish Rev1 | Baseline Duration Rev1 | : | % Complete Peso | % Baseline Peso | % Baseline (Tempo) | Text11 |
| --- | --- | --- | --- | --- | --- | --- | --- | --- | --- | --- | --- | --- | --- | --- | --- | --- | --- | --- | --- | --- | --- | --- | --- | --- | --- |
| 536 | 2.13.5 | **EI-Estudios de Interconexión (Definidos por CEM)** | 306d | 2024-10-23 A | 2025-12-24 |  | 16% | 257.36d | 2024-10-23 | 2025-12-24 | 306d | 2024-10-23 | 2025-06-12 | 12d |  | ENKI - Días habiles | SATT | 23-10-2024 | 21-07-2025 | 194 días | SATT | 0,00% | 0,00% | 77% |  |
| 537 | 2.13.5.1 | Elaboración de Estudios de Interconexión | 40d | 2024-10-23 A | 2024-12-17 | 39FS-15d, 450FS-15d, 514 | 60% | 16d | 2024-10-23 | 2024-12-17 | 40d | 2024-10-23 | 2024-12-17 | 155d | 16d | ENKI - Días habiles | SATT | 23-10-2024 | 17-12-2024 | 40 días | SATT | 60,00% | 100,00% | 100% | día 484,75 |
| 538 | 2.13.5.2 | Entrega y Revisión CEN de EI - 1era Iteración | 30d | 2025-01-09 | 2025-02-19 | 535, 537 |  |  | 2025-01-09 | 2025-02-19 | 30d | 2025-01-09 | 2025-02-19 | 139d | 0d | ENKI - Días habiles | SATT | 09-01-2025 | 19-02-2025 | 30 días | SATT | 0,00% | 100,00% | 100% | día 547,75 |
| 539 | 2.13.5.3 | Envío de Levantamiento de Observaciones de Estudios de Interconexión N°1 | 5d | 2025-02-20 | 2025-02-26 | 538 |  |  | 2025-02-20 | 2025-02-26 | 5d | 2025-02-20 | 2025-02-26 | 139d | 0d | ENKI - Días habiles | SATT | 20-02-2025 | 26-02-2025 | 5 días | SATT | 0,00% | 100,00% | 100% | día 581,5 |
| 540 | 2.13.5.4 | Entrega y Revisión CEN de EI - 2da Iteración | 20d | 2025-02-27 | 2025-03-26 | 539 |  |  | 2025-02-27 | 2025-03-26 | 20d | 2025-02-27 | 2025-03-26 | 139d | 0d | ENKI - Días habiles | SATT | 27-02-2025 | 26-03-2025 | 20 días | SATT | 0,00% | 100,00% | 100% | día 587,125 |
| 541 | 2.13.5.5 | Envío y Levantamiento de Observaciones de EI - 2da Iteración | 5d | 2025-03-27 | 2025-04-02 | 540 |  |  | 2025-03-27 | 2025-04-02 | 5d | 2025-03-27 | 2025-04-02 | 139d | 0d | ENKI - Días habiles | SATT | 27-03-2025 | 02-04-2025 | 5 días | SATT | 0,00% | 100,00% | 100% | día 609,625 |
| 542 | 2.13.5.6 | Aprobación por parte del CEN de Estudios de Interconexión | 20d | 2025-04-03 | 2025-04-30 | 541 |  |  | 2025-04-03 | 2025-04-30 | 20d | 2025-04-03 | 2025-04-30 | 139d | 0d | ENKI - Días habiles | SATT | 03-04-2025 | 30-04-2025 | 20 días | SATT | 0,00% | 100,00% | 100% | día 615,25 |
| 543 | 2.13.5.7 | **Entrega de Print Outs (PO)** | 31d | 2025-11-12 | 2025-12-24 |  |  |  | 2025-11-12 | 2025-12-24 | 31d | 2025-05-01 | 2025-06-12 | 12d |  | ENKI - Días habiles | SATT | 09-06-2025 | 21-07-2025 | 31 días | SATT | 0,00% | 0,00% | 0% |  |
| 544 | 2.13.5.7.1 | Revision ECAP y elaboracion de los PO | 15d | 2025-11-12 | 2025-12-02 | 179, 234, 542, 146, 202, 257 |  |  | 2025-11-12 | 2025-12-02 | 15d | 2025-05-01 | 2025-05-21 | 12d | 0d | ENKI - Días habiles | SATT | 09-06-2025 | 27-06-2025 | 15 días | SATT | 0,00% | 0,00% | 0% | día 794,125 |
| 545 | 2.13.5.7.2 | Entrega y Revisión CEN de PO - 1era Iteración | 15d | 2025-12-03 | 2025-12-23 | 544 |  |  | 2025-12-03 | 2025-12-23 | 15d | 2025-05-22 | 2025-06-11 | 12d | 0d | ENKI - Días habiles | SATT | 30-06-2025 | 18-07-2025 | 15 días | SATT | 0,00% | 0,00% | 0% | día 811 |
| 546 | 2.13.5.7.3 | Aprobación de Print Out | 1d | 2025-12-24 | 2025-12-24 | 545 |  |  | 2025-12-24 | 2025-12-24 | 1d | 2025-06-12 | 2025-06-12 | 12d |  | ENKI - Días habiles | SATT | 21-07-2025 | 21-07-2025 | 1 día | SATT | 0,00% | 0,00% | 0% | día 827,875 |
| 547 | 2.13.6 | **Sistema de Información es Tiempo Real (SITR)** | 64d | 2025-01-09 | 2025-04-08 |  |  |  | 2025-01-09 | 2025-04-08 | 64d | 2025-01-09 | 2025-04-08 | 198d |  | ENKI - Días habiles | SATT | 09-01-2025 | 08-04-2025 | 64 días | SATT | 0,00% | 0,00% | 100% |  |
| 548 | 2.13.6.1 | Solicitud al CEN del Listado SITR | 1d | 2025-01-10 | 2025-01-10 | 554 |  |  | 2025-01-10 | 2025-01-10 | 1d | 2025-01-10 | 2025-01-10 | 198d | 0d | ENKI - Días habiles | SATT | 10-01-2025 | 10-01-2025 | 1 día | SATT | 0,00% | 100,00% | 100% | día 548,875 |
| 549 | 2.13.6.2 | Definición del CEN del Listado SITR | 15d | 2025-01-13 | 2025-01-31 | 548 |  |  | 2025-01-13 | 2025-01-31 | 15d | 2025-01-13 | 2025-01-31 | 198d | 0d | ENKI - Días habiles | SATT | 13-01-2025 | 31-01-2025 | 15 días | SATT | 0,00% | 100,00% | 100% | día 550 |
| 550 | 2.13.6.3 | Observaciones SE sobre el Listado SITR | 3d | 2025-02-03 | 2025-02-05 | 549 |  |  | 2025-02-03 | 2025-02-05 | 3d | 2025-02-03 | 2025-02-05 | 198d | 0d | ENKI - Días habiles | SATT | 03-02-2025 | 05-02-2025 | 3 días | SATT | 0,00% | 100,00% | 100% | día 566,875 |
| 551 | 2.13.6.4 | Aprobación del Listado SITR | 10d | 2025-02-06 | 2025-02-19 | 550 |  |  | 2025-02-06 | 2025-02-19 | 10d | 2025-02-06 | 2025-02-19 | 198d | 0d | ENKI - Días habiles | SATT | 06-02-2025 | 19-02-2025 | 10 días | SATT | 0,00% | 100,00% | 100% | día 570,25 |
| 552 | 2.13.6.5 | Emision CEN del Listado SITR Definitivo | 1d | 2025-02-20 | 2025-02-20 | 551 |  |  | 2025-02-20 | 2025-02-20 | 1d | 2025-02-20 | 2025-02-20 | 198d | 0d | ENKI - Días habiles | SATT | 20-02-2025 | 20-02-2025 | 1 día | SATT | 0,00% | 100,00% | 100% | día 581,5 |
| 553 | 2.13.6.6 | **Enlace** | 6d | 2025-01-09 | 2025-01-16 |  |  |  | 2025-01-09 | 2025-01-16 | 6d | 2025-01-09 | 2025-01-16 | 198d |  | ENKI - Días habiles | SATT | 09-01-2025 | 16-01-2025 | 6 días | SATT | 0,00% | 0,00% | 100% |  |
| 554 | 2.13.6.6.1 | Definición del Enlace | 1d | 2025-01-09 | 2025-01-09 | 538SS |  |  | 2025-01-09 | 2025-01-09 | 1d | 2025-01-09 | 2025-01-09 | 198d | 0d | ENKI - Días habiles | SATT | 09-01-2025 | 09-01-2025 | 1 día | SATT | 0,00% | 100,00% | 100% | día 547,75 |
| 555 | 2.13.6.6.2 | Prueba de Enlace | 5d | 2025-01-10 | 2025-01-16 | 554 |  |  | 2025-01-10 | 2025-01-16 | 5d | 2025-01-10 | 2025-01-16 | 256d |  | ENKI - Días habiles | SATT | 10-01-2025 | 16-01-2025 | 5 días | SATT | 0,00% | 100,00% | 100% | día 548,875 |
| 556 | 2.13.6.7 | **DIR/TAG** | 6d | 2025-02-21 | 2025-02-28 |  |  |  | 2025-02-21 | 2025-02-28 | 6d | 2025-02-21 | 2025-02-28 | 198d |  | ENKI - Días habiles | SATT | 21-02-2025 | 28-02-2025 | 6 días | SATT | 0,00% | 0,00% | 100% |  |
| 557 | 2.13.6.7.1 | Solicitud de Tag ICCP o Direcciones IEC104/DNP | 1d | 2025-02-21 | 2025-02-21 | 552 |  |  | 2025-02-21 | 2025-02-21 | 1d | 2025-02-21 | 2025-02-21 | 198d | 0d | ENKI - Días habiles | SATT | 21-02-2025 | 21-02-2025 | 1 día | SATT | 0,00% | 100,00% | 100% | día 582,625 |
| 558 | 2.13.6.7.2 | Emisión o revisión de Tag ICCP o Direcciones IEC104/DNP | 5d | 2025-02-24 | 2025-02-28 | 557 |  |  | 2025-02-24 | 2025-02-28 | 5d | 2025-02-24 | 2025-02-28 | 198d | 0d | ENKI - Días habiles | SATT | 24-02-2025 | 28-02-2025 | 5 días | SATT | 0,00% | 100,00% | 100% | día 583,75 |
| 559 | 2.13.6.8 | **Pruebas** | 7d | 2025-03-03 | 2025-03-11 |  |  |  | 2025-03-03 | 2025-03-11 | 7d | 2025-03-03 | 2025-03-11 | 198d |  | ENKI - Días habiles | SATT | 03-03-2025 | 11-03-2025 | 7 días | SATT | 0,00% | 0,00% | 100% |  |
| 560 | 2.13.6.8.1 | Solicitud de Fecha de Pruebas SITR | 1d | 2025-03-03 | 2025-03-03 | 552, 558 |  |  | 2025-03-03 | 2025-03-03 | 1d | 2025-03-03 | 2025-03-03 | 198d | 0d | ENKI - Días habiles | SATT | 03-03-2025 | 03-03-2025 | 1 día | SATT | 0,00% | 100,00% | 100% | día 589,375 |
| 561 | 2.13.6.8.2 | Confirmación de Fecha de Pruebas SITR | 3d | 2025-03-04 | 2025-03-06 | 560 |  |  | 2025-03-04 | 2025-03-06 | 3d | 2025-03-04 | 2025-03-06 | 198d | 0d | ENKI - Días habiles | SATT | 04-03-2025 | 06-03-2025 | 3 días | SATT | 0,00% | 100,00% | 100% | día 590,5 |
| 562 | 2.13.6.8.3 | Resultados de Pruebas Internas SITR | 3d | 2025-03-07 | 2025-03-11 | 561 |  |  | 2025-03-07 | 2025-03-11 | 3d | 2025-03-07 | 2025-03-11 | 198d | 0d | ENKI - Días habiles | SATT | 07-03-2025 | 11-03-2025 | 3 días | SATT | 0,00% | 100,00% | 100% | día 593,875 |

| ID | WBS | Task | Duration | Start | Finish | Predecessors | Baseline start | Baseline finish | Baseline duration | Baseline 1 start | Baseline 1 finish | Total slack | Free slack | Calendar | Propietario | Baseline Star Rev1 | Baseline Finish Rev1 | Baseline Duration Rev1 | : | % Complete Peso | % Baseline Peso | % Baseline (Tempo) | Text11 |
| --- | --- | --- | --- | --- | --- | --- | --- | --- | --- | --- | --- | --- | --- | --- | --- | --- | --- | --- | --- | --- | --- | --- | --- |
| 563 | 2.13.6.9 | **Pruebas SITR** | 20d | 2025-03-12 | 2025-04-08 |  | 2025-03-12 | 2025-04-08 | 20d | 2025-03-12 | 2025-04-08 | 198d |  | ENKI - Días habiles | SATT | 12-03-2025 | 08-04-2025 | 20 días | SATT | 0,00% | 0,00% | 100% |  |
| 564 | 2.13.6.9.1 | Resultados de Pruebas SITR | 20d | 2025-03-12 | 2025-04-08 | 562 | 2025-03-12 | 2025-04-08 | 20d | 2025-03-12 | 2025-04-08 | 198d |  | ENKI - Días habiles | SATT | 12-03-2025 | 08-04-2025 | 20 días | SATT | 0,00% | 100,00% | 100% | día 597,25 |
| 565 | 2.13.7 | **Esquema de Medida de Energía (EME)** | 74d | 2025-02-20 | 2025-06-03 |  | 2025-02-20 | 2025-06-03 | 74d | 2025-02-20 | 2025-06-03 | 158d |  | ENKI - Días habiles | SATT | 20-02-2025 | 03-06-2025 | 74 días | SATT | 0,00% | 0,00% | 100% |  |
| 566 | 2.13.7.1 | Solicitud al CEN de Requisitos EME | 1d | 2025-02-20 | 2025-02-20 | 538 | 2025-02-20 | 2025-02-20 | 1d | 2025-02-20 | 2025-02-20 | 158d | 0d | ENKI - Días habiles | SATT | 20-02-2025 | 20-02-2025 | 1 día | SATT | 0,00% | 100,00% | 100% | día 581,5 |
| 567 | 2.13.7.2 | Envio de informe EME a Empresa Solicitante (ES) | 5d | 2025-02-21 | 2025-02-27 | 566 | 2025-02-21 | 2025-02-27 | 5d | 2025-02-21 | 2025-02-27 | 158d | 0d | ENKI - Días habiles | SATT | 21-02-2025 | 27-02-2025 | 5 días | SATT | 0,00% | 100,00% | 100% | día 582,625 |
| 568 | 2.13.7.3 | Respuesta de ES a EME | 15d | 2025-02-28 | 2025-03-20 | 567 | 2025-02-28 | 2025-03-20 | 15d | 2025-02-28 | 2025-03-20 | 158d | 0d | ENKI - Días habiles | SATT | 28-02-2025 | 20-03-2025 | 15 días | SATT | 0,00% | 100,00% | 100% | día 588,25 |
| 569 | 2.13.7.4 | Revision CEM de antecedentes EME - 1era Iteración | 15d | 2025-03-21 | 2025-04-10 | 568 | 2025-03-21 | 2025-04-10 | 15d | 2025-03-21 | 2025-04-10 | 158d | 0d | ENKI - Días habiles | SATT | 21-03-2025 | 10-04-2025 | 15 días | SATT | 0,00% | 100,00% | 100% | día 605,125 |
| 570 | 2.13.7.5 | Definición y Pruebas de Enlace | 5d | 2025-04-11 | 2025-04-17 | 569 | 2025-04-11 | 2025-04-17 | 5d | 2025-04-11 | 2025-04-17 | 158d | 0d | ENKI - Días habiles | SATT | 11-04-2025 | 17-04-2025 | 5 días | SATT | 0,00% | 100,00% | 100% | día 622 |
| 571 | 2.13.7.6 | Solicitud de Fecha de Pruebas PRMTE | 1d | 2025-04-18 | 2025-04-18 | 570 | 2025-04-18 | 2025-04-18 | 1d | 2025-04-18 | 2025-04-18 | 158d | 0d | ENKI - Días habiles | SATT | 18-04-2025 | 18-04-2025 | 1 día | SATT | 0,00% | 100,00% | 100% | día 627,625 |
| 572 | 2.13.7.7 | Confirmación de Fecha de Pruebas PRMTE | 5d | 2025-04-21 | 2025-04-25 | 571 | 2025-04-21 | 2025-04-25 | 5d | 2025-04-21 | 2025-04-25 | 158d | 0d | ENKI - Días habiles | SATT | 21-04-2025 | 25-04-2025 | 5 días | SATT | 0,00% | 100,00% | 100% | día 628,75 |
| 573 | 2.13.7.8 | Pruebas PRMTE | 1d | 2025-04-28 | 2025-04-28 | 572 | 2025-04-28 | 2025-04-28 | 1d | 2025-04-28 | 2025-04-28 | 158d | 0d | ENKI - Días habiles | SATT | 28-04-2025 | 28-04-2025 | 1 día | SATT | 0,00% | 100,00% | 100% | día 634,375 |
| 574 | 2.13.7.9 | Resultados PRMTE | 10d | 2025-04-29 | 2025-05-12 | 573 | 2025-04-29 | 2025-05-12 | 10d | 2025-04-29 | 2025-05-12 | 158d | 0d | ENKI - Días habiles | SATT | 29-04-2025 | 12-05-2025 | 10 días | SATT | 0,00% | 100,00% | 100% | día 635,5 |
| 575 | 2.13.7.10 | Complemento ES de antecedentes EME | 1d | 2025-05-13 | 2025-05-13 | 574 | 2025-05-13 | 2025-05-13 | 1d | 2025-05-13 | 2025-05-13 | 158d | 0d | ENKI - Días habiles | SATT | 13-05-2025 | 13-05-2025 | 1 día | SATT | 0,00% | 100,00% | 100% | día 646,75 |
| 576 | 2.13.7.11 | Aprobación de EME - 2da Iteración | 15d | 2025-05-14 | 2025-06-03 | 575 | 2025-05-14 | 2025-06-03 | 15d | 2025-05-14 | 2025-06-03 | 158d |  | ENKI - Días habiles | SATT | 14-05-2025 | 03-06-2025 | 15 días | SATT | 0,00% | 100,00% | 100% | día 647,875 |
| 577 | 2.13.8 | **PES-Requisitos para PES** | 162d | 2025-05-01 | 2025-12-12 |  | 2025-05-01 | 2025-12-12 | 162d | 2025-03-18 | 2025-07-18 | 20d |  | ENKI - Días habiles | SATT | 01-05-2025 | 11-08-2025 | 73 días | SATT | 0,00% | 0,00% | 62% |  |
| 578 | 2.13.8.1 | **Guía de maniobras** | 41d | 2025-05-01 | 2025-06-26 |  | 2025-05-01 | 2025-06-26 | 41d | 2025-05-01 | 2025-06-26 | 139d |  | ENKI - Días habiles | SATT | 01-05-2025 | 26-06-2025 | 41 días | SATT | 0,00% | 0,00% | 100% |  |
| 579 | 2.13.8.1.1 | Envío de Guía de Maniobras | 1d | 2025-05-01 | 2025-05-01 | 542 | 2025-05-01 | 2025-05-01 | 1d | 2025-05-01 | 2025-05-01 | 139d |  | ENKI - Días habiles | SATT | 01-05-2025 | 01-05-2025 | 1 día | SATT | 0,00% | 100,00% | 100% | día 637,75 |
| 580 | 2.13.8.1.2 | Revisión de Guía de Maniobras - 1era Iteración | 15d | 2025-05-01 | 2025-05-21 | 542 | 2025-05-01 | 2025-05-21 | 15d | 2025-05-01 | 2025-05-21 | 140d | 0d | ENKI - Días habiles | SATT | 01-05-2025 | 21-05-2025 | 15 días | SATT | 0,00% | 100,00% | 100% | día 637,75 |
| 581 | 2.13.8.1.3 | Envío de Respuesta a Observaciones a Guia de Maniobras | 5d | 2025-05-22 | 2025-05-28 | 580 | 2025-05-22 | 2025-05-28 | 5d | 2025-05-22 | 2025-05-28 | 140d | 0d | ENKI - Días habiles | SATT | 22-05-2025 | 28-05-2025 | 5 días | SATT | 0,00% | 100,00% | 100% | día 654,625 |
| 582 | 2.13.8.1.4 | Revisión de Guía de Maniobras - 2da Iteración | 20d | 2025-05-29 | 2025-06-25 | 581 | 2025-05-29 | 2025-06-25 | 20d | 2025-05-29 | 2025-06-25 | 140d | 0d | ENKI - Días habiles | SATT | 29-05-2025 | 25-06-2025 | 20 días | SATT | 0,00% | 100,00% | 100% | día 660,25 |
| 583 | 2.13.8.1.5 | Aprobación de Guía de Maniobras | 1d | 2025-06-26 | 2025-06-26 | 582 | 2025-06-26 | 2025-06-26 | 1d | 2025-06-26 | 2025-06-26 | 140d | 114d | ENKI - Días habiles | SATT | 26-06-2025 | 26-06-2025 | 1 día | SATT | 0,00% | 100,00% | 100% | día 682,75 |
| 584 | 2.13.8.2 | **Programa de Pruebas (PROG P)** | 37d | 2025-05-01 | 2025-06-20 |  | 2025-05-01 | 2025-06-20 | 37d | 2025-05-01 | 2025-06-20 | 139d |  | ENKI - Días habiles | SATT | 01-05-2025 | 20-06-2025 | 37 días | SATT | 0,00% | 0,00% | 100% |  |
| 585 | 2.13.8.2.1 | Envío de Programa de Pruebas | 1d | 2025-05-01 | 2025-05-01 | 542 | 2025-05-01 | 2025-05-01 | 1d | 2025-05-01 | 2025-05-01 | 139d | 0d | ENKI - Días habiles | SATT | 01-05-2025 | 01-05-2025 | 1 día | SATT | 0,00% | 100,00% | 100% | día 637,75 |
| 586 | 2.13.8.2.2 | Revisión de Programa de Pruebas- 1era Iteración | 15d | 2025-05-02 | 2025-05-22 | 585 | 2025-05-02 | 2025-05-22 | 15d | 2025-05-02 | 2025-05-22 | 144d | 0d | ENKI - Días habiles | SATT | 02-05-2025 | 22-05-2025 | 15 días | SATT | 0,00% | 100,00% | 100% | día 638,875 |
| 587 | 2.13.8.2.3 | Respuesta a Observaciones de Programa de Pruebas | 5d | 2025-05-23 | 2025-05-29 | 586 | 2025-05-23 | 2025-05-29 | 5d | 2025-05-23 | 2025-05-29 | 144d | 0d | ENKI - Días habiles | SATT | 23-05-2025 | 29-05-2025 | 5 días | SATT | 0,00% | 100,00% | 100% | día 655,75 |
| 588 | 2.13.8.2.4 | Revisión de Programa de Pruebas - 2da Iteración | 15d | 2025-05-30 | 2025-06-19 | 587 | 2025-05-30 | 2025-06-19 | 15d | 2025-05-30 | 2025-06-19 | 144d | 0d | ENKI - Días habiles | SATT | 30-05-2025 | 19-06-2025 | 15 días | SATT | 0,00% | 100,00% | 100% | día 661,375 |
| 589 | 2.13.8.2.5 | Aprobación de Programa de Pruebas | 1d | 2025-06-20 | 2025-06-20 | 588 | 2025-06-20 | 2025-06-20 | 1d | 2025-06-20 | 2025-06-20 | 144d | 118d | ENKI - Días habiles | SATT | 20-06-2025 | 20-06-2025 | 1 día | SATT | 0,00% | 100,00% | 100% | día 678,25 |

| ID | WBS | Task | Type | Duration | Start | Finish | Predecessors | Baseline start | Baseline finish | Baseline duration | Baseline 1 start | Baseline 1 finish | Total slack | Free slack | Calendar | Propietario | Baseline Star Rev1 | Baseline Finish Rev1 | Baseline Duration Rev1 | : | % Complete Peso | % Baseline Peso | % Baseline (Tempo) | Text11 |
| --- | --- | --- | --- | --- | --- | --- | --- | --- | --- | --- | --- | --- | --- | --- | --- | --- | --- | --- | --- | --- | --- | --- | --- | --- |
| 590 | 2.13.8.3 | **Protocolos SAT Equipos Primarios (PROT E)** |  | 17d | 2025-11-10 | 2025-12-02 |  | 2025-11-10 | 2025-12-02 | 17d | 2025-03-18 | 2025-04-10 | 2d |  | ENKI - Días habiles | SATT | 04-06-2025 | 26-06-2025 | 17 días | SATT | 0,00% | 0,00% | 0% |  |
| 591 | 2.13.8.3.1 | Solicitud de Revisión Protocolos SAT Equipos Primarios |  | 1d | 2025-11-10 | 2025-11-10 | 169, 171, 173, 224, 226, 228, 138, 140, 194, 249 | 2025-11-10 | 2025-11-10 | 1d | 2025-03-18 | 2025-03-19 | 2d | 0d | ENKI - Días habiles | SATT | 04-06-2025 | 04-06-2025 | 1 día | SATT | 0,00% | 0,00% | 0% | día 791,875 |
| 592 | 2.13.8.3.2 | Revisión de Protocolos SAT Equipos Primarios - 1era Iteración |  | 15d | 2025-11-11 | 2025-12-01 | 591 | 2025-11-11 | 2025-12-01 | 15d | 2025-03-19 | 2025-04-09 | 27d | 0d | ENKI - Días habiles | SATT | 05-06-2025 | 25-06-2025 | 15 días | SATT | 0,00% | 0,00% | 0% | día 793 |
| 593 | 2.13.8.3.3 | Protocolos PROT E Aprobados |  | 1d | 2025-12-02 | 2025-12-02 | 592 | 2025-12-02 | 2025-12-02 | 1d | 2025-04-09 | 2025-04-10 | 27d | 1d | ENKI - Días habiles | SATT | 26-06-2025 | 26-06-2025 | 1 día | SATT | 0,00% | 0,00% | 0% | día 809,875 |
| 594 | 2.13.8.4 | **Protocolos Protecciones(PROT P)** |  | 16d | 2025-11-12 | 2025-12-03 |  | 2025-11-12 | 2025-12-03 | 16d | 2025-04-14 | 2025-05-05 | 0d |  | ENKI - Días habiles | SATT | 09-06-2025 | 30-06-2025 | 16 días | SATT | 0,00% | 0,00% | 0% |  |
| 595 | 2.13.8.4.1 | Solicitud de Revisión Protocolos Protecciones |  | 1d | 2025-11-12 | 2025-11-12 | 179, 234, 146, 202, 257 | 2025-11-12 | 2025-11-12 | 1d | 2025-04-14 | 2025-04-14 | 0d |  | ENKI - Días habiles | SATT | 09-06-2025 | 09-06-2025 | 1 día | SATT | 0,00% | 0,00% | 0% | día 794,125 |
| 596 | 2.13.8.4.2 | Revisión de Protocolos Protecciones - 1era Iteración |  | 15d | 2025-11-13 | 2025-12-03 | 595 | 2025-11-13 | 2025-12-03 | 15d | 2025-04-15 | 2025-05-05 | 26d | 0d | ENKI - Días habiles | SATT | 10-06-2025 | 30-06-2025 | 15 días | SATT | 0,00% | 0,00% | 0% | día 795,25 |
| 597 | 2.13.8.4.3 | Protocolos PROT P Aprobados | milestone | 0d | 2025-12-03 | 2025-12-03 | 596 | 2025-12-03 | 2025-12-03 | 0d | 2025-05-05 | 2025-05-05 | 26d | 0d | ENKI - Días habiles | SATT | 30-06-2025 | 30-06-2025 | 0 días | SATT | 0,00% | 0,00% | 0% | día 812,125 |
| 598 | 2.13.8.5 | **Comunicación a la SEC (CARTA SEC)** |  | 15d | 2025-11-24 | 2025-12-12 |  | 2025-11-24 | 2025-12-12 | 15d | 2025-06-27 | 2025-07-18 | 4d |  | ENKI - Días habiles | SATT | 01-07-2025 | 11-08-2025 | 30 días | SATT | 0,00% | 0,00% | 0% |  |
| 599 | 2.13.8.5.1 | Envío de Comunicación a la SEC |  | 1d | 2025-12-04 | 2025-12-04 | 185, 240, 498, 501, 583, 589, 593, 597, 153, 208, 263 | 2025-12-04 | 2025-12-04 | 1d | 2025-06-27 | 2025-06-27 | 26d |  | ENKI - Días habiles | SATT | 01-07-2025 | 01-07-2025 | 1 día | SATT | 0,00% | 0,00% | 0% | día 812,125 |
| 600 | 2.13.8.5.2 | Autorización para PES por parte del CEN |  | 15d | 2025-11-24 | 2025-12-12 | 394SS | 2025-11-24 | 2025-12-12 | 15d | 2025-06-30 | 2025-07-18 | 4d | 0d | ENKI - Días habiles | SATT | 22-07-2025 | 11-08-2025 | 15 días | SATT | 0,00% | 0,00% | 0% | día 803,125 |
| 601 | 2.13.9 | **Entrada en Operación** |  | 259d | 2025-01-09 | 2026-01-06 |  | 2025-01-09 | 2026-01-06 | 259d | 2025-01-09 | 2025-09-02 | 3d |  | ENKI - Días habiles | SATT | 09-01-2025 | 02-09-2025 | 169 días | SATT | 0,00% | 0,00% | 70% |  |
| 602 | 2.13.9.1 | **Infotécnica para Puesta en Servicio (IT PES)** |  | 27d | 2025-01-09 | 2025-02-14 |  | 2025-01-09 | 2025-02-14 | 27d | 2025-01-09 | 2025-02-14 | 218d |  | ENKI - Días habiles | SATT | 09-01-2025 | 14-02-2025 | 27 días | SATT | 0,00% | 0,00% | 100% |  |
| 603 | 2.13.9.1.1 | Solicitud de Verificación de Información Técnica PES - 1era Iteración |  | 1d | 2025-01-09 | 2025-01-09 | 86, 91, 97, 103, 484, 535 | 2025-01-09 | 2025-01-09 | 1d | 2025-01-09 | 2025-01-09 | 218d | 0d | ENKI - Días habiles | SATT | 09-01-2025 | 09-01-2025 | 1 día | SATT | 0,00% | 100,00% | 100% | día 547,75 |
| 604 | 2.13.9.1.2 | Solicitud de Revisión de Completitud PES |  | 5d | 2025-01-10 | 2025-01-16 | 603 | 2025-01-10 | 2025-01-16 | 5d | 2025-01-10 | 2025-01-16 | 218d | 0d | ENKI - Días habiles | SATT | 10-01-2025 | 16-01-2025 | 5 días | SATT | 0,00% | 100,00% | 100% | día 548,875 |
| 605 | 2.13.9.1.3 | Revisión del CEN de Información Técnica PES - 1era Iteración |  | 5d | 2025-01-17 | 2025-01-23 | 604 | 2025-01-17 | 2025-01-23 | 5d | 2025-01-17 | 2025-01-23 | 218d | 0d | ENKI - Días habiles | SATT | 17-01-2025 | 23-01-2025 | 5 días | SATT | 0,00% | 100,00% | 100% | día 554,5 |
| 606 | 2.13.9.1.4 | Respuesta a Observaciones del CEN de IT PES - 1era Iteración |  | 3d | 2025-01-24 | 2025-01-28 | 605 | 2025-01-24 | 2025-01-28 | 3d | 2025-01-24 | 2025-01-28 | 218d | 0d | ENKI - Días habiles | SATT | 24-01-2025 | 28-01-2025 | 3 días | SATT | 0,00% | 100,00% | 100% | día 560,125 |
| 607 | 2.13.9.1.5 | Solicitud de Verificación de Información Técnica PES - 2da Iteración |  | 7d | 2025-01-29 | 2025-02-06 | 606 | 2025-01-29 | 2025-02-06 | 7d | 2025-01-29 | 2025-02-06 | 218d | 0d | ENKI - Días habiles | SATT | 29-01-2025 | 06-02-2025 | 7 días | SATT | 0,00% | 100,00% | 100% | día 563,5 |
| 608 | 2.13.9.1.6 | Revisión de Información Técnica PES - 2da Iteración |  | 5d | 2025-02-07 | 2025-02-13 | 607 | 2025-02-07 | 2025-02-13 | 5d | 2025-02-07 | 2025-02-13 | 218d | 0d | ENKI - Días habiles | SATT | 07-02-2025 | 13-02-2025 | 5 días | SATT | 0,00% | 100,00% | 100% | día 571,375 |
| 609 | 2.13.9.1.7 | Aprobación de IT PES |  | 1d | 2025-02-14 | 2025-02-14 | 608 | 2025-02-14 | 2025-02-14 | 1d | 2025-02-14 | 2025-02-14 | 218d | 185d | ENKI - Días habiles | SATT | 14-02-2025 | 14-02-2025 | 1 día | SATT | 0,00% | 100,00% | 100% | día 577 |
| 610 | 2.13.9.2 | **Print Out Relés Existentes (PO E)** |  | 17d | 2025-11-03 | 2025-11-25 |  | 2025-11-03 | 2025-11-25 | 17d | 2025-07-21 | 2025-08-12 | 33d |  | ENKI - Días habiles | SATT | 01-07-2025 | 23-07-2025 | 17 días | SATT | 0,00% | 0,00% | 0% |  |
| 611 | 2.13.9.2.1 | Solicitud de Revisión de PO Existentes |  | 1d | 2025-11-03 | 2025-11-03 | 600FS-30d, 609 | 2025-11-03 | 2025-11-03 | 1d | 2025-07-21 | 2025-07-21 | 33d | 0d | ENKI - Días habiles | SATT | 01-07-2025 | 01-07-2025 | 1 día | SATT | 0,00% | 0,00% | 0% | día 786,25 |
| 612 | 2.13.9.2.2 | Revisión de Print Out Existentes |  | 15d | 2025-11-04 | 2025-11-24 | 611 | 2025-11-04 | 2025-11-24 | 15d | 2025-07-22 | 2025-08-11 | 33d | 0d | ENKI - Días habiles | SATT | 02-07-2025 | 22-07-2025 | 15 días | SATT | 0,00% | 0,00% | 0% | día 787,375 |
| 613 | 2.13.9.2.3 | Aprobación de PO Existentes |  | 1d | 2025-11-25 | 2025-11-25 | 612 | 2025-11-25 | 2025-11-25 | 1d | 2025-08-12 | 2025-08-12 | 33d |  | ENKI - Días habiles | SATT | 23-07-2025 | 23-07-2025 | 1 día | SATT | 0,00% | 0,00% | 0% | día 804,25 |

| ID | WBS | Task | Duration | Start | Finish | Predecessors | Baseline start | Baseline finish | Baseline duration | Baseline 1 start | Baseline 1 finish | Total slack | Free slack | Calendar | Propietario | Baseline Star Rev1 | Baseline Finish Rev1 | Baseline Duration Rev1 | : | % Complete Peso | % Baseline Peso | % Baseline (Tempo) | Text11 |
| --- | --- | --- | --- | --- | --- | --- | --- | --- | --- | --- | --- | --- | --- | --- | --- | --- | --- | --- | --- | --- | --- | --- | --- |
| 614 | 2.13.9.3 | **Solicitud de entrada en operación (SEO)** | 26d | 2025-12-02 | 2026-01-06 |  | 2025-12-02 | 2026-01-06 | 26d | 2025-08-12 | 2025-09-02 | 3d |  | ENKI - Días habiles | SATT | 12-08-2025 | 02-09-2025 | 16 días | SATT | 0,00% | 0,00% | 0% |  |
| 615 | 2.13.9.3.1 | Solicitud de entrada en operación | 1d | 2025-12-02 | 2025-12-02 | 409SS | 2025-12-02 | 2025-12-02 | 1d | 2025-08-12 | 2025-08-12 | 19d | 0d | ENKI - Días habiles | SATT | 12-08-2025 | 12-08-2025 | 1 día | SATT | 0,00% | 0,00% | 0% | día 809,875 |
| 616 | 2.13.9.3.2 | Carta de respuesta de solicitud de entrada en operación | 8d | 2025-12-03 | 2025-12-12 | 615 | 2025-12-03 | 2025-12-12 | 8d | 2025-08-13 | 2025-09-02 | 19d | 16d | ENKI - Días habiles | SATT | 13-08-2025 | 02-09-2025 | 15 días | SATT | 0,00% | 0,00% | 0% | día 811 |
| 617 | 2.13.9.3.3 | Declaración de Entrada en operación | 1d | 2026-01-06 | 2026-01-06 | 616, 5FS+742d | 2026-01-06 | 2026-01-06 | 1d | 2025-09-02 | 2025-09-02 | 3d |  | ENKI - Días habiles | SATT | 02-09-2025 | 02-09-2025 | 0 días | SATT | 0,00% | 0,00% | 0% | día 838 |
